# AUV Docking 2005

Schedule from MS Project, 2005-01-03 to 2008-12-16, 9 hours a day.
MBARI

## Calendars

- Standard: Mon-Fri 08:00-12:00, 13:00-17:00; Sat-Sun off.

## Resources

| Resource |
| --- |
| AUV Fabricator #1 |
| OSG |
| MA |
| EXT_VENDOR |
| MT |
| EE |
| ET |
| SE |
| ST |
| IAG |
| ME |
| SUE |
| SCI_TECH |
| SYS_ENG |

## Schedule

| ID | WBS | Task | Duration | Start | Finish | Predecessors | Total slack | Free slack | Constraint | Deadline | Work |
| --- | --- | --- | --- | --- | --- | --- | --- | --- | --- | --- | --- |
| 1 | 1 | **AUV Docking Project** | 917.16d? | 2005-01-03 | 2008-12-16 |  | 473.07d |  |  | 2010-12-30 | 10316.6h |
| 2 | 1.1 | **analysis** | 11.56d? | 2005-01-03 | 2005-01-19 |  | 473.07d | 0d |  | 2010-12-30 |  |
| 3 | 1.1.1 | **Define Missions** | 1d? | 2005-01-03 | 2005-01-04 |  | 477.4d | 3.44d |  | 2010-12-30 |  |
| 4 | 1.1.1.1 | Environmental Parameters | 1d? | 2005-01-03 | 2005-01-04 |  | 477.4d |  |  |  |  |
| 5 | 1.1.1.2 | Science Parameters | 1d? | 2005-01-03 | 2005-01-04 |  | 477.4d |  |  |  |  |
| 6 | 1.1.2 | **Define Requirements** | 7.11d | 2005-01-10 | 2005-01-19 | 3 | 473.07d | 0d |  | 2010-12-30 |  |
| 7 | 1.1.2.1 | **Homing from a distance** | 7.11d | 2005-01-10 | 2005-01-19 |  | 473.07d |  |  | 2010-12-30 |  |
| 8 | 1.1.2.1.1 | Identify Reqs | 0.89d | 2005-01-10 | 2005-01-10 |  | 474.84d | 0d | start no earlier than 2005-01-10 | 2010-12-30 |  |
| 9 | 1.1.2.1.2 | Identify method | 0.89d | 2005-01-11 | 2005-01-11 | 8 | 474.84d | 0d | start no earlier than 2005-01-10 | 2010-12-30 |  |
| 10 | 1.1.2.1.3 | Algorithm development | 0.89d | 2005-01-12 | 2005-01-12 | 9 | 474.84d | 0d | start no earlier than 2005-01-10 | 2010-12-30 |  |
| 11 | 1.1.2.1.4 | Modeling | 0.89d | 2005-01-13 | 2005-01-13 | 10 | 474.84d | 0d | start no earlier than 2005-01-10 | 2010-12-30 |  |
| 12 | 1.1.2.1.5 | Integrate on AUV | 0.89d | 2005-01-14 | 2005-01-14 | 11 | 474.84d | 0d | start no earlier than 2005-01-10 | 2010-12-30 |  |
| 13 | 1.1.2.1.6 | Build test platform | 0.89d | 2005-01-17 | 2005-01-17 | 12 | 474.84d |  | start no earlier than 2005-01-10 | 2010-12-30 |  |
| 14 | 1.1.2.1.7 | **Terminal navigation** | 4.44d | 2005-01-11 | 2005-01-17 |  | 473.07d | 0d |  | 2010-12-30 |  |
| 15 | 1.1.2.1.7.1 | Identify Reqs | 0.89d | 2005-01-11 | 2005-01-11 |  | 473.07d | 0d | start no earlier than 2005-01-10 | 2010-12-30 |  |
| 16 | 1.1.2.1.7.2 | Identify method | 0.89d | 2005-01-12 | 2005-01-12 | 15 | 473.07d | 0d | start no earlier than 2005-01-10 | 2010-12-30 |  |
| 17 | 1.1.2.1.7.3 | Algorithm development | 0.89d | 2005-01-13 | 2005-01-13 | 16 | 473.07d | 0d | start no earlier than 2005-01-10 | 2010-12-30 |  |
| 18 | 1.1.2.1.7.4 | Design solution | 0.89d | 2005-01-14 | 2005-01-14 | 17 | 473.07d | 0d | start no earlier than 2005-01-10 | 2010-12-30 |  |
| 19 | 1.1.2.1.7.5 | Prototype | 0.89d | 2005-01-17 | 2005-01-17 | 18 | 473.07d |  | start no earlier than 2005-01-10 | 2010-12-30 |  |
| 20 | 1.1.2.1.8 | Test in tank | 0.89d | 2005-01-18 | 2005-01-18 | 14 | 473.07d | 0d | start no earlier than 2005-01-10 | 2010-12-30 |  |
| 21 | 1.1.2.1.9 | Test at sea | 0.89d | 2005-01-19 | 2005-01-19 | 20 | 473.07d |  | start no earlier than 2005-01-10 | 2010-12-30 |  |
| 22 | 1.1.2.2 | **Data transfer** | 0.89d | 2005-01-11 | 2005-01-11 |  | 478.4d |  |  | 2010-12-30 |  |
| 23 | 1.1.2.2.1 | Identify Reqs | 0.89d | 2005-01-11 | 2005-01-11 |  | 478.4d |  | start no earlier than 2005-01-10 | 2010-12-30 |  |
| 24 | 1.1.2.2.2 | Identify method | 0.89d | 2005-01-11 | 2005-01-11 |  | 478.4d |  | start no earlier than 2005-01-10 | 2010-12-30 |  |
| 25 | 1.1.2.2.3 | Build prototype/int. COTS | 0.89d | 2005-01-11 | 2005-01-11 |  | 478.4d |  | start no earlier than 2005-01-10 | 2010-12-30 |  |

Notes:
- 7: MS
- 8: MS
- 9: MS
- 10: MS
- 11: MS
- 12: MS
- 13: MS
- 14: MS
- 15: MS
- 16: MS
- 17: MS
- 18: MS
- 19: MS
- 20: MS
- 21: MS
- 22: MS
- 23: MS
- 24: MS
- 25: MS

| ID | WBS | Task | Duration | Start | Finish | Predecessors | Total slack | Free slack | Constraint | Deadline |
| --- | --- | --- | --- | --- | --- | --- | --- | --- | --- | --- |
| 26 | 1.1.2.3 | **Power transfer** | 1.78d | 2005-01-11 | 2005-01-12 |  | 477.51d | 4.44d |  | 2010-12-30 |
| 27 | 1.1.2.3.1 | Identify Reqs | 0.89d | 2005-01-11 | 2005-01-11 |  | 477.51d | 0d | start no earlier than 2005-01-10 | 2010-12-30 |
| 28 | 1.1.2.3.2 | Identify method | 0.89d | 2005-01-12 | 2005-01-12 | 27 | 477.51d |  | start no earlier than 2005-01-10 | 2010-12-30 |
| 29 | 1.1.2.4 | **Latching system** | 4.44d | 2005-01-11 | 2005-01-17 |  | 474.84d | 1.78d |  | 2010-12-30 |
| 30 | 1.1.2.4.1 | Identify method | 0.89d | 2005-01-11 | 2005-01-11 |  | 478.4d |  | start no earlier than 2005-01-10 | 2010-12-30 |
| 31 | 1.1.2.4.2 | **Capturing mech. system (cage/cone/etc.)** | 4.44d | 2005-01-11 | 2005-01-17 |  | 474.84d |  |  | 2010-12-30 |
| 32 | 1.1.2.4.2.1 | Concept design | 0.89d | 2005-01-11 | 2005-01-11 |  | 474.84d | 0d | start no earlier than 2005-01-10 | 2010-12-30 |
| 33 | 1.1.2.4.2.2 | PDR | 0.89d | 2005-01-12 | 2005-01-12 | 32 | 474.84d | 0d | start no earlier than 2005-01-10 | 2010-12-30 |
| 34 | 1.1.2.4.2.3 | Detailed design | 0.89d | 2005-01-13 | 2005-01-13 | 33 | 474.84d | 0d | start no earlier than 2005-01-10 | 2010-12-30 |
| 35 | 1.1.2.4.2.4 | Build | 0.89d | 2005-01-14 | 2005-01-14 | 34 | 474.84d | 0d | start no earlier than 2005-01-10 | 2010-12-30 |
| 36 | 1.1.2.4.2.5 | Test in tank | 0.89d | 2005-01-17 | 2005-01-17 | 35 | 474.84d |  | start no earlier than 2005-01-10 | 2010-12-30 |
| 37 | 1.1.2.5 | **Acomms** | 2.67d | 2005-01-11 | 2005-01-13 |  | 476.62d | 3.56d |  | 2010-12-30 |
| 38 | 1.1.2.5.1 | Identify Reqs | 0.89d | 2005-01-11 | 2005-01-11 |  | 476.62d | 0d | start no earlier than 2005-01-10 | 2010-12-30 |
| 39 | 1.1.2.5.2 | Collaborate with mapping AUV | 0.89d | 2005-01-12 | 2005-01-12 | 38 | 476.62d | 0d | start no earlier than 2005-01-10 | 2010-12-30 |
| 40 | 1.1.2.5.3 | Identify protocol | 0.89d | 2005-01-13 | 2005-01-13 | 39 | 476.62d |  | start no earlier than 2005-01-10 | 2010-12-30 |
| 41 | 1.1.2.6 | **Sensor reliability** | 0.89d | 2005-01-11 | 2005-01-11 |  | 478.4d | 5.33d |  | 2010-12-30 |
| 42 | 1.1.2.6.1 | How long before sensor re-calibration | 0.89d | 2005-01-11 | 2005-01-11 |  | 478.4d |  | start no earlier than 2005-01-10 | 2010-12-30 |
| 43 | 1.1.2.6.2 | How long before biofouling? | 0.89d | 2005-01-11 | 2005-01-11 |  | 478.4d |  | start no earlier than 2005-01-10 | 2010-12-30 |
| 44 | 1.1.2.7 | **Host network connection (MOOS/MARS)** | 1.78d | 2005-01-11 | 2005-01-12 |  | 477.51d | 4.44d |  | 2010-12-30 |
| 45 | 1.1.2.7.1 | Specify req's | 0.89d | 2005-01-11 | 2005-01-11 |  | 477.51d | 0d | start no earlier than 2005-01-10 | 2010-12-30 |
| 46 | 1.1.2.7.2 | Specifiy protocol | 0.89d | 2005-01-12 | 2005-01-12 | 45 | 477.51d |  | start no earlier than 2005-01-10 | 2010-12-30 |
| 47 | 1.1.2.8 | **Sensor interface (CANbrick)** | 1.78d | 2005-01-11 | 2005-01-12 |  | 477.51d |  |  | 2010-12-30 |
| 48 | 1.1.2.8.1 | Prototype development | 0.89d | 2005-01-11 | 2005-01-11 |  | 477.51d | 0d | start no earlier than 2005-01-10 | 2010-12-30 |
| 49 | 1.1.2.8.2 | Vehicle interconnect concept | 0.89d | 2005-01-12 | 2005-01-12 | 48 | 477.51d |  | start no earlier than 2005-01-10 | 2010-12-30 |

Notes:
- 26: MS
- 27: MS
- 28: MS
- 29: MS
- 30: MS
- 31: MS
- 32: MS
- 33: MS
- 34: MS
- 35: MS
- 36: MS
- 37: MS
- 38: MS
- 39: MS
- 40: MS
- 41: MS
- 42: MS
- 43: MS
- 44: MS
- 45: MS
- 46: MS
- 47: MS
- 48: MS
- 49: MS

| ID | WBS | Task | Duration | Start | Finish | Predecessors | Total slack | Free slack | Constraint | Deadline | Work |
| --- | --- | --- | --- | --- | --- | --- | --- | --- | --- | --- | --- |
| 50 | 1.2 | **AUV** | 28.11d? | 2005-01-20 | 2005-03-04 | 6 | 512.29d |  |  | 2010-12-30 | 956.25h |
| 51 | 1.2.1 | **design** | 3.56d? | 2005-01-20 | 2005-01-25 |  | 512.29d | 0d |  | 2010-12-30 |  |
| 52 | 1.2.1.1 | **Communications** | 1d? | 2005-01-20 | 2005-01-21 | 37, 41, 44 | 514.84d |  |  | 2010-12-30 |  |
| 53 | 1.2.1.1.1 | Integrate acoustic modem on AUV | 0.89d | 2005-01-20 | 2005-01-20 |  | 514.96d |  | start no earlier than 2005-01-10 | 2010-12-30 |  |
| 54 | 1.2.1.1.2 | Integrate network comm device | 1d? | 2005-01-20 | 2005-01-21 |  | 514.84d |  |  | 2010-12-30 |  |
| 55 | 1.2.1.2 | **Fairing, Frame, Housing** | 0.89d | 2005-01-20 | 2005-01-20 | 29 | 514.96d |  |  | 2010-12-30 |  |
| 56 | 1.2.1.2.1 | Prototype Latch | 0.89d | 2005-01-20 | 2005-01-20 |  | 514.96d |  | start no earlier than 2005-01-10 | 2010-12-30 |  |
| 57 | 1.2.1.2.2 | Integrate latch onto AUV | 0.89d | 2005-01-20 | 2005-01-20 |  | 514.96d |  | start no earlier than 2005-01-10 | 2010-12-30 |  |
| 58 | 1.2.1.3 | **Guidance navigation and Control** | 0.89d | 2005-01-20 | 2005-01-20 |  | 514.96d |  |  | 2010-12-30 |  |
| 59 | 1.2.1.3.1 | **Obstacle Avoidance** | 0.89d | 2005-01-20 | 2005-01-20 |  | 514.96d |  |  | 2010-12-30 |  |
| 60 | 1.2.1.3.1.1 | Algorithm development | 0.89d | 2005-01-20 | 2005-01-20 |  | 514.96d |  | start no earlier than 2005-01-10 | 2010-12-30 |  |
| 61 | 1.2.1.3.1.2 | Tests at sea | 0.89d | 2005-01-20 | 2005-01-20 |  | 514.96d |  | start no earlier than 2005-01-10 | 2010-12-30 |  |
| 62 | 1.2.1.4 | Location Devices | 1d? | 2005-01-20 | 2005-01-21 |  | 514.84d |  |  | 2010-12-30 |  |
| 63 | 1.2.1.5 | Propulsion and control surfaces | 1d? | 2005-01-20 | 2005-01-21 |  | 514.84d |  |  | 2010-12-30 |  |
| 64 | 1.2.1.6 | **Wet Cables and Connectors** | 0.89d | 2005-01-20 | 2005-01-20 | 26 | 514.96d |  |  | 2010-12-30 |  |
| 65 | 1.2.1.6.1 | Build prototype/int. COTS | 0.89d | 2005-01-20 | 2005-01-20 |  | 514.96d |  | start no earlier than 2005-01-10 | 2010-12-30 |  |
| 66 | 1.2.1.7 | **Power** | 0.89d | 2005-01-20 | 2005-01-20 | 26 | 514.96d |  |  | 2010-12-30 |  |
| 67 | 1.2.1.7.1 | Build prototype/int. COTS | 0.89d | 2005-01-20 | 2005-01-20 |  | 514.96d |  | start no earlier than 2005-01-10 | 2010-12-30 |  |
| 68 | 1.2.1.8 | **AUV reliability** | 3.56d | 2005-01-20 | 2005-01-25 |  | 512.29d |  |  | 2010-12-30 |  |
| 69 | 1.2.1.8.1 | **Battery reliability** | 3.56d | 2005-01-20 | 2005-01-25 | 26 | 512.29d |  |  | 2010-12-30 |  |
| 70 | 1.2.1.8.1.1 | Cell balancing | 0.89d | 2005-01-20 | 2005-01-20 |  | 512.29d | 0d | start no earlier than 2005-01-10 | 2010-12-30 |  |
| 71 | 1.2.1.8.1.2 | Oil conservation | 0.89d | 2005-01-21 | 2005-01-21 | 70 | 512.29d | 0d | start no earlier than 2005-01-10 | 2010-12-30 |  |
| 72 | 1.2.1.8.1.3 | Auto battery recharge | 0.89d | 2005-01-24 | 2005-01-24 | 71 | 512.29d | 0d | start no earlier than 2005-01-10 | 2010-12-30 |  |
| 73 | 1.2.1.8.1.4 | Tank test for 96 hours | 0.89d | 2005-01-25 | 2005-01-25 | 72 | 512.29d |  | start no earlier than 2005-01-10 | 2010-12-30 |  |

Notes:
- 50: MS
- 53: MS
- 56: MS
- 57: MS
- 59: MS
- 60: MS
- 61: MS
- 65: MS
- 67: MS
- 68: MS
- 69: MS
- 70: MS
- 71: MS
- 72: MS
- 73: MS

| ID | WBS | Task | Type | Duration | Start | Finish | Predecessors | Total slack | Free slack | Constraint | Deadline | Resources | Work |
| --- | --- | --- | --- | --- | --- | --- | --- | --- | --- | --- | --- | --- | --- |
| 74 | 1.2.1.8.2 | **Tailcone reliability** |  | 1.78d | 2005-01-20 | 2005-01-21 |  | 514.07d |  |  | 2010-12-30 |  |  |
| 75 | 1.2.1.8.2.1 | Prop seal life |  | 0.89d | 2005-01-20 | 2005-01-20 |  | 514.07d | 0d | start no earlier than 2005-01-10 | 2010-12-30 |  |  |
| 76 | 1.2.1.8.2.2 | Lin act pot life |  | 0.89d | 2005-01-21 | 2005-01-21 | 75 | 514.07d |  | start no earlier than 2005-01-10 | 2010-12-30 |  |  |
| 77 | 1.2.1.8.3 | **Connector reliability** |  | 1.78d | 2005-01-20 | 2005-01-21 |  | 514.07d |  |  | 2010-12-30 |  |  |
| 78 | 1.2.1.8.3.1 | Ground fault detection |  | 0.89d | 2005-01-20 | 2005-01-20 |  | 514.07d | 0d | start no earlier than 2005-01-10 | 2010-12-30 |  |  |
| 79 | 1.2.1.8.3.2 | O-ring life |  | 0.89d | 2005-01-21 | 2005-01-21 | 78 | 514.07d |  | start no earlier than 2005-01-10 | 2010-12-30 |  |  |
| 80 | 1.2.1.8.4 | **Software reliability** |  | 1.78d | 2005-01-20 | 2005-01-21 |  | 514.07d |  |  | 2010-12-30 |  |  |
| 81 | 1.2.1.8.4.1 | Auto-reboot after docking |  | 0.89d | 2005-01-20 | 2005-01-20 |  | 514.07d | 0d | start no earlier than 2005-01-10 | 2010-12-30 |  |  |
| 82 | 1.2.1.8.4.2 | Tank test for 96 hours |  | 0.89d | 2005-01-21 | 2005-01-21 | 81 | 514.07d |  | start no earlier than 2005-01-10 | 2010-12-30 |  |  |
| 85 | 1.2.2 | design review | milestone | 3.56d | 2005-01-26 | 2005-01-31 | 51 | 512.29d | 0d |  | 2010-12-30 |  |  |
| 86 | 1.2.3 | **purchasing** |  | 1d? | 2005-02-01 | 2005-02-02 | 85 | 1350.56d | 0d |  | 2010-12-30 |  |  |
| 87 | 1.2.3.1 | quote and order Fairings |  | 1d? | 2005-02-01 | 2005-02-02 |  | 1350.56d |  | start no earlier than 2005-01-10 | 2010-12-30 |  |  |
| 88 | 1.2.4 | **fab** |  | 2d | 2005-02-02 | 2005-02-04 | 86 | 1350.56d | 0d |  | 2010-12-30 |  | 207h |
| 89 | 1.2.4.1 | **AUV Fabrication** |  | 2d | 2005-02-02 | 2005-02-04 |  | 1350.56d |  |  | 2010-12-30 |  | 207h |
| 90 | 1.2.4.1.1 | **SubSystem Ordering/Fabrication** |  | 2d | 2005-02-02 | 2005-02-04 |  | 1350.56d |  |  | 2010-12-30 | AUV Fabricator #1 | 207h |
| 91 | 1.2.4.1.1.1 | **Pressure Vessel Fabrication** |  | 0.5d | 2005-02-02 | 2005-02-02 |  | 1352.06d |  |  | 2010-12-30 | AUV Fabricator #1 | 27h |
| 92 | 1.2.4.1.1.1.1 | **MVC Sphere** |  | 0.5d | 2005-02-02 | 2005-02-02 |  | 1352.06d |  |  | 2010-12-30 | AUV Fabricator #1 | 11.25h |
| 93 | 1.2.4.1.1.1.1.1 | Quoting & Ordering Benthos sphere |  | 0.25d | 2005-02-02 | 2005-02-02 |  | 1352.31d |  | start no earlier than 2005-01-10 | 2010-12-30 | AUV Fabricator #1 | 2.25h |
| 94 | 1.2.4.1.1.1.1.2 | Penetrator/dummy kitting for pressure test |  | 0.5d | 2005-02-02 | 2005-02-02 |  | 1352.06d |  | start no earlier than 2005-01-10 | 2010-12-30 | AUV Fabricator #1 | 4.5h |
| 95 | 1.2.4.1.1.1.2 | **Nose DCON** |  | 0.5d | 2005-02-02 | 2005-02-02 |  | 1352.06d |  |  | 2010-12-30 | AUV Fabricator #1 | 11.25h |
| 96 | 1.2.4.1.1.1.2.1 | Quoting & ordering housing |  | 0.25d | 2005-02-02 | 2005-02-02 |  | 1352.31d |  | start no earlier than 2005-01-10 | 2010-12-30 | AUV Fabricator #1 | 2.25h |
| 97 | 1.2.4.1.1.1.2.2 | Penetrator/dummy kitting for pressure test |  | 0.5d | 2005-02-02 | 2005-02-02 |  | 1352.06d |  | start no earlier than 2005-01-10 | 2010-12-30 | AUV Fabricator #1 | 4.5h |
| 98 | 1.2.4.1.1.2 | **Fairing Fabrication/Holes** |  | 1d | 2005-02-02 | 2005-02-03 |  | 1351.56d |  |  | 2010-12-30 | AUV Fabricator #1 | 36h |
| 99 | 1.2.4.1.1.2.1 | Tail Fairing |  | 1d | 2005-02-02 | 2005-02-03 |  | 1351.56d |  | start no earlier than 2005-01-10 | 2010-12-30 | AUV Fabricator #1 | 9h |
| 100 | 1.2.4.1.1.2.2 | Nose Fairing |  | 1d | 2005-02-02 | 2005-02-03 |  | 1351.56d |  | start no earlier than 2005-01-10 | 2010-12-30 | AUV Fabricator #1 | 9h |
| 101 | 1.2.4.1.1.2.3 | MidSection Faiiring |  | 1d | 2005-02-02 | 2005-02-03 |  | 1351.56d |  | start no earlier than 2005-01-10 | 2010-12-30 | AUV Fabricator #1 | 9h |

Notes:
- 74: MS
- 75: MS
- 76: MS
- 77: MS
- 78: MS
- 79: MS
- 80: MS
- 81: MS
- 82: MS
- 85: Bouy
- 89: HT
- 90: HT
- 91: HT
- 92: HT
- 93: HT
- 94: HT
- 95: HT
- 96: HT
- 97: HT
- 98: HT
- 99: HT
- 100: HT
- 101: HT

| ID | WBS | Task | Type | Duration | Start | Finish | Total slack | Constraint | Deadline | Resources | Work |
| --- | --- | --- | --- | --- | --- | --- | --- | --- | --- | --- | --- |
| 102 | 1.2.4.1.1.3 | **Wet Cabling Fabrication** |  | 0.5d | 2005-02-02 | 2005-02-02 | 1352.06d |  | 2010-12-30 | AUV Fabricator #1 | 58.05h |
| 103 | 1.2.4.1.1.3.1 | C/F Kitting for Seaconn |  | 0.5d | 2005-02-02 | 2005-02-02 | 1352.06d | start no earlier than 2005-01-10 | 2010-12-30 | AUV Fabricator #1 | 4.5h |
| 104 | 1.2.4.1.1.3.2 | C/F Kitting for Subconn |  | 0.5d | 2005-02-02 | 2005-02-02 | 1352.06d | start no earlier than 2005-01-10 | 2010-12-30 | AUV Fabricator #1 | 4.5h |
| 105 | 1.2.4.1.1.3.3 | C/F Kitting for Burton |  | 0.5d | 2005-02-02 | 2005-02-02 | 1352.06d | start no earlier than 2005-01-10 | 2010-12-30 | AUV Fabricator #1 | 4.5h |
| 106 | 1.2.4.1.1.3.4 | C/F Kitting for Impulse |  | 0.5d | 2005-02-02 | 2005-02-02 | 1352.06d | start no earlier than 2005-01-10 | 2010-12-30 | AUV Fabricator #1 | 4.5h |
| 107 | 1.2.4.1.1.3.5 | MVC Forward Bus Cable |  | 0.1d | 2005-02-02 | 2005-02-02 | 1352.46d | start no earlier than 2005-01-10 | 2010-12-30 | AUV Fabricator #1 | 0.9h |
| 108 | 1.2.4.1.1.3.6 | MVC Shore Tether Cable |  | 0.05d | 2005-02-02 | 2005-02-02 | 1352.51d | start no earlier than 2005-01-10 | 2010-12-30 | AUV Fabricator #1 | 0.45h |
| 109 | 1.2.4.1.1.3.7 | MVC/TailCone Cable |  | 0.05d | 2005-02-02 | 2005-02-02 | 1352.51d | start no earlier than 2005-01-10 | 2010-12-30 | AUV Fabricator #1 | 0.45h |
| 110 | 1.2.4.1.1.3.8 | MVC/DVL Cable |  | 0.05d | 2005-02-02 | 2005-02-02 | 1352.51d | start no earlier than 2005-01-10 | 2010-12-30 | AUV Fabricator #1 | 0.45h |
| 111 | 1.2.4.1.1.3.9 | MVC/Pressure Sensor Cable |  | 0.05d | 2005-02-02 | 2005-02-02 | 1352.51d | start no earlier than 2005-01-10 | 2010-12-30 | AUV Fabricator #1 | 0.45h |
| 112 | 1.2.4.1.1.3.10 | Battery JBOX Aft Cable |  | 0.05d | 2005-02-02 | 2005-02-02 | 1352.51d | start no earlier than 2005-01-10 | 2010-12-30 | AUV Fabricator #1 | 0.45h |
| 113 | 1.2.4.1.1.3.11 | Battery JBOX Forward Cable |  | 0.05d | 2005-02-02 | 2005-02-02 | 1352.51d | start no earlier than 2005-01-10 | 2010-12-30 | AUV Fabricator #1 | 0.45h |
| 114 | 1.2.4.1.1.3.12 | Science DCON Aft Cable |  | 0.05d | 2005-02-02 | 2005-02-02 | 1352.51d | start no earlier than 2005-01-10 | 2010-12-30 | AUV Fabricator #1 | 0.45h |
| 115 | 1.2.4.1.1.3.13 | CTD1 Cable |  | 0.5d | 2005-02-02 | 2005-02-02 | 1352.06d | start no earlier than 2005-01-10 | 2010-12-30 | AUV Fabricator #1 | 4.5h |
| 116 | 1.2.4.1.1.3.14 | CTD2 Cable |  | 0.5d | 2005-02-02 | 2005-02-02 | 1352.06d | start no earlier than 2005-01-10 | 2010-12-30 | AUV Fabricator #1 | 4.5h |
| 117 | 1.2.4.1.1.3.15 | DO Sensor Cable |  | 0.5d | 2005-02-02 | 2005-02-02 | 1352.06d | start no earlier than 2005-01-10 | 2010-12-30 | AUV Fabricator #1 | 4.5h |
| 118 | 1.2.4.1.1.3.16 | ISUS Cable |  | 0.5d | 2005-02-02 | 2005-02-02 | 1352.06d | start no earlier than 2005-01-10 | 2010-12-30 | AUV Fabricator #1 | 4.5h |
| 119 | 1.2.4.1.1.3.17 | Flow Sensor Cable |  | 0.5d | 2005-02-02 | 2005-02-02 | 1352.06d | start no earlier than 2005-01-10 | 2010-12-30 | AUV Fabricator #1 | 4.5h |
| 120 | 1.2.4.1.1.3.18 | Biolume Cable |  | 0.5d | 2005-02-02 | 2005-02-02 | 1352.06d | start no earlier than 2005-01-10 | 2010-12-30 | AUV Fabricator #1 | 4.5h |
| 121 | 1.2.4.1.1.3.19 | LISST Cable |  | 0.5d | 2005-02-02 | 2005-02-02 | 1352.06d | start no earlier than 2005-01-10 | 2010-12-30 | AUV Fabricator #1 | 4.5h |
| 122 | 1.2.4.1.1.4 | **Syntactic Fabrication** |  | 0.25d | 2005-02-02 | 2005-02-02 | 1352.31d |  | 2010-12-30 | AUV Fabricator #1 | 6.75h |
| 123 | 1.2.4.1.1.4.1 | Drawing Package Preparation |  | 0.25d | 2005-02-02 | 2005-02-02 | 1352.31d | start no earlier than 2005-01-10 | 2010-12-30 | AUV Fabricator #1 | 2.25h |
| 124 | 1.2.4.1.1.4.2 | Vendor Quoting/Contracting |  | 0.25d | 2005-02-02 | 2005-02-02 | 1352.31d | start no earlier than 2005-01-10 | 2010-12-30 | AUV Fabricator #1 | 2.25h |
| 125 | 1.2.4.1.1.4.3 | Syntactic Module Fabrication | milestone | 0d | 2005-02-02 | 2005-02-02 | 1352.56d | start no earlier than 2005-01-10 | 2010-12-30 | AUV Fabricator #1 |  |

Notes:
- 102: HT
- 103: HT
- 104: HT
- 105: HT
- 106: HT
- 107: HT
- 108: HT
- 109: HT
- 110: HT
- 111: HT
- 112: HT
- 113: HT
- 114: HT
- 115: HT
- 116: HT
- 117: HT
- 118: HT
- 119: HT
- 120: HT
- 121: HT
- 122: HT
- 123: HT
- 124: HT
- 125: HT

| ID | WBS | Task | Duration | Start | Finish | Predecessors | Total slack | Free slack | Constraint | Deadline | Resources | Work |
| --- | --- | --- | --- | --- | --- | --- | --- | --- | --- | --- | --- | --- |
| 126 | 1.2.4.1.1.5 | **Custom Printed Circuit Board Fabrication** | 2d | 2005-02-02 | 2005-02-04 |  | 1350.56d |  |  | 2010-12-30 | AUV Fabricator #1 | 61.2h |
| 127 | 1.2.4.1.1.5.1 | **MVC Power Board Fabrication** | 2d | 2005-02-02 | 2005-02-04 |  | 1350.56d |  |  | 2010-12-30 | AUV Fabricator #1 | 42.75h |
| 128 | 1.2.4.1.1.5.1.1 | Component ordering | 0.25d | 2005-02-02 | 2005-02-02 |  | 1352.31d |  | start no earlier than 2005-01-10 | 2010-12-30 | AUV Fabricator #1 | 2.25h |
| 129 | 1.2.4.1.1.5.1.2 | Component installation | 2d | 2005-02-02 | 2005-02-04 |  | 1350.56d |  | start no earlier than 2005-01-10 | 2010-12-30 | AUV Fabricator #1 | 18h |
| 130 | 1.2.4.1.1.5.1.3 | Burn-in & test | 0.5d | 2005-02-02 | 2005-02-02 |  | 1352.06d |  | start no earlier than 2005-01-10 | 2010-12-30 | AUV Fabricator #1 | 4.5h |
| 131 | 1.2.4.1.1.5.2 | Junction Box PCB Fabrication | 0.05d | 2005-02-02 | 2005-02-02 |  | 1352.51d |  | start no earlier than 2005-01-10 | 2010-12-30 | AUV Fabricator #1 | 0.45h |
| 132 | 1.2.5 | **assembly** | 1d? | 2005-02-04 | 2005-02-07 | 88 | 1350.56d | 0d |  | 2010-12-30 |  |  |
| 133 | 1.2.5.1 | AUV | 1d? | 2005-02-04 | 2005-02-07 |  | 1350.56d |  | start no earlier than 2005-01-10 | 2010-12-30 |  |  |
| 134 | 1.2.6 | **Integration and Test** | 15d? | 2005-02-07 | 2005-03-02 | 132 | 1350.56d | 0d |  | 2010-12-30 |  | 749.25h |
| 135 | 1.2.6.1 | **Tail Section Electrical/Mechanical Integration & Test** | 5d | 2005-02-07 | 2005-02-15 |  | 1360.56d |  |  | 2010-12-30 | AUV Fabricator #1 | 425.25h |
| 136 | 1.2.6.1.1 | **Tail Bracketry Fabrication** | 4d | 2005-02-07 | 2005-02-11 |  | 1361.56d |  |  | 2010-12-30 | AUV Fabricator #1 | 126h |
| 137 | 1.2.6.1.1.1 | Forward Plate | 1d | 2005-02-07 | 2005-02-08 |  | 1364.56d |  | start no earlier than 2005-01-10 | 2010-12-30 | AUV Fabricator #1 | 9h |
| 138 | 1.2.6.1.1.2 | Bottom Plate | 2d | 2005-02-07 | 2005-02-09 |  | 1363.56d |  | start no earlier than 2005-01-10 | 2010-12-30 | AUV Fabricator #1 | 18h |
| 139 | 1.2.6.1.1.3 | Aft Plate | 1d | 2005-02-07 | 2005-02-08 |  | 1364.56d |  | start no earlier than 2005-01-10 | 2010-12-30 | AUV Fabricator #1 | 9h |
| 140 | 1.2.6.1.1.4 | Mounting Clamps (DVL,parosci,homerpro,xpndr) | 4d | 2005-02-07 | 2005-02-11 |  | 1361.56d |  | start no earlier than 2005-01-10 | 2010-12-30 | AUV Fabricator #1 | 36h |
| 141 | 1.2.6.1.1.5 | Antenna/strobe mount | 2d | 2005-02-07 | 2005-02-09 |  | 1363.56d |  | start no earlier than 2005-01-10 | 2010-12-30 | AUV Fabricator #1 | 18h |
| 142 | 1.2.6.1.2 | Propulsion Integration/Installation | 5d | 2005-02-07 | 2005-02-15 |  | 1360.56d |  | start no earlier than 2005-01-10 | 2010-12-30 | AUV Fabricator #1 | 45h |
| 143 | 1.2.6.1.3 | **MVC Sphere/Dry Integation** | 5d | 2005-02-07 | 2005-02-15 |  | 1360.56d |  |  | 2010-12-30 | AUV Fabricator #1 | 171h |
| 144 | 1.2.6.1.3.1 | Threaded Insert Frame Fabrication | 1d | 2005-02-07 | 2005-02-08 |  | 1364.56d |  | start no earlier than 2005-01-10 | 2010-12-30 | AUV Fabricator #1 | 9h |
| 145 | 1.2.6.1.3.2 | Urethane Base Molding | 1d | 2005-02-07 | 2005-02-08 |  | 1364.56d |  | start no earlier than 2005-01-10 | 2010-12-30 | AUV Fabricator #1 | 9h |
| 146 | 1.2.6.1.3.3 | Mounting Plate Installation | 1d | 2005-02-07 | 2005-02-08 |  | 1364.56d |  | start no earlier than 2005-01-10 | 2010-12-30 | AUV Fabricator #1 | 9h |
| 147 | 1.2.6.1.3.4 | PC104 Stack Intallation | 0.25d | 2005-02-07 | 2005-02-07 |  | 1365.31d |  | start no earlier than 2005-01-10 | 2010-12-30 | AUV Fabricator #1 | 2.25h |
| 148 | 1.2.6.1.3.5 | Novatech Installation | 0.25d | 2005-02-07 | 2005-02-07 |  | 1365.31d |  | start no earlier than 2005-01-10 | 2010-12-30 | AUV Fabricator #1 | 2.25h |
| 149 | 1.2.6.1.3.6 | GPS Installation | 0.25d | 2005-02-07 | 2005-02-07 |  | 1365.31d |  | start no earlier than 2005-01-10 | 2010-12-30 | AUV Fabricator #1 | 2.25h |
| 150 | 1.2.6.1.3.7 | Heading Reference Installation | 0.25d | 2005-02-07 | 2005-02-07 |  | 1365.31d |  | start no earlier than 2005-01-10 | 2010-12-30 | AUV Fabricator #1 | 2.25h |
| 151 | 1.2.6.1.3.8 | RF Penetrator Installation/Wiring | 0.5d | 2005-02-07 | 2005-02-08 |  | 1365.06d |  | start no earlier than 2005-01-10 | 2010-12-30 | AUV Fabricator #1 | 4.5h |
| 152 | 1.2.6.1.3.9 | MINK Penetrator Installation/Wiring | 2d | 2005-02-07 | 2005-02-09 |  | 1363.56d |  | start no earlier than 2005-01-10 | 2010-12-30 | AUV Fabricator #1 | 18h |
| 153 | 1.2.6.1.3.10 | LPBH Installation/Wiring | 2d | 2005-02-07 | 2005-02-09 |  | 1363.56d |  | start no earlier than 2005-01-10 | 2010-12-30 | AUV Fabricator #1 | 18h |
| 154 | 1.2.6.1.3.11 | MVC Power Board Installation | 0.5d | 2005-02-07 | 2005-02-08 |  | 1365.06d |  | start no earlier than 2005-01-10 | 2010-12-30 | AUV Fabricator #1 | 4.5h |
| 155 | 1.2.6.1.3.12 | Point-to-Point Wiring Installation | 5d | 2005-02-07 | 2005-02-15 |  | 1360.56d |  | start no earlier than 2005-01-10 | 2010-12-30 | AUV Fabricator #1 | 45h |

Notes:
- 126: HT
- 127: HT
- 128: HT
- 129: HT
- 130: HT
- 131: HT
- 135: HT
- 136: HT
- 137: HT
- 138: HT
- 139: HT
- 140: HT
- 141: HT
- 142: HT
- 143: HT
- 144: HT
- 145: HT
- 146: HT
- 147: HT
- 148: HT
- 149: HT
- 150: HT
- 151: HT
- 152: HT
- 153: HT
- 154: HT
- 155: HT

| ID | WBS | Task | Duration | Start | Finish | Predecessors | Total slack | Free slack | Constraint | Deadline | Resources | Work |
| --- | --- | --- | --- | --- | --- | --- | --- | --- | --- | --- | --- | --- |
| 156 | 1.2.6.1.4 | **Mechanical/Wet Integration** | 1d | 2005-02-07 | 2005-02-08 |  | 1364.56d |  |  | 2010-12-30 | AUV Fabricator #1 | 27h |
| 157 | 1.2.6.1.4.1 | Mount Sphere to base plate | 1d | 2005-02-07 | 2005-02-08 |  | 1364.56d |  | start no earlier than 2005-01-10 | 2010-12-30 | AUV Fabricator #1 | 9h |
| 158 | 1.2.6.1.4.2 | Mount/cable Parosci, HomerPro | 0.25d | 2005-02-07 | 2005-02-07 |  | 1365.31d |  | start no earlier than 2005-01-10 | 2010-12-30 | AUV Fabricator #1 | 2.25h |
| 159 | 1.2.6.1.4.3 | Mount USBL Beacon/Transducer | 0.25d | 2005-02-07 | 2005-02-07 |  | 1365.31d |  | start no earlier than 2005-01-10 | 2010-12-30 | AUV Fabricator #1 | 2.25h |
| 160 | 1.2.6.1.4.4 | Mount/Cable DVL | 0.25d | 2005-02-07 | 2005-02-07 |  | 1365.31d |  | start no earlier than 2005-01-10 | 2010-12-30 | AUV Fabricator #1 | 2.25h |
| 161 | 1.2.6.1.4.5 | Syntactic Installation | 0.25d | 2005-02-07 | 2005-02-07 |  | 1365.31d |  | start no earlier than 2005-01-10 | 2010-12-30 | AUV Fabricator #1 | 2.25h |
| 162 | 1.2.6.1.5 | **Functional test of Tail Section sub-systems** | 0.25d | 2005-02-07 | 2005-02-07 |  | 1365.31d |  |  | 2010-12-30 | AUV Fabricator #1 | 11.25h |
| 163 | 1.2.6.1.5.1 | Tailcone Calibration | 0.25d | 2005-02-07 | 2005-02-07 |  | 1365.31d |  | start no earlier than 2005-01-10 | 2010-12-30 | AUV Fabricator #1 | 2.25h |
| 164 | 1.2.6.1.5.2 | DVL Comms and Rub Test | 0.25d | 2005-02-07 | 2005-02-07 |  | 1365.31d |  | start no earlier than 2005-01-10 | 2010-12-30 | AUV Fabricator #1 | 2.25h |
| 165 | 1.2.6.1.5.3 | Parosci Test | 0.25d | 2005-02-07 | 2005-02-07 |  | 1365.31d |  | start no earlier than 2005-01-10 | 2010-12-30 | AUV Fabricator #1 | 2.25h |
| 166 | 1.2.6.1.5.4 | Crossbow comms test | 0.25d | 2005-02-07 | 2005-02-07 |  | 1365.31d |  | start no earlier than 2005-01-10 | 2010-12-30 | AUV Fabricator #1 | 2.25h |
| 167 | 1.2.6.2 | Nose Section Electrical/Mechanical Integration & Test | 15d | 2005-02-07 | 2005-03-02 |  | 1350.56d |  | start no earlier than 2005-01-10 | 2010-12-30 | AUV Fabricator #1 | 135h |
| 168 | 1.2.6.3 | **Mid Section Electrical/Mechanical Integration & Test** | 8d? | 2005-02-07 | 2005-02-18 |  | 1357.56d |  |  | 2010-12-30 | AUV Fabricator #1 | 189h |
| 169 | 1.2.6.3.1 | **Bracketry** | 8d | 2005-02-07 | 2005-02-18 |  | 1357.56d |  |  | 2010-12-30 | AUV Fabricator #1 | 72h |
| 170 | 1.2.6.3.1.1 | Bracketry Fabrication | 8d | 2005-02-07 | 2005-02-18 |  | 1357.56d |  | start no earlier than 2005-01-10 | 2010-12-30 |  |  |
| 171 | 1.2.6.3.1.2 | Bracketry assembly | 2d | 2005-02-07 | 2005-02-09 |  | 1363.56d |  | start no earlier than 2005-01-10 | 2010-12-30 |  |  |
| 172 | 1.2.6.3.2 | Syntactic Assembly | 1d | 2005-02-07 | 2005-02-08 |  | 1364.56d |  | start no earlier than 2005-01-10 | 2010-12-30 | AUV Fabricator #1 | 9h |
| 173 | 1.2.6.3.3 | **Battery** | 2d? | 2005-02-07 | 2005-02-09 |  | 1363.56d |  |  | 2010-12-30 | AUV Fabricator #1 | 18h |
| 174 | 1.2.6.3.3.1 | Battery ordering | 1d? | 2005-02-07 | 2005-02-08 |  | 1364.56d |  | start no earlier than 2005-01-10 | 2010-12-30 |  |  |
| 175 | 1.2.6.3.3.2 | Bench testing | 2d | 2005-02-07 | 2005-02-09 |  | 1363.56d |  | start no earlier than 2005-01-10 | 2010-12-30 |  |  |
| 176 | 1.2.6.3.3.3 | Installation | 1d | 2005-02-07 | 2005-02-08 |  | 1364.56d |  | start no earlier than 2005-01-10 | 2010-12-30 |  |  |
| 177 | 1.2.6.3.4 | **junction Box** | 2d | 2005-02-07 | 2005-02-09 |  | 1363.56d |  |  | 2010-12-30 | AUV Fabricator #1 | 18h |
| 178 | 1.2.6.3.4.1 | Assembly | 2d | 2005-02-07 | 2005-02-09 |  | 1363.56d |  | start no earlier than 2005-01-10 | 2010-12-30 |  |  |
| 179 | 1.2.6.3.4.2 | Casting | 1d | 2005-02-07 | 2005-02-08 |  | 1364.56d |  | start no earlier than 2005-01-10 | 2010-12-30 |  |  |
| 180 | 1.2.6.3.4.3 | Installation | 0.5d | 2005-02-07 | 2005-02-08 |  | 1365.06d |  | start no earlier than 2005-01-10 | 2010-12-30 |  |  |
| 181 | 1.2.7 | Test and debug | 1d? | 2005-03-02 | 2005-03-03 | 134 | 1350.56d | 0d |  | 2010-12-30 |  |  |
| 182 | 1.2.8 | Deployment | 1d? | 2005-03-03 | 2005-03-04 | 181 | 1350.56d |  |  | 2010-12-30 |  |  |

Notes:
- 156: HT
- 157: HT
- 158: HT
- 159: HT
- 160: HT
- 161: HT
- 162: HT
- 163: HT
- 164: HT
- 165: HT
- 166: HT
- 167: HT
- 168: HT
- 169: HT
- 170: HT
- 171: HT
- 172: HT
- 173: HT
- 175: HT
- 176: HT
- 177: HT
- 178: HT
- 179: HT
- 180: HT

| ID | WBS | Task | Type | Duration | Start | Finish | Predecessors | Total slack | Free slack | Constraint | Deadline | Resources | Work |
| --- | --- | --- | --- | --- | --- | --- | --- | --- | --- | --- | --- | --- | --- |
| 183 | 1.3 | **Dock** |  | 911.82d? | 2005-01-10 | 2008-12-16 |  | 473.07d |  |  | 2010-12-30 |  | 9360.4h |
| 184 | 1.3.1 | **design** |  | 38.33d? | 2005-01-20 | 2005-03-22 | 2 | 473.07d | 0d |  | 2010-12-30 |  | 208h |
| 185 | 1.3.1.1 | single line diagram and instrument list |  | 0.63w | 2005-01-20 | 2005-01-26 |  | 473.07d | 0d | start no earlier than 2005-01-10 | 2010-12-30 | SYS_ENG | 40h |
| 186 | 1.3.1.2 | power budget |  | 0.63w | 2005-01-27 | 2005-02-02 | 185 | 473.07d | 0d | start no earlier than 2005-01-10 | 2010-12-30 | SYS_ENG | 40h |
| 187 | 1.3.1.3 | data and telemetry budget |  | 0.63w | 2005-02-03 | 2005-02-09 | 186 | 473.07d | 0d | start no earlier than 2005-01-10 | 2010-12-30 | SYS_ENG | 40h |
| 188 | 1.3.1.4 | design radio housing |  | 1.78d | 2005-02-10 | 2005-02-11 | 187 | 473.07d | 0d | start no earlier than 2005-01-10 | 2010-12-30 |  |  |
| 189 | 1.3.1.5 | design radio cabling and connectors |  | 1.78d | 2005-02-14 | 2005-02-15 | 188 | 473.07d | 0d | start no earlier than 2005-01-10 | 2010-12-30 |  |  |
| 190 | 1.3.1.6 | RF link quality monitoring |  | 8.89d | 2005-02-16 | 2005-03-01 | 189 | 473.07d | 0d | start no earlier than 2005-01-10 | 2010-12-30 | SUE [10%] | 8h |
| 191 | 1.3.1.7 | design instrument cable and connectors |  | 5.33d | 2005-03-02 | 2005-03-09 | 190 | 473.07d | 0d | start no earlier than 2005-01-10 | 2010-12-30 | OSG | 48h |
| 192 | 1.3.1.8 | design monster cable |  | 2.67d | 2005-03-10 | 2005-03-14 | 191 | 473.07d | 0d | start no earlier than 2005-01-10 | 2010-12-30 | OSG | 24h |
| 193 | 1.3.1.9 | anchor design |  | 0.89d | 2005-03-15 | 2005-03-15 | 192 | 473.07d | 0d | start no earlier than 2005-01-10 | 2010-12-30 | OSG | 8h |
| 194 | 1.3.1.10 | Define requirements |  | 1d? | 2005-03-16 | 2005-03-17 | 193 | 473.07d | 0d |  | 2010-12-30 |  |  |
| 195 | 1.3.1.11 | Concept design |  | 0.89d | 2005-03-17 | 2005-03-18 | 194 | 473.07d | 0d | start no earlier than 2005-01-10 | 2010-12-30 |  |  |
| 196 | 1.3.1.12 | Concept prototype design |  | 0.89d | 2005-03-18 | 2005-03-21 | 195 | 473.07d | 0d | start no earlier than 2005-01-10 | 2010-12-30 |  |  |
| 197 | 1.3.1.13 | Concept prototype build |  | 0.89d | 2005-03-21 | 2005-03-22 | 196 | 473.07d |  | start no earlier than 2005-01-10 | 2010-12-30 |  |  |
| 198 | 1.3.2 | **design review** |  | 8.89d | 2005-03-22 | 2005-04-05 | 184 | 473.07d | 0d |  | 2010-12-30 |  | 56h |
| 199 | 1.3.2.1 | review of connectors and penetrations |  | 0.89d | 2005-03-22 | 2005-03-23 |  | 473.07d | 0d | start no earlier than 2005-01-10 | 2010-12-30 | SYS_ENG | 8h |
| 200 | 1.3.2.2 | review instrument cable and connectors |  | 1.78d | 2005-03-23 | 2005-03-25 | 199 | 473.07d | 0d | start no earlier than 2005-01-10 | 2010-12-30 | OSG | 16h |
| 201 | 1.3.2.3 | configuration freeze | milestone | 0d | 2005-03-25 | 2005-03-25 | 200 | 473.07d | 0d | start no earlier than 2005-01-10 | 2010-12-30 |  |  |
| 202 | 1.3.2.4 | readiness reviews |  | 3.56d | 2005-03-25 | 2005-03-31 | 201 | 473.07d | 0d | start no earlier than 2005-01-10 | 2010-12-30 | SYS_ENG | 32h |
| 203 | 1.3.2.5 | Test concept prototype in tank |  | 0.89d | 2005-03-31 | 2005-04-01 | 202 | 473.07d | 0d | start no earlier than 2005-01-10 | 2010-12-30 |  |  |
| 204 | 1.3.2.6 | Detailed design |  | 0.89d | 2005-04-01 | 2005-04-04 | 203 | 473.07d | 0d | start no earlier than 2005-01-10 | 2010-12-30 |  |  |
| 205 | 1.3.2.7 | PDR | milestone | 0.89d | 2005-04-04 | 2005-04-05 | 204, 85 | 473.07d |  | start no earlier than 2005-01-10 | 2010-12-30 |  |  |
| 206 | 1.3.3 | **Purchasing** |  | 167.78d | 2005-04-05 | 2005-12-23 | 198 | 473.07d | 0d |  | 2010-12-30 |  | 354h |
| 207 | 1.3.3.1 | design instrument mounts |  | 7.11d | 2005-04-05 | 2005-04-15 |  | 473.07d | 0d | start no earlier than 2005-01-10 | 2010-12-30 | ME | 64h |
| 208 | 1.3.3.2 | instruments and test cables available | milestone | 0d | 2005-04-15 | 2005-04-15 | 207 | 473.07d | 0d | start no earlier than 2005-01-10 | 2010-12-30 |  |  |
| 209 | 1.3.3.3 | purchase floatation foam |  | 0.89d | 2005-04-15 | 2005-04-18 | 208 | 473.07d | 0d | start no earlier than 2005-01-10 | 2010-12-30 | OSG | 8h |
| 210 | 1.3.3.4 | floatation plate orders |  | 0.44d | 2005-04-18 | 2005-04-18 | 209 | 473.07d | 0d | start no earlier than 2005-01-10 | 2010-12-30 | MA | 4h |
| 211 | 1.3.3.5 | purchase tower |  | 0.89d | 2005-04-18 | 2005-04-19 | 210 | 473.07d | 0d | start no earlier than 2005-01-10 | 2010-12-30 | OSG | 8h |
| 212 | 1.3.3.6 | purchase anchor parts |  | 0.89d | 2005-04-19 | 2005-04-20 | 211 | 473.07d | 0d | start no earlier than 2005-01-10 | 2010-12-30 | OSG | 8h |
| 213 | 1.3.3.7 | purchase bridle parts and heat treating |  | 0.89d | 2005-04-20 | 2005-04-21 | 212 | 473.07d | 0d | start no earlier than 2005-01-10 | 2010-12-30 | OSG | 8h |
| 214 | 1.3.3.8 | purchase elevator and winch parts |  | 0.89d | 2005-04-21 | 2005-04-22 | 213 | 473.07d | 0d | start no earlier than 2005-01-10 | 2010-12-30 | OSG | 8h |
| 215 | 1.3.3.9 | inventory hardware and cable |  | 1.78d | 2005-04-22 | 2005-04-26 | 214 | 473.07d | 0d | start no earlier than 2005-01-10 | 2010-12-30 | OSG | 16h |
| 216 | 1.3.3.10 | purchase cable, chain, standard hardware |  | 1.27w | 2005-04-26 | 2005-05-10 | 215 | 473.07d | 0d | start no earlier than 2005-01-10 | 2010-12-30 | OSG | 80h |
| 217 | 1.3.3.11 | purchase steamer chain |  | 1.78d | 2005-05-10 | 2005-05-12 | 216 | 473.07d | 0d | start no earlier than 2005-01-10 | 2010-12-30 | OSG | 16h |
| 218 | 1.3.3.12 | accoustic release lead time |  | 3.81w | 2005-05-12 | 2005-06-23 | 217 | 473.07d | 0d | start no earlier than 2005-01-10 | 2010-12-30 |  |  |
| 219 | 1.3.3.13 | purchase power can mechanical |  | 0.89d | 2005-06-23 | 2005-06-24 | 218 | 473.07d | 0d | start no earlier than 2005-01-10 | 2010-12-30 | OSG | 8h |
| 220 | 1.3.3.14 | purchase power can electrical |  | 0.89d | 2005-06-24 | 2005-06-27 | 219 | 473.07d | 0d | start no earlier than 2005-01-10 | 2010-12-30 | OSG | 8h |
| 221 | 1.3.3.15 | purchasing support |  | 17.78d | 2005-06-27 | 2005-07-25 | 220 | 473.07d | 0d | start no earlier than 2005-01-10 | 2010-12-30 | EE [10%] | 16h |
| 222 | 1.3.3.16 | power can chassis | milestone | 0d | 2005-07-25 | 2005-07-25 | 221 | 473.07d | 0d | start no earlier than 2005-01-10 | 2010-12-30 |  |  |
| 223 | 1.3.3.17 | power can electronics parts | milestone | 0d | 2005-07-25 | 2005-07-25 | 222 | 473.07d | 0d | start no earlier than 2005-01-10 | 2010-12-30 |  |  |
| 224 | 1.3.3.18 | power can housing | milestone | 0d | 2005-07-25 | 2005-07-25 | 223 | 473.07d | 0d | start no earlier than 2005-01-10 | 2010-12-30 |  |  |
| 225 | 1.3.3.19 | power can lid | milestone | 0d | 2005-07-25 | 2005-07-25 | 224 | 473.07d | 0d | start no earlier than 2005-01-10 | 2010-12-30 |  |  |
| 226 | 1.3.3.20 | power can bulkhead connectors | milestone | 0d | 2005-07-25 | 2005-07-25 | 225 | 473.07d | 0d | start no earlier than 2005-01-10 | 2010-12-30 |  |  |
| 227 | 1.3.3.21 | power cables | milestone | 0d | 2005-07-25 | 2005-07-25 | 226 | 473.07d | 0d | start no earlier than 2005-01-10 | 2010-12-30 |  |  |
| 228 | 1.3.3.22 | solar panels | milestone | 0d | 2005-07-25 | 2005-07-25 | 227 | 473.07d | 0d | start no earlier than 2005-01-10 | 2010-12-30 |  |  |
| 229 | 1.3.3.23 | battery boxes | milestone | 0d | 2005-07-25 | 2005-07-25 | 228 | 473.07d | 0d | start no earlier than 2005-01-10 | 2010-12-30 |  |  |
| 230 | 1.3.3.24 | load sink resistors | milestone | 0d | 2005-07-25 | 2005-07-25 | 229 | 473.07d | 0d | start no earlier than 2005-01-10 | 2010-12-30 |  |  |
| 231 | 1.3.3.25 | batteries | milestone | 0d | 2005-07-25 | 2005-07-25 | 230 | 473.07d | 0d | start no earlier than 2005-01-10 | 2010-12-30 |  |  |
| 232 | 1.3.3.26 | purchase puck mechanical |  | 0.89d | 2005-07-25 | 2005-07-26 | 231 | 473.07d | 0d | start no earlier than 2005-01-10 | 2010-12-30 | OSG | 8h |
| 233 | 1.3.3.27 | purchase puck electrical |  | 0.89d | 2005-07-26 | 2005-07-27 | 232 | 473.07d | 0d | start no earlier than 2005-01-10 | 2010-12-30 | OSG | 8h |
| 234 | 1.3.3.28 | potted puck cables and connectors | milestone | 0d | 2005-07-27 | 2005-07-27 | 233 | 473.07d | 0d | start no earlier than 2005-01-10 | 2010-12-30 |  |  |
| 235 | 1.3.3.29 | puck housing tubes | milestone | 0d | 2005-07-27 | 2005-07-27 | 234 | 473.07d | 0d | start no earlier than 2005-01-10 | 2010-12-30 |  |  |
| 236 | 1.3.3.30 | puck housing bulkheads | milestone | 0d | 2005-07-27 | 2005-07-27 | 235 | 473.07d | 0d | start no earlier than 2005-01-10 | 2010-12-30 |  |  |
| 237 | 1.3.3.31 | puck housing board connectors | milestone | 0d | 2005-07-27 | 2005-07-27 | 236 | 473.07d | 0d | start no earlier than 2005-01-10 | 2010-12-30 |  |  |
| 238 | 1.3.3.32 | puck boards | milestone | 0d | 2005-07-27 | 2005-07-27 | 237 | 473.07d | 0d | start no earlier than 2005-01-10 | 2010-12-30 |  |  |
| 239 | 1.3.3.33 | puck electronics | milestone | 0d | 2005-07-27 | 2005-07-27 | 238 | 473.07d | 0d | start no earlier than 2005-01-10 | 2010-12-30 |  |  |
| 240 | 1.3.3.34 | test cable parts | milestone | 0d | 2005-07-27 | 2005-07-27 | 239 | 473.07d | 0d | start no earlier than 2005-01-10 | 2010-12-30 |  |  |
| 241 | 1.3.3.35 | purchase MMC mechanical parts |  | 0.89d | 2005-07-27 | 2005-07-28 | 240 | 473.07d | 0d | start no earlier than 2005-01-10 | 2010-12-30 | OSG | 8h |
| 242 | 1.3.3.36 | purchase MMC electrical parts |  | 0.89d | 2005-07-28 | 2005-07-29 | 241 | 473.07d | 0d | start no earlier than 2005-01-10 | 2010-12-30 | OSG | 8h |
| 243 | 1.3.3.37 | MMC bulkhead connectors | milestone | 0d | 2005-07-29 | 2005-07-29 | 242 | 473.07d | 0d | start no earlier than 2005-01-10 | 2010-12-30 |  |  |
| 244 | 1.3.3.38 | MMC housing | milestone | 0d | 2005-07-29 | 2005-07-29 | 243 | 473.07d | 0d | start no earlier than 2005-01-10 | 2010-12-30 |  |  |
| 245 | 1.3.3.39 | MMC housing lid | milestone | 0d | 2005-07-29 | 2005-07-29 | 244 | 473.07d | 0d | start no earlier than 2005-01-10 | 2010-12-30 |  |  |
| 246 | 1.3.3.40 | MMC chassis | milestone | 0d | 2005-07-29 | 2005-07-29 | 245 | 473.07d | 0d | start no earlier than 2005-01-10 | 2010-12-30 |  |  |
| 247 | 1.3.3.41 | MMC electronics parts (Sidearm, DPA, backplane,RFComms) | milestone | 0d | 2005-07-29 | 2005-07-29 | 246 | 473.07d | 0d | start no earlier than 2005-01-10 | 2010-12-30 |  |  |
| 248 | 1.3.3.42 | compass | milestone | 0d | 2005-07-29 | 2005-07-29 | 247 | 473.07d | 0d | start no earlier than 2005-01-10 | 2010-12-30 |  |  |
| 249 | 1.3.3.43 | purchase RF electrical |  | 0.89d | 2005-07-29 | 2005-08-01 | 248 | 473.07d | 0d | start no earlier than 2005-01-10 | 2010-12-30 | SUE | 8h |
| 250 | 1.3.3.44 | purchase RF mechanical |  | 0.89d | 2005-08-01 | 2005-08-02 | 249 | 473.07d | 0d | start no earlier than 2005-01-10 | 2010-12-30 | SUE | 8h |
| 251 | 1.3.3.45 | radio housing | milestone | 0d | 2005-08-02 | 2005-08-02 | 250 | 473.07d | 0d | start no earlier than 2005-01-10 | 2010-12-30 |  |  |
| 252 | 1.3.3.46 | radio mounts | milestone | 0d | 2005-08-02 | 2005-08-02 | 251 | 473.07d | 0d | start no earlier than 2005-01-10 | 2010-12-30 |  |  |

Notes:
- 184: Bouy
- 185: Bouy
- 186: Bouy
- 187: Bouy
- 188: Bouy
- 189: Bouy
- 190: Bouy
- 191: Bouy
- 192: Bouy
- 193: Bouy
- 195: MS
- 196: MS
- 197: MS
- 199: Bouy
- 200: Bouy
- 201: Bouy
- 202: Bouy
- 203: MS
- 204: MS
- 205: MS
- 207: Bouy
- 208: Bouy
- 209: Bouy
- 210: Bouy
- 211: Bouy
- 212: Bouy
- 213: Bouy
- 214: Bouy
- 215: Bouy
- 216: Bouy
- 217: Bouy
- 218: Bouy
- 219: Bouy
- 220: Bouy
- 221: Bouy
- 222: Bouy
- 223: Bouy
- 224: Bouy
- 225: Bouy
- 226: Bouy
- 227: Bouy
- 228: Bouy
- 229: Bouy
- 230: Bouy
- 231: Bouy
- 232: Bouy
- 233: Bouy
- 234: Bouy
- 235: Bouy
- 236: Bouy
- 237: Bouy
- 238: Bouy
- 239: Bouy
- 240: Bouy
- 241: Bouy
- 242: Bouy
- 243: Bouy
- 244: Bouy
- 245: Bouy
- 246: Bouy
- 247: Bouy
- 248: Bouy
- 249: Bouy
- 250: Bouy
- 251: Bouy
- 252: Bouy

| ID | WBS | Task | Type | Duration | Start | Finish | Predecessors | Total slack | Free slack | Constraint | Deadline | Resources | Work |
| --- | --- | --- | --- | --- | --- | --- | --- | --- | --- | --- | --- | --- | --- |
| 253 | 1.3.3.47 | cables and connectors | milestone | 0d | 2005-08-02 | 2005-08-02 | 252 | 473.07d | 0d | start no earlier than 2005-01-10 | 2010-12-30 |  |  |
| 254 | 1.3.3.48 | radios | milestone | 0d | 2005-08-02 | 2005-08-02 | 253 | 473.07d | 0d | start no earlier than 2005-01-10 | 2010-12-30 |  |  |
| 255 | 1.3.3.49 | antennas | milestone | 0d | 2005-08-02 | 2005-08-02 | 254 | 473.07d | 0d | start no earlier than 2005-01-10 | 2010-12-30 |  |  |
| 256 | 1.3.3.50 | inventory instrument cables and connectors |  | 0.89d | 2005-08-02 | 2005-08-03 | 255 | 473.07d | 0d | start no earlier than 2005-01-10 | 2010-12-30 | OSG | 8h |
| 257 | 1.3.3.51 | purchase instruments |  | 44.44d | 2005-08-03 | 2005-10-12 | 256 | 473.07d | 0d | start no earlier than 2005-01-10 | 2010-12-30 | OSG [2%] | 8h |
| 258 | 1.3.3.52 | purchase instrument cables and connectors |  | 44.44d | 2005-10-12 | 2005-12-21 | 257 | 473.07d | 0d | start no earlier than 2005-01-10 | 2010-12-30 | OSG [5%] | 20h |
| 259 | 1.3.3.53 | Metsys | milestone | 0d | 2005-12-21 | 2005-12-21 | 258 | 473.07d | 0d | start no earlier than 2005-01-10 | 2010-12-30 |  |  |
| 260 | 1.3.3.54 | ADCP | milestone | 0d | 2005-12-21 | 2005-12-21 | 259 | 473.07d | 0d | start no earlier than 2005-01-10 | 2010-12-30 |  |  |
| 261 | 1.3.3.55 | Serial CTD | milestone | 0d | 2005-12-21 | 2005-12-21 | 260 | 473.07d | 0d | start no earlier than 2005-01-10 | 2010-12-30 |  |  |
| 262 | 1.3.3.56 | Inductive CTD 10m,20m,40m,60m | milestone | 0d | 2005-12-21 | 2005-12-21 | 261 | 473.07d | 0d | start no earlier than 2005-01-10 | 2010-12-30 |  |  |
| 263 | 1.3.3.57 | Inductive Modem | milestone | 0d | 2005-12-21 | 2005-12-21 | 262 | 473.07d | 0d | start no earlier than 2005-01-10 | 2010-12-30 |  |  |
| 264 | 1.3.3.58 | Inductive Coupler | milestone | 0d | 2005-12-21 | 2005-12-21 | 263 | 473.07d | 0d | start no earlier than 2005-01-10 | 2010-12-30 |  |  |
| 265 | 1.3.3.59 | Nitrate | milestone | 0d | 2005-12-21 | 2005-12-21 | 264 | 473.07d | 0d | start no earlier than 2005-01-10 | 2010-12-30 |  |  |
| 266 | 1.3.3.60 | CO2 | milestone | 0d | 2005-12-21 | 2005-12-21 | 265 | 473.07d | 0d | start no earlier than 2005-01-10 | 2010-12-30 |  |  |
| 267 | 1.3.3.61 | Radiometers | milestone | 0d | 2005-12-21 | 2005-12-21 | 266 | 473.07d | 0d | start no earlier than 2005-01-10 | 2010-12-30 |  |  |
| 268 | 1.3.3.62 | Fluorometer | milestone | 0d | 2005-12-21 | 2005-12-21 | 267 | 473.07d | 0d | start no earlier than 2005-01-10 | 2010-12-30 |  |  |
| 269 | 1.3.3.63 | Backscatter | milestone | 0d | 2005-12-21 | 2005-12-21 | 268 | 473.07d | 0d | start no earlier than 2005-01-10 | 2010-12-30 |  |  |
| 270 | 1.3.3.64 | Locator | milestone | 0d | 2005-12-21 | 2005-12-21 | 269 | 473.07d | 0d | start no earlier than 2005-01-10 | 2010-12-30 |  |  |
| 271 | 1.3.3.65 | GPS | milestone | 0d | 2005-12-21 | 2005-12-21 | 270 | 473.07d | 0d | start no earlier than 2005-01-10 | 2010-12-30 |  |  |
| 272 | 1.3.3.66 | purchase pager reset mechanical |  | 0.89d | 2005-12-21 | 2005-12-22 | 271 | 473.07d | 0d | start no earlier than 2005-01-10 | 2010-12-30 | OSG | 8h |
| 273 | 1.3.3.67 | purchase pager reset electronics |  | 0.89d | 2005-12-22 | 2005-12-23 | 272 | 473.07d | 0d | start no earlier than 2005-01-10 | 2010-12-30 | OSG | 8h |
| 274 | 1.3.3.68 | pager service setup |  | 0.22d | 2005-12-23 | 2005-12-23 | 273 | 473.07d | 0d | start no earlier than 2005-01-10 | 2010-12-30 | OSG | 2h |
| 275 | 1.3.3.69 | pager reset board | milestone | 0d | 2005-12-23 | 2005-12-23 | 274 | 473.07d | 0d | start no earlier than 2005-01-10 | 2010-12-30 |  |  |
| 276 | 1.3.3.70 | pager reset housing | milestone | 0d | 2005-12-23 | 2005-12-23 | 275 | 473.07d | 0d | start no earlier than 2005-01-10 | 2010-12-30 |  |  |
| 277 | 1.3.3.71 | pager reset connectors | milestone | 0d | 2005-12-23 | 2005-12-23 | 276 | 473.07d | 0d | start no earlier than 2005-01-10 | 2010-12-30 |  |  |
| 278 | 1.3.3.72 | pager reset cable | milestone | 0d | 2005-12-23 | 2005-12-23 | 277 | 473.07d | 0d | start no earlier than 2005-01-10 | 2010-12-30 |  |  |
| 279 | 1.3.3.73 | pager reset mounts | milestone | 0d | 2005-12-23 | 2005-12-23 | 278 | 473.07d |  | start no earlier than 2005-01-10 | 2010-12-30 |  |  |

Notes:
- 253: Bouy
- 254: Bouy
- 255: Bouy
- 256: Bouy
- 257: Bouy
- 258: Bouy
- 259: Bouy
- 260: Bouy
- 261: Bouy
- 262: Bouy
- 263: Bouy
- 264: Bouy
- 265: Bouy
- 266: Bouy
- 267: Bouy
- 268: Bouy
- 269: Bouy
- 270: Bouy
- 271: Bouy
- 272: Bouy
- 273: Bouy
- 274: Bouy
- 275: Bouy
- 276: Bouy
- 277: Bouy
- 278: Bouy
- 279: Bouy

| ID | WBS | Task | Type | Duration | Start | Finish | Predecessors | Total slack | Free slack | Constraint | Deadline | Resources | Work |
| --- | --- | --- | --- | --- | --- | --- | --- | --- | --- | --- | --- | --- | --- |
| 280 | 1.3.4 | **fab** |  | 562.67d | 2005-12-23 | 2008-05-28 | 206 | 473.07d | 0d |  | 2010-12-30 |  | 6824h |
| 281 | 1.3.4.1 | **Misc** |  | 562.67d | 2005-12-23 | 2008-05-28 |  | 473.07d |  |  | 2010-12-30 |  | 3232h |
| 282 | 1.3.4.1.1 | build and ship foam |  | 7.62w | 2005-12-23 | 2006-03-17 |  | 473.07d | 0d | start no earlier than 2005-01-10 | 2010-12-30 | EXT_VENDOR | 480h |
| 283 | 1.3.4.1.2 | floatation plate cut |  | 0.89d | 2006-03-17 | 2006-03-20 | 282 | 473.07d | 0d | start no earlier than 2005-01-10 | 2010-12-30 | MA | 8h |
| 284 | 1.3.4.1.3 | floatation plate weld |  | 4.44d | 2006-03-20 | 2006-03-27 | 283 | 473.07d | 0d | start no earlier than 2005-01-10 | 2010-12-30 | MA | 40h |
| 285 | 1.3.4.1.4 | floatation plate finishing |  | 0.44d | 2006-03-27 | 2006-03-28 | 284 | 473.07d | 0d | start no earlier than 2005-01-10 | 2010-12-30 | MA | 4h |
| 286 | 1.3.4.1.5 | floatation tie rod machining |  | 0.89d | 2006-03-28 | 2006-03-29 | 285 | 473.07d | 0d | start no earlier than 2005-01-10 | 2010-12-30 | MA | 8h |
| 287 | 1.3.4.1.6 | floatation tie rod weld |  | 0.89d | 2006-03-29 | 2006-03-30 | 286 | 473.07d | 0d | start no earlier than 2005-01-10 | 2010-12-30 | MA | 8h |
| 288 | 1.3.4.1.7 | buoy standup support |  | 4.44d | 2006-03-30 | 2006-04-06 | 287 | 473.07d | 0d | start no earlier than 2005-01-10 | 2010-12-30 | MT | 40h |
| 289 | 1.3.4.1.8 | tower machining |  | 7.62w | 2006-04-06 | 2006-06-29 | 288 | 473.07d | 0d | start no earlier than 2005-01-10 | 2010-12-30 | EXT_VENDOR | 480h |
| 290 | 1.3.4.1.9 | tower bracket welding |  | 2.67d | 2006-06-29 | 2006-07-04 | 289 | 473.07d | 0d | start no earlier than 2005-01-10 | 2010-12-30 | MA | 24h |
| 291 | 1.3.4.1.10 | tower heat treat+shipping |  | 1.27w | 2006-07-04 | 2006-07-18 | 290 | 473.07d | 0d | start no earlier than 2005-01-10 | 2010-12-30 | EXT_VENDOR | 80h |
| 292 | 1.3.4.1.11 | bridle machining (stainless, no heat treat) |  | 7.62w | 2006-07-18 | 2006-10-10 | 291 | 473.07d | 0d | start no earlier than 2005-01-10 | 2010-12-30 | EXT_VENDOR | 480h |
| 293 | 1.3.4.1.12 | bridle mods for ballast mount |  | 0.89d | 2006-10-10 | 2006-10-11 | 292 | 473.07d | 0d | start no earlier than 2005-01-10 | 2010-12-30 | MT | 8h |
| 294 | 1.3.4.1.13 | elevator cage machining |  | 1.27w | 2006-10-11 | 2006-10-25 | 293 | 473.07d | 0d | start no earlier than 2005-01-10 | 2010-12-30 | EXT_VENDOR | 80h |
| 295 | 1.3.4.1.14 | anchor trawl-resistant dome fab and ship |  | 1.9w | 2006-10-25 | 2006-11-15 | 294 | 473.07d | 0d | start no earlier than 2005-01-10 | 2010-12-30 | EXT_VENDOR | 120h |
| 296 | 1.3.4.1.15 | anchor welding |  | 4d | 2006-11-15 | 2006-11-21 | 295 | 473.07d | 0d | start no earlier than 2005-01-10 | 2010-12-30 | MA | 36h |
| 297 | 1.3.4.1.16 | elevator cage electropolish, passivate |  | 1.27w | 2006-11-21 | 2006-12-05 | 296 | 473.07d | 0d | start no earlier than 2005-01-10 | 2010-12-30 | EXT_VENDOR | 80h |
| 298 | 1.3.4.1.17 | elevator cage copper plate |  | 1.27w | 2006-12-05 | 2006-12-19 | 297 | 473.07d | 0d | start no earlier than 2005-01-10 | 2010-12-30 | EXT_VENDOR | 80h |
| 299 | 1.3.4.1.18 | elevator rods machining |  | 0.63w | 2006-12-19 | 2006-12-26 | 298 | 473.07d | 0d | start no earlier than 2005-01-10 | 2010-12-30 | MA | 40h |
| 300 | 1.3.4.1.19 | elevator small parts ( bushings, clamp blocks, stops, stop brackets, pins…) |  | 1.9w | 2006-12-26 | 2007-01-16 | 299 | 473.07d | 0d | start no earlier than 2005-01-10 | 2010-12-30 | MA | 120h |
| 301 | 1.3.4.1.20 | elevator winch lead time |  | 0.63w | 2007-01-16 | 2007-01-23 | 300 | 473.07d | 0d | start no earlier than 2005-01-10 | 2010-12-30 |  |  |
| 302 | 1.3.4.1.21 | elevator assembly |  | 0.89d | 2007-01-23 | 2007-01-24 | 301 | 473.07d | 0d | start no earlier than 2005-01-10 | 2010-12-30 | OSG | 8h |
| 303 | 1.3.4.1.22 | puck board build |  | 1.27w | 2007-01-24 | 2007-02-07 | 302 | 473.07d | 0d | start no earlier than 2005-01-10 | 2010-12-30 | EXT_VENDOR | 80h |
| 304 | 1.3.4.1.23 | puck board test |  | 0.44d | 2007-02-07 | 2007-02-08 | 303 | 473.07d | 0d | start no earlier than 2005-01-10 | 2010-12-30 | ET | 4h |
| 305 | 1.3.4.1.24 | puck housing machining |  | 1.27w | 2007-02-08 | 2007-02-22 | 304 | 473.07d | 0d | start no earlier than 2005-01-10 | 2010-12-30 | EXT_VENDOR | 80h |
| 306 | 1.3.4.1.25 | puck bulkhead machining |  | 1.27w | 2007-02-22 | 2007-03-08 | 305 | 473.07d | 0d | start no earlier than 2005-01-10 | 2010-12-30 | EXT_VENDOR | 80h |
| 307 | 1.3.4.1.26 | puck test cable build |  | 0.89d | 2007-03-08 | 2007-03-09 | 306 | 473.07d | 0d | start no earlier than 2005-01-10 | 2010-12-30 | OSG | 8h |
| 308 | 1.3.4.1.27 | puck firmware changes |  | 0.89d | 2007-03-09 | 2007-03-12 | 307 | 473.07d | 0d | start no earlier than 2005-01-10 | 2010-12-30 | SE | 8h |
| 309 | 1.3.4.1.28 | puck mount machining |  | 1.27w | 2007-03-12 | 2007-03-26 | 308 | 473.07d | 0d | start no earlier than 2005-01-10 | 2010-12-30 | MA | 80h |
| 310 | 1.3.4.1.29 | power cables lead time |  | 3.81w | 2007-03-26 | 2007-05-07 | 309 | 473.07d | 0d | start no earlier than 2005-01-10 | 2010-12-30 |  |  |
| 311 | 1.3.4.1.30 | batteries lead time |  | 3.56d | 2007-05-07 | 2007-05-11 | 310 | 473.07d | 0d | start no earlier than 2005-01-10 | 2010-12-30 |  |  |
| 312 | 1.3.4.1.31 | radio lead time |  | 2.67d | 2007-05-11 | 2007-05-16 | 311 | 473.07d | 0d | start no earlier than 2005-01-10 | 2010-12-30 |  |  |
| 313 | 1.3.4.1.32 | antenna lead time |  | 2.67d | 2007-05-16 | 2007-05-21 | 312 | 473.07d | 0d | start no earlier than 2005-01-10 | 2010-12-30 |  |  |
| 314 | 1.3.4.1.33 | radio housings and mounts machining |  | 1.27w | 2007-05-21 | 2007-06-04 | 313 | 473.07d | 0d | start no earlier than 2005-01-10 | 2010-12-30 | EXT_VENDOR | 80h |
| 315 | 1.3.4.1.34 | radio cables and connectors fab |  | 3.81w | 2007-06-04 | 2007-07-16 | 314 | 473.07d | 0d | start no earlier than 2005-01-10 | 2010-12-30 | EXT_VENDOR | 240h |
| 316 | 1.3.4.1.35 | test RF cables |  | 0.44d | 2007-07-16 | 2007-07-16 | 315 | 473.07d | 0d | start no earlier than 2005-01-10 | 2010-12-30 | SUE | 4h |
| 317 | 1.3.4.1.36 | radio can mounts machining |  | 0.63w | 2007-07-16 | 2007-07-23 | 316 | 473.07d | 0d | start no earlier than 2005-01-10 | 2010-12-30 | EXT_VENDOR | 40h |
| 318 | 1.3.4.1.37 | radio housing vacuum test |  | 0.89d | 2007-07-23 | 2007-07-24 | 317 | 473.07d | 0d | start no earlier than 2005-01-10 | 2010-12-30 | SUE | 8h |
| 319 | 1.3.4.1.38 | instrument order lead time |  | 3.81w | 2007-07-24 | 2007-09-04 | 318 | 473.07d | 0d | start no earlier than 2005-01-10 | 2010-12-30 |  |  |
| 320 | 1.3.4.1.39 | instrument calibration time |  | 1.27w | 2007-09-04 | 2007-09-18 | 319 | 473.07d | 0d | start no earlier than 2005-01-10 | 2010-12-30 |  |  |
| 321 | 1.3.4.1.40 | instrument cable and connector lead time |  | 3.81w | 2007-09-18 | 2007-10-30 | 320 | 473.07d | 0d | start no earlier than 2005-01-10 | 2010-12-30 |  |  |
| 322 | 1.3.4.1.41 | build instrument cables |  | 4.44d | 2007-10-30 | 2007-11-06 | 321 | 473.07d | 0d | start no earlier than 2005-01-10 | 2010-12-30 | ET | 40h |
| 323 | 1.3.4.1.42 | monster cable lead time |  | 3.81w | 2007-11-06 | 2007-12-18 | 322 | 473.07d | 0d | start no earlier than 2005-01-10 | 2010-12-30 |  |  |
| 324 | 1.3.4.1.43 | build monster cable |  | 0.63w | 2007-12-18 | 2007-12-25 | 323 | 473.07d | 0d | start no earlier than 2005-01-10 | 2010-12-30 | OSG | 40h |
| 325 | 1.3.4.1.44 | test instrument cables |  | 1.78d | 2007-12-25 | 2007-12-27 | 324 | 473.07d | 0d | start no earlier than 2005-01-10 | 2010-12-30 | OSG | 16h |
| 326 | 1.3.4.1.45 | SOON battery housings | milestone | 0d | 2007-12-27 | 2007-12-27 | 325 | 473.07d | 0d | start no earlier than 2005-01-10 | 2010-12-30 |  |  |
| 327 | 1.3.4.1.46 | SSDS workarounds for TBD automation |  | 53.33d | 2007-12-27 | 2008-03-20 | 326 | 473.07d | 0d | start no earlier than 2005-01-10 | 2010-12-30 | IAG [10%] | 48h |
| 328 | 1.3.4.1.47 | SSDS device ID management | milestone | 0d | 2008-03-20 | 2008-03-20 | 327 | 473.07d | 0d | start no earlier than 2005-01-10 | 2010-12-30 | IAG |  |
| 329 | 1.3.4.1.48 | SSDS QC plots impl | milestone | 0d | 2008-03-20 | 2008-03-20 | 328 | 473.07d | 0d | start no earlier than 2005-01-10 | 2010-12-30 | IAG |  |
| 330 | 1.3.4.1.49 | SSDS API impl | milestone | 0d | 2008-03-20 | 2008-03-20 | 329 | 473.07d | 0d | start no earlier than 2005-01-10 | 2010-12-30 | IAG |  |
| 331 | 1.3.4.1.50 | SSDS external access impl | milestone | 0d | 2008-03-20 | 2008-03-20 | 330 | 473.07d | 0d | start no earlier than 2005-01-10 | 2010-12-30 | IAG |  |
| 332 | 1.3.4.1.51 | SSDS metadata input impl |  | 9.78d | 2008-03-20 | 2008-04-04 | 331 | 473.07d | 0d | start no earlier than 2005-01-10 | 2010-12-30 | IAG | 88h |
| 333 | 1.3.4.1.52 | pager reset board build |  | 1.78d | 2008-04-04 | 2008-04-08 | 332 | 473.07d | 0d | start no earlier than 2005-01-10 | 2010-12-30 | ET | 16h |
| 334 | 1.3.4.1.53 | pager reset electronics assy |  | 0.89d | 2008-04-08 | 2008-04-09 | 333 | 473.07d | 0d | start no earlier than 2005-01-10 | 2010-12-30 | OSG | 8h |
| 335 | 1.3.4.1.54 | pager reset mounts |  | 0.63w | 2008-04-09 | 2008-04-16 | 334 | 473.07d | 0d | start no earlier than 2005-01-10 | 2010-12-30 | EXT_VENDOR | 40h |
| 336 | 1.3.4.1.55 | puck cable and connector lead time |  | 3.81w | 2008-04-16 | 2008-05-28 | 335 | 473.07d |  | start no earlier than 2005-01-10 | 2010-12-30 |  |  |

Notes:
- 280: Bouy
- 282: Bouy
- 283: Bouy
- 284: Bouy
- 285: Bouy
- 286: Bouy
- 287: Bouy
- 288: Bouy
- 289: Bouy
- 290: Bouy
- 291: Bouy
- 292: Bouy
- 293: Bouy
- 294: Bouy
- 295: Bouy
- 296: Bouy
- 297: Bouy
- 298: Bouy
- 299: Bouy
- 300: Bouy
- 301: Bouy
- 302: Bouy
- 303: Bouy
- 304: Bouy
- 305: Bouy
- 306: Bouy
- 307: Bouy
- 308: Bouy
- 309: Bouy
- 310: Bouy
- 311: Bouy
- 312: Bouy
- 313: Bouy
- 314: Bouy
- 315: Bouy
- 316: Bouy
- 317: Bouy
- 318: Bouy
- 319: Bouy
- 320: Bouy
- 321: Bouy
- 322: Bouy
- 323: Bouy
- 324: Bouy
- 325: Bouy
- 326: Bouy
- 327: Bouy
- 328: Bouy
- 329: Bouy
- 330: Bouy
- 331: Bouy
- 332: Bouy
- 333: Bouy
- 334: Bouy
- 335: Bouy
- 336: Bouy

| ID | WBS | Task | Type | Duration | Start | Finish | Predecessors | Total slack | Free slack | Constraint | Deadline | Resources | Work |
| --- | --- | --- | --- | --- | --- | --- | --- | --- | --- | --- | --- | --- | --- |
| 337 | 1.3.4.2 | **chassis (1+1 spare)** |  | 54.22d | 2005-12-23 | 2006-03-20 |  | 981.51d |  |  | 2010-12-30 |  | 488h |
| 338 | 1.3.4.2.1 | power can chassis endplates |  | 1.27w | 2005-12-23 | 2006-01-06 |  | 981.51d | 0d | start no earlier than 2005-01-10 | 2010-12-30 | EXT_VENDOR | 80h |
| 339 | 1.3.4.2.2 | power can chassis rails |  | 2.54w | 2006-01-06 | 2006-02-03 | 338 | 981.51d | 0d | start no earlier than 2005-01-10 | 2010-12-30 | EXT_VENDOR | 160h |
| 340 | 1.3.4.2.3 | power can chassis card guide |  | 1.9w | 2006-02-03 | 2006-02-24 | 339 | 981.51d | 0d | start no earlier than 2005-01-10 | 2010-12-30 | MA | 120h |
| 341 | 1.3.4.2.4 | power can chassis clips |  | 1.9w | 2006-02-24 | 2006-03-17 | 340 | 981.51d | 0d | start no earlier than 2005-01-10 | 2010-12-30 | MA | 120h |
| 342 | 1.3.4.2.5 | power can chassis assy |  | 0.89d | 2006-03-17 | 2006-03-20 | 341 | 981.51d |  | start no earlier than 2005-01-10 | 2010-12-30 | OSG | 8h |
| 343 | 1.3.4.3 | **housing (1 + 1 spare)** |  | 38.22d | 2005-12-23 | 2006-02-22 |  | 997.51d |  |  | 2010-12-30 |  | 344h |
| 344 | 1.3.4.3.1 | power can housing machining |  | 2.54w | 2005-12-23 | 2006-01-20 |  | 997.51d | 0d | start no earlier than 2005-01-10 | 2010-12-30 | EXT_VENDOR | 160h |
| 345 | 1.3.4.3.2 | power can housing brazing (incl shipping) |  | 1.27w | 2006-01-20 | 2006-02-03 | 344 | 997.51d | 0d | start no earlier than 2005-01-10 | 2010-12-30 | EXT_VENDOR | 80h |
| 346 | 1.3.4.3.3 | power can housing anodization (incl shipping) |  | 1.27w | 2006-02-03 | 2006-02-17 | 345 | 997.51d | 0d | start no earlier than 2005-01-10 | 2010-12-30 | EXT_VENDOR | 80h |
| 347 | 1.3.4.3.4 | power can housing QC (2x) |  | 0.89d | 2006-02-17 | 2006-02-20 | 346 | 997.51d | 0d | start no earlier than 2005-01-10 | 2010-12-30 | OSG | 8h |
| 348 | 1.3.4.3.5 | power can housing pressure test |  | 1.78d | 2006-02-20 | 2006-02-22 | 347 | 997.51d | 0d | start no earlier than 2005-01-10 | 2010-12-30 | OSG | 16h |
| 349 | 1.3.4.3.6 | power can complete | milestone | 0d | 2006-02-22 | 2006-02-22 | 348 | 997.51d |  | start no earlier than 2005-01-10 | 2010-12-30 |  |  |
| 350 | 1.3.4.4 | **endcap (1 + 1 spare)** |  | 31.11d | 2005-12-23 | 2006-02-10 |  | 1004.62d |  |  | 2010-12-30 |  | 120h |
| 351 | 1.3.4.4.1 | power can endcap machining |  | 2.67d | 2005-12-23 | 2005-12-28 |  | 1004.62d | 0d | start no earlier than 2005-01-10 | 2010-12-30 | EXT_VENDOR | 24h |
| 352 | 1.3.4.4.2 | power can endcap anodization (incl shipping) |  | 1.27w | 2005-12-28 | 2006-01-11 | 351 | 1004.62d | 0d | start no earlier than 2005-01-10 | 2010-12-30 | EXT_VENDOR | 80h |
| 353 | 1.3.4.4.3 | power can endcap QC (2x) |  | 0.89d | 2006-01-11 | 2006-01-12 | 352 | 1004.62d | 0d | start no earlier than 2005-01-10 | 2010-12-30 | OSG | 8h |
| 354 | 1.3.4.4.4 | power can bulkhead connectors lead time |  | 2.54w | 2006-01-12 | 2006-02-09 | 353 | 1004.62d | 0d | start no earlier than 2005-01-10 | 2010-12-30 |  |  |
| 355 | 1.3.4.4.5 | power can endcap assembly |  | 0.89d | 2006-02-09 | 2006-02-10 | 354 | 1004.62d |  | start no earlier than 2005-01-10 | 2010-12-30 | OSG | 8h |
| 356 | 1.3.4.5 | **battery boxes (8+2 spare)** |  | 61.33d | 2005-12-23 | 2006-03-30 |  | 974.4d |  |  | 2010-12-30 |  | 552h |
| 357 | 1.3.4.5.1 | battery box machining |  | 1.9w | 2005-12-23 | 2006-01-13 |  | 974.4d | 0d | start no earlier than 2005-01-10 | 2010-12-30 | EXT_VENDOR | 120h |
| 358 | 1.3.4.5.2 | battery box flanges machining |  | 5.33d | 2006-01-13 | 2006-01-23 | 357 | 974.4d | 0d | start no earlier than 2005-01-10 | 2010-12-30 | EXT_VENDOR | 48h |
| 359 | 1.3.4.5.3 | battery box lid machining |  | 8.89d | 2006-01-23 | 2006-02-06 | 358 | 974.4d | 0d | start no earlier than 2005-01-10 | 2010-12-30 | EXT_VENDOR | 80h |
| 360 | 1.3.4.5.4 | battery box internal parts machining |  | 1.27w | 2006-02-06 | 2006-02-20 | 359 | 974.4d | 0d | start no earlier than 2005-01-10 | 2010-12-30 | EXT_VENDOR | 80h |
| 361 | 1.3.4.5.5 | flange,battery box brazing (incl shipping) |  | 1.27w | 2006-02-20 | 2006-03-06 | 360 | 974.4d | 0d | start no earlier than 2005-01-10 | 2010-12-30 | EXT_VENDOR | 80h |
| 362 | 1.3.4.5.6 | flange, battery box, anodization (incl shipping) |  | 1.27w | 2006-03-06 | 2006-03-20 | 361 | 974.4d | 0d | start no earlier than 2005-01-10 | 2010-12-30 | EXT_VENDOR | 80h |
| 363 | 1.3.4.5.7 | battery box QC (2x) |  | 0.89d | 2006-03-20 | 2006-03-21 | 362 | 974.4d | 0d | start no earlier than 2005-01-10 | 2010-12-30 | OSG | 8h |
| 364 | 1.3.4.5.8 | battery box assy |  | 4.44d | 2006-03-21 | 2006-03-28 | 363 | 974.4d | 0d | start no earlier than 2005-01-10 | 2010-12-30 | OSG | 40h |
| 365 | 1.3.4.5.9 | battery box pressure test |  | 1.78d | 2006-03-28 | 2006-03-30 | 364 | 974.4d |  | start no earlier than 2005-01-10 | 2010-12-30 | OSG | 16h |

Notes:
- 337: Bouy
- 338: Bouy
- 339: Bouy
- 340: Bouy
- 341: Bouy
- 342: Bouy
- 343: Bouy
- 344: Bouy
- 345: Bouy
- 346: Bouy
- 347: Bouy
- 348: Bouy
- 349: Bouy
- 350: Bouy
- 351: Bouy
- 352: Bouy
- 353: Bouy
- 354: Bouy
- 355: Bouy
- 356: Bouy
- 357: Bouy
- 358: Bouy
- 359: Bouy
- 360: Bouy
- 361: Bouy
- 362: Bouy
- 363: Bouy
- 364: Bouy
- 365: Bouy

| ID | WBS | Task | Type | Duration | Start | Finish | Predecessors | Total slack | Free slack | Constraint | Deadline | Resources | Work |
| --- | --- | --- | --- | --- | --- | --- | --- | --- | --- | --- | --- | --- | --- |
| 366 | 1.3.4.6 | **load resistors (2+1 spare)** |  | 15.11d | 2005-12-23 | 2006-01-17 |  | 1020.62d |  |  | 2010-12-30 |  | 136h |
| 367 | 1.3.4.6.1 | load resistor tube machining |  | 7.11d | 2005-12-23 | 2006-01-04 |  | 1020.62d | 0d | start no earlier than 2005-01-10 | 2010-12-30 | EXT_VENDOR | 64h |
| 368 | 1.3.4.6.2 | load resistor brazing |  | 6.22d | 2006-01-04 | 2006-01-13 | 367 | 1020.62d | 0d | start no earlier than 2005-01-10 | 2010-12-30 | EXT_VENDOR | 56h |
| 369 | 1.3.4.6.3 | load resistor QC |  | 0.89d | 2006-01-13 | 2006-01-16 | 368 | 1020.62d | 0d | start no earlier than 2005-01-10 | 2010-12-30 | OSG | 8h |
| 370 | 1.3.4.6.4 | load resistor assy |  | 0.89d | 2006-01-16 | 2006-01-17 | 369 | 1020.62d |  | start no earlier than 2005-01-10 | 2010-12-30 | OSG | 8h |
| 371 | 1.3.4.7 | **solar panels (4+1 spare)** |  | 67.56d | 2005-12-23 | 2006-04-10 |  | 968.18d |  |  | 2010-12-30 |  | 288h |
| 372 | 1.3.4.7.1 | solar panel lamination lead time |  | 1.9w | 2005-12-23 | 2006-01-13 |  | 968.18d | 0d | start no earlier than 2005-01-10 | 2010-12-30 |  |  |
| 373 | 1.3.4.7.2 | solar panel lead time |  | 3.17w | 2006-01-13 | 2006-02-17 | 372 | 968.18d | 0d | start no earlier than 2005-01-10 | 2010-12-30 |  |  |
| 374 | 1.3.4.7.3 | solar panel frame machining |  | 1.27w | 2006-02-17 | 2006-03-03 | 373 | 968.18d | 0d | start no earlier than 2005-01-10 | 2010-12-30 | EXT_VENDOR | 80h |
| 375 | 1.3.4.7.4 | solar panel assembly |  | 23.11d | 2006-03-03 | 2006-04-10 | 374 | 968.18d |  | start no earlier than 2005-01-10 | 2010-12-30 | MT | 208h |
| 376 | 1.3.4.8 | **wind generator** |  | 0d | 2005-12-23 | 2005-12-23 |  | 1035.73d |  |  | 2010-12-30 |  |  |
| 377 | 1.3.4.8.1 | wind generator lead time | milestone | 0d | 2005-12-23 | 2005-12-23 |  | 1035.73d | 0d | start no earlier than 2005-01-10 | 2010-12-30 |  |  |
| 378 | 1.3.4.8.2 | wind generator mast machining | milestone | 0d | 2005-12-23 | 2005-12-23 | 377 | 1035.73d | 0d | start no earlier than 2005-01-10 | 2010-12-30 | MA |  |
| 379 | 1.3.4.8.3 | wind generator cable lead time | milestone | 0d | 2005-12-23 | 2005-12-23 | 378 | 1035.73d | 0d | start no earlier than 2005-01-10 | 2010-12-30 |  |  |
| 380 | 1.3.4.8.4 | wind generator assembly | milestone | 0d | 2005-12-23 | 2005-12-23 | 379 | 1035.73d |  | start no earlier than 2005-01-10 | 2010-12-30 | OSG |  |
| 381 | 1.3.4.9 | **electronics** |  | 23.11d | 2005-12-23 | 2006-01-30 |  | 1012.62d |  |  | 2010-12-30 |  | 88h |
| 382 | 1.3.4.9.1 | power can electronics board fab | milestone | 0d | 2005-12-23 | 2005-12-23 |  | 1012.62d | 0d | start no earlier than 2005-01-10 | 2010-12-30 | EXT_VENDOR |  |
| 383 | 1.3.4.9.2 | power tracker lead time |  | 1.9w | 2005-12-23 | 2006-01-13 | 382 | 1012.62d | 0d | start no earlier than 2005-01-10 | 2010-12-30 |  |  |
| 384 | 1.3.4.9.3 | power can electronics assembly and board bringup |  | 0.89d | 2006-01-13 | 2006-01-16 | 383 | 1012.62d | 0d | start no earlier than 2005-01-10 | 2010-12-30 | ET | 8h |
| 385 | 1.3.4.9.4 | power can wiring harness |  | 1.27w | 2006-01-16 | 2006-01-30 | 384 | 1012.62d |  | start no earlier than 2005-01-10 | 2010-12-30 | ET | 80h |
| 386 | 1.3.4.10 | **chassis (1+1 spare)** |  | 54.22d | 2005-12-23 | 2006-03-20 |  | 981.51d |  |  | 2010-12-30 |  | 488h |
| 387 | 1.3.4.10.1 | MMC chassis endplates |  | 1.27w | 2005-12-23 | 2006-01-06 |  | 981.51d | 0d | start no earlier than 2005-01-10 | 2010-12-30 | EXT_VENDOR | 80h |
| 388 | 1.3.4.10.2 | MMC chassis rails |  | 2.54w | 2006-01-06 | 2006-02-03 | 387 | 981.51d | 0d | start no earlier than 2005-01-10 | 2010-12-30 | EXT_VENDOR | 160h |
| 389 | 1.3.4.10.3 | MMC chassis card guide |  | 1.9w | 2006-02-03 | 2006-02-24 | 388 | 981.51d | 0d | start no earlier than 2005-01-10 | 2010-12-30 | MA | 120h |
| 390 | 1.3.4.10.4 | MMC chassis clips |  | 1.9w | 2006-02-24 | 2006-03-17 | 389 | 981.51d | 0d | start no earlier than 2005-01-10 | 2010-12-30 | MA | 120h |
| 391 | 1.3.4.10.5 | MMC chassis assy |  | 0.89d | 2006-03-17 | 2006-03-20 | 390 | 981.51d |  | start no earlier than 2005-01-10 | 2010-12-30 | OSG | 8h |

Notes:
- 366: Bouy
- 367: Bouy
- 368: Bouy
- 369: Bouy
- 370: Bouy
- 371: Bouy
- 372: Bouy
- 373: Bouy
- 374: Bouy
- 375: Bouy
- 376: Bouy
- 377: Bouy
- 378: Bouy
- 379: Bouy
- 380: Bouy
- 381: Bouy
- 382: Bouy
- 383: Bouy
- 384: Bouy
- 385: Bouy
- 386: Bouy
- 387: Bouy
- 388: Bouy
- 389: Bouy
- 390: Bouy
- 391: Bouy

| ID | WBS | Task | Duration | Start | Finish | Predecessors | Total slack | Free slack | Constraint | Deadline | Resources | Work |
| --- | --- | --- | --- | --- | --- | --- | --- | --- | --- | --- | --- | --- |
| 392 | 1.3.4.11 | **housing (1 + 1 spare)** | 38.22d | 2005-12-23 | 2006-02-22 |  | 997.51d |  |  | 2010-12-30 |  | 344h |
| 393 | 1.3.4.11.1 | MMC housing machining | 2.54w | 2005-12-23 | 2006-01-20 |  | 997.51d | 0d | start no earlier than 2005-01-10 | 2010-12-30 | EXT_VENDOR | 160h |
| 394 | 1.3.4.11.2 | MMC housing brazing (incl shipping) | 1.27w | 2006-01-20 | 2006-02-03 | 393 | 997.51d | 0d | start no earlier than 2005-01-10 | 2010-12-30 | EXT_VENDOR | 80h |
| 395 | 1.3.4.11.3 | MMC housing anodization (incl shipping) | 1.27w | 2006-02-03 | 2006-02-17 | 394 | 997.51d | 0d | start no earlier than 2005-01-10 | 2010-12-30 | EXT_VENDOR | 80h |
| 396 | 1.3.4.11.4 | MMC housing QC (2x) | 0.89d | 2006-02-17 | 2006-02-20 | 395 | 997.51d | 0d | start no earlier than 2005-01-10 | 2010-12-30 | OSG | 8h |
| 397 | 1.3.4.11.5 | MMC housing pressure test | 1.78d | 2006-02-20 | 2006-02-22 | 396 | 997.51d |  | start no earlier than 2005-01-10 | 2010-12-30 | OSG | 16h |
| 398 | 1.3.4.12 | **endcap (1 + 1 spare)** | 31.11d | 2005-12-23 | 2006-02-10 |  | 1004.62d |  |  | 2010-12-30 |  | 120h |
| 399 | 1.3.4.12.1 | MMC endcap machining | 2.67d | 2005-12-23 | 2005-12-28 |  | 1004.62d | 0d | start no earlier than 2005-01-10 | 2010-12-30 | EXT_VENDOR | 24h |
| 400 | 1.3.4.12.2 | MMC endcap anodization (incl shipping) | 1.27w | 2005-12-28 | 2006-01-11 | 399 | 1004.62d | 0d | start no earlier than 2005-01-10 | 2010-12-30 | EXT_VENDOR | 80h |
| 401 | 1.3.4.12.3 | MMC endcap QC (2x) | 0.89d | 2006-01-11 | 2006-01-12 | 400 | 1004.62d | 0d | start no earlier than 2005-01-10 | 2010-12-30 | OSG | 8h |
| 402 | 1.3.4.12.4 | MMC bulkhead connectors lead time | 2.54w | 2006-01-12 | 2006-02-09 | 401 | 1004.62d | 0d | start no earlier than 2005-01-10 | 2010-12-30 |  |  |
| 403 | 1.3.4.12.5 | MMC endcap assembly | 0.89d | 2006-02-09 | 2006-02-10 | 402 | 1004.62d |  | start no earlier than 2005-01-10 | 2010-12-30 | OSG | 8h |
| 404 | 1.3.4.13 | **DPA** | 4.44d | 2005-12-23 | 2005-12-30 |  | 1031.29d |  |  | 2010-12-30 |  | 40h |
| 405 | 1.3.4.13.1 | DPA kit | 0.89d | 2005-12-23 | 2005-12-26 |  | 1031.29d | 0d | start no earlier than 2005-01-10 | 2010-12-30 | EXT_VENDOR | 8h |
| 406 | 1.3.4.13.2 | DPA board fab | 1.78d | 2005-12-26 | 2005-12-28 | 405 | 1031.29d | 0d | start no earlier than 2005-01-10 | 2010-12-30 | EXT_VENDOR | 16h |
| 407 | 1.3.4.13.3 | DPA mount | 0.89d | 2005-12-28 | 2005-12-29 | 406 | 1031.29d | 0d | start no earlier than 2005-01-10 | 2010-12-30 | EXT_VENDOR | 8h |
| 408 | 1.3.4.13.4 | DPA test | 0.89d | 2005-12-29 | 2005-12-30 | 407 | 1031.29d |  | start no earlier than 2005-01-10 | 2010-12-30 | OSG | 8h |
| 409 | 1.3.4.14 | **Backplane** | 4.44d | 2005-12-23 | 2005-12-30 |  | 1031.29d |  |  | 2010-12-30 |  | 40h |
| 410 | 1.3.4.14.1 | Backplane kit | 0.89d | 2005-12-23 | 2005-12-26 |  | 1031.29d | 0d | start no earlier than 2005-01-10 | 2010-12-30 | EXT_VENDOR | 8h |
| 411 | 1.3.4.14.2 | Backplane board fab | 1.78d | 2005-12-26 | 2005-12-28 | 410 | 1031.29d | 0d | start no earlier than 2005-01-10 | 2010-12-30 | EXT_VENDOR | 16h |
| 412 | 1.3.4.14.3 | Backplane mount | 0.89d | 2005-12-28 | 2005-12-29 | 411 | 1031.29d | 0d | start no earlier than 2005-01-10 | 2010-12-30 | EXT_VENDOR | 8h |
| 413 | 1.3.4.14.4 | Backplane test | 0.89d | 2005-12-29 | 2005-12-30 | 412 | 1031.29d |  | start no earlier than 2005-01-10 | 2010-12-30 | OSG | 8h |
| 414 | 1.3.4.15 | **Sidearm** | 31.11d | 2005-12-23 | 2006-02-10 |  | 1004.62d |  |  | 2010-12-30 |  | 280h |
| 415 | 1.3.4.15.1 | Sidearm kit | 1.27w | 2005-12-23 | 2006-01-06 |  | 1004.62d | 0d | start no earlier than 2005-01-10 | 2010-12-30 | EXT_VENDOR | 80h |
| 416 | 1.3.4.15.2 | Sidearm board fab | 1.27w | 2006-01-06 | 2006-01-20 | 415 | 1004.62d | 0d | start no earlier than 2005-01-10 | 2010-12-30 | EXT_VENDOR | 80h |
| 417 | 1.3.4.15.3 | Sidearm mount | 0.63w | 2006-01-20 | 2006-01-27 | 416 | 1004.62d | 0d | start no earlier than 2005-01-10 | 2010-12-30 | EXT_VENDOR | 40h |
| 418 | 1.3.4.15.4 | Sidearm bringup/config | 1.27w | 2006-01-27 | 2006-02-10 | 417 | 1004.62d |  | start no earlier than 2005-01-10 | 2010-12-30 | ET | 80h |

Notes:
- 392: Bouy
- 393: Bouy
- 394: Bouy
- 395: Bouy
- 396: Bouy
- 397: Bouy
- 398: Bouy
- 399: Bouy
- 400: Bouy
- 401: Bouy
- 402: Bouy
- 403: Bouy
- 404: Bouy
- 405: Bouy
- 406: Bouy
- 407: Bouy
- 408: Bouy
- 409: Bouy
- 410: Bouy
- 411: Bouy
- 412: Bouy
- 413: Bouy
- 414: Bouy
- 415: Bouy
- 416: Bouy
- 417: Bouy
- 418: Bouy

| ID | WBS | Task | Type | Duration | Start | Finish | Predecessors | Total slack | Free slack | Constraint | Deadline | Resources | Work |
| --- | --- | --- | --- | --- | --- | --- | --- | --- | --- | --- | --- | --- | --- |
| 419 | 1.3.4.16 | **RFIO** |  | 5.33d | 2005-12-23 | 2006-01-02 |  | 1030.4d |  |  | 2010-12-30 |  | 48h |
| 420 | 1.3.4.16.1 | RFIO kit |  | 0.89d | 2005-12-23 | 2005-12-26 |  | 1030.4d | 0d | start no earlier than 2005-01-10 | 2010-12-30 | EXT_VENDOR | 8h |
| 421 | 1.3.4.16.2 | RFIO board fab |  | 1.78d | 2005-12-26 | 2005-12-28 | 420 | 1030.4d | 0d | start no earlier than 2005-01-10 | 2010-12-30 | EXT_VENDOR | 16h |
| 422 | 1.3.4.16.3 | RFIO mount |  | 0.89d | 2005-12-28 | 2005-12-29 | 421 | 1030.4d | 0d | start no earlier than 2005-01-10 | 2010-12-30 | EXT_VENDOR | 8h |
| 423 | 1.3.4.16.4 | RFIO test |  | 1.78d | 2005-12-29 | 2006-01-02 | 422 | 1030.4d |  | start no earlier than 2005-01-10 | 2010-12-30 | OSG | 16h |
| 424 | 1.3.4.17 | **Fiber Optic Switch** |  | 0d | 2005-12-23 | 2005-12-23 |  | 1035.73d |  |  | 2010-12-30 |  |  |
| 425 | 1.3.4.17.1 | need significant EE time to support build and test | milestone | 0d | 2005-12-23 | 2005-12-23 |  | 1035.73d |  | start no earlier than 2005-01-10 | 2010-12-30 |  |  |
| 426 | 1.3.4.18 | **mounts** |  | 5.33d | 2005-12-23 | 2006-01-02 |  | 1030.4d |  |  | 2010-12-30 |  | 48h |
| 427 | 1.3.4.18.1 | inventory instrument mounts |  | 0.89d | 2005-12-23 | 2005-12-26 |  | 1030.4d | 0d | start no earlier than 2005-01-10 | 2010-12-30 | OSG | 8h |
| 428 | 1.3.4.18.2 | radiometer mounts | milestone | 0d | 2005-12-26 | 2005-12-26 | 427 | 1030.4d | 0d | start no earlier than 2005-01-10 | 2010-12-30 |  |  |
| 429 | 1.3.4.18.3 | SOON mounts | milestone | 0d | 2005-12-26 | 2005-12-26 | 428 | 1030.4d | 0d | start no earlier than 2005-01-10 | 2010-12-30 |  |  |
| 430 | 1.3.4.18.4 | nitrate mounts | milestone | 0d | 2005-12-26 | 2005-12-26 | 429 | 1030.4d | 0d | start no earlier than 2005-01-10 | 2010-12-30 |  |  |
| 431 | 1.3.4.18.5 | other instrument mounts fab |  | 0.63w | 2005-12-26 | 2006-01-02 | 430 | 1030.4d |  | start no earlier than 2005-01-10 | 2010-12-30 | MA | 40h |
| 432 | 1.3.4.19 | **software** |  | 0d | 2005-12-23 | 2005-12-23 |  | 1035.73d |  |  | 2010-12-30 |  |  |
| 433 | 1.3.4.19.1 | Metsys service | milestone | 0d | 2005-12-23 | 2005-12-23 |  | 1035.73d | 0d | start no earlier than 2005-01-10 | 2010-12-30 |  |  |
| 434 | 1.3.4.19.2 | ADCP service | milestone | 0d | 2005-12-23 | 2005-12-23 | 433 | 1035.73d | 0d | start no earlier than 2005-01-10 | 2010-12-30 |  |  |
| 435 | 1.3.4.19.3 | Serial CTD service | milestone | 0d | 2005-12-23 | 2005-12-23 | 434 | 1035.73d | 0d | start no earlier than 2005-01-10 | 2010-12-30 |  |  |
| 436 | 1.3.4.19.4 | Inductive CTD service | milestone | 0d | 2005-12-23 | 2005-12-23 | 435 | 1035.73d | 0d | start no earlier than 2005-01-10 | 2010-12-30 |  |  |
| 437 | 1.3.4.19.5 | Nitrate service | milestone | 0d | 2005-12-23 | 2005-12-23 | 436 | 1035.73d | 0d | start no earlier than 2005-01-10 | 2010-12-30 |  |  |
| 438 | 1.3.4.19.6 | CO2 service | milestone | 0d | 2005-12-23 | 2005-12-23 | 437 | 1035.73d | 0d | start no earlier than 2005-01-10 | 2010-12-30 |  |  |
| 439 | 1.3.4.19.7 | Radiometer service | milestone | 0d | 2005-12-23 | 2005-12-23 | 438 | 1035.73d | 0d | start no earlier than 2005-01-10 | 2010-12-30 |  |  |
| 440 | 1.3.4.19.8 | Fluorometer service | milestone | 0d | 2005-12-23 | 2005-12-23 | 439 | 1035.73d | 0d | start no earlier than 2005-01-10 | 2010-12-30 |  |  |
| 441 | 1.3.4.19.9 | Backscatter service | milestone | 0d | 2005-12-23 | 2005-12-23 | 440 | 1035.73d | 0d | start no earlier than 2005-01-10 | 2010-12-30 |  |  |
| 442 | 1.3.4.19.10 | metadata specification | milestone | 0d | 2005-12-23 | 2005-12-23 | 441 | 1035.73d |  | start no earlier than 2005-01-10 | 2010-12-30 | SE |  |

Notes:
- 419: Bouy
- 420: Bouy
- 421: Bouy
- 422: Bouy
- 423: Bouy
- 424: Bouy
- 425: Bouy
- 426: Bouy
- 427: Bouy
- 428: Bouy
- 429: Bouy
- 430: Bouy
- 431: Bouy
- 432: Bouy
- 433: Bouy
- 434: Bouy
- 435: Bouy
- 436: Bouy
- 437: Bouy
- 438: Bouy
- 439: Bouy
- 440: Bouy
- 441: Bouy
- 442: Bouy

| ID | WBS | Task | Type | Duration | Start | Finish | Predecessors | Total slack | Free slack | Constraint | Deadline | Resources | Work |
| --- | --- | --- | --- | --- | --- | --- | --- | --- | --- | --- | --- | --- | --- |
| 443 | 1.3.4.20 | **housing** |  | 18.67d | 2005-12-23 | 2006-01-23 |  | 1017.07d |  |  | 2010-12-30 |  | 168h |
| 444 | 1.3.4.20.1 | pager reset housing machining |  | 1.27w | 2005-12-23 | 2006-01-06 |  | 1017.07d | 0d | start no earlier than 2005-01-10 | 2010-12-30 | EXT_VENDOR | 80h |
| 445 | 1.3.4.20.2 | pager reset internal mounts |  | 1.27w | 2006-01-06 | 2006-01-20 | 444 | 1017.07d | 0d | start no earlier than 2005-01-10 | 2010-12-30 | EXT_VENDOR | 80h |
| 446 | 1.3.4.20.3 | pager reset pressure test |  | 0.89d | 2006-01-20 | 2006-01-23 | 445 | 1017.07d |  | start no earlier than 2005-01-10 | 2010-12-30 | OSG | 8h |
| 447 | 1.3.5 | **assembly** |  | 24.44d | 2008-05-28 | 2008-07-07 | 280 | 473.07d | 0d |  | 2010-12-30 |  | 220h |
| 448 | 1.3.5.1 | elevator winch |  | 0.89d | 2008-05-28 | 2008-05-29 |  | 473.07d | 0d | start no earlier than 2005-01-10 | 2010-12-30 | OSG | 8h |
| 449 | 1.3.5.2 | elevator rods |  | 0.89d | 2008-05-29 | 2008-05-30 | 448 | 473.07d | 0d | start no earlier than 2005-01-10 | 2010-12-30 | OSG | 8h |
| 450 | 1.3.5.3 | spool cable |  | 2.22d | 2008-05-30 | 2008-06-04 | 449 | 473.07d | 0d | start no earlier than 2005-01-10 | 2010-12-30 | OSG | 20h |
| 451 | 1.3.5.4 | cable install hardware |  | 1.33d | 2008-06-04 | 2008-06-05 | 450 | 473.07d | 0d | start no earlier than 2005-01-10 | 2010-12-30 | OSG | 12h |
| 452 | 1.3.5.5 | attach top and bottom plates, tie rods |  | 2.67d | 2008-06-05 | 2008-06-10 | 451 | 473.07d | 0d | start no earlier than 2005-01-10 | 2010-12-30 | MT | 24h |
| 453 | 1.3.5.6 | apply anti-fouling paint |  | 2.67d | 2008-06-10 | 2008-06-13 | 452 | 473.07d | 0d | start no earlier than 2005-01-10 | 2010-12-30 | EXT_VENDOR | 24h |
| 454 | 1.3.5.7 | paint logo |  | 0.44d | 2008-06-13 | 2008-06-16 | 453 | 473.07d | 0d | start no earlier than 2005-01-10 | 2010-12-30 | EXT_VENDOR | 4h |
| 455 | 1.3.5.8 | puck electronic assembly |  | 1.78d | 2008-06-16 | 2008-06-18 | 454 | 473.07d | 0d | start no earlier than 2005-01-10 | 2010-12-30 | OSG | 16h |
| 456 | 1.3.5.9 | puck potting |  | 0.63w | 2008-06-18 | 2008-06-25 | 455 | 473.07d | 0d | start no earlier than 2005-01-10 | 2010-12-30 | OSG | 40h |
| 457 | 1.3.5.10 | shore side RF installation |  | 1.78d | 2008-06-25 | 2008-06-27 | 456 | 473.07d | 0d | start no earlier than 2005-01-10 | 2010-12-30 | SUE | 16h |
| 458 | 1.3.5.11 | ship RF installation |  | 0.89d | 2008-06-27 | 2008-06-30 | 457 | 473.07d | 0d | start no earlier than 2005-01-10 | 2010-12-30 | OSG | 8h |
| 459 | 1.3.5.12 | MMC setup |  | 1.33d | 2008-06-30 | 2008-07-01 | 458 | 473.07d | 0d | start no earlier than 2005-01-10 | 2010-12-30 | SE | 12h |
| 460 | 1.3.5.13 | PC setup |  | 0.89d | 2008-07-01 | 2008-07-02 | 459 | 473.07d | 0d | start no earlier than 2005-01-10 | 2010-12-30 | SE | 8h |
| 461 | 1.3.5.14 | SIAM software setup |  | 1.33d | 2008-07-02 | 2008-07-04 | 460 | 473.07d | 0d | start no earlier than 2005-01-10 | 2010-12-30 | SE | 12h |
| 462 | 1.3.5.15 | pager reset assembly |  | 0.89d | 2008-07-04 | 2008-07-07 | 461 | 473.07d |  | start no earlier than 2005-01-10 | 2010-12-30 | OSG | 8h |
| 463 | 1.3.6 | **Integration and Test** |  | 96.71d | 2008-07-07 | 2008-12-05 | 447 | 473.07d | 0d |  | 2010-12-30 |  | 1206.4h |
| 464 | 1.3.6.1 | integration ready | milestone | 0d | 2008-07-07 | 2008-07-07 |  | 473.07d | 0d | start no earlier than 2005-01-10 | 2010-12-30 |  |  |
| 465 | 1.3.6.2 | anchor integration with cable |  | 1.33d | 2008-07-07 | 2008-07-08 | 464 | 473.07d | 0d | start no earlier than 2005-01-10 | 2010-12-30 | OSG | 12h |
| 466 | 1.3.6.3 | chassis checkout |  | 0.63w | 2008-07-08 | 2008-07-15 | 465 | 473.07d | 0d | start no earlier than 2005-01-10 | 2010-12-30 | OSG; EE | 80h |
| 467 | 1.3.6.4 | solar panel test |  | 0.27d | 2008-07-15 | 2008-07-16 | 466 | 473.07d | 0d | start no earlier than 2005-01-10 | 2010-12-30 | OSG | 2.4h |
| 468 | 1.3.6.5 | battery box test |  | 0.89d | 2008-07-16 | 2008-07-17 | 467 | 473.07d | 0d | start no earlier than 2005-01-10 | 2010-12-30 | OSG | 8h |
| 469 | 1.3.6.6 | pressure test pucks |  | 2.67d | 2008-07-17 | 2008-07-22 | 468 | 473.07d | 0d | start no earlier than 2005-01-10 | 2010-12-30 | OSG | 24h |
| 470 | 1.3.6.7 | verify puck operation |  | 0.44d | 2008-07-22 | 2008-07-22 | 469 | 473.07d | 0d | start no earlier than 2005-01-10 | 2010-12-30 | SE | 4h |
| 471 | 1.3.6.8 | integration ready | milestone | 0d | 2008-07-22 | 2008-07-22 | 470 | 473.07d | 0d | start no earlier than 2005-01-10 | 2010-12-30 |  |  |
| 472 | 1.3.6.9 | attach bridle to float |  | 0.89d | 2008-07-22 | 2008-07-23 | 471 | 473.07d | 0d | start no earlier than 2005-01-10 | 2010-12-30 | MT | 8h |
| 473 | 1.3.6.10 | attach tower to float |  | 0.89d | 2008-07-23 | 2008-07-24 | 472 | 473.07d | 0d | start no earlier than 2005-01-10 | 2010-12-30 | MT | 8h |
| 474 | 1.3.6.11 | install elevator |  | 1.78d | 2008-07-24 | 2008-07-28 | 473 | 473.07d | 0d | start no earlier than 2005-01-10 | 2010-12-30 | OSG | 16h |
| 475 | 1.3.6.12 | solar panel install |  | 1.78d | 2008-07-28 | 2008-07-30 | 474 | 473.07d | 0d | start no earlier than 2005-01-10 | 2010-12-30 | MT | 16h |
| 476 | 1.3.6.13 | solar panel door fitting |  | 0.63w | 2008-07-30 | 2008-08-06 | 475 | 473.07d | 0d | start no earlier than 2005-01-10 | 2010-12-30 | MA | 40h |
| 477 | 1.3.6.14 | battery box install |  | 0.89d | 2008-08-06 | 2008-08-07 | 476 | 473.07d | 0d | start no earlier than 2005-01-10 | 2010-12-30 | OSG | 8h |
| 478 | 1.3.6.15 | load dump install |  | 0.44d | 2008-08-07 | 2008-08-08 | 477 | 473.07d | 0d | start no earlier than 2005-01-10 | 2010-12-30 | OSG | 4h |
| 479 | 1.3.6.16 | power system wiring |  | 1.78d | 2008-08-08 | 2008-08-12 | 478 | 473.07d | 0d | start no earlier than 2005-01-10 | 2010-12-30 |  |  |
| 480 | 1.3.6.17 | open can test |  | 5.33d | 2008-08-12 | 2008-08-20 | 479 | 473.07d | 0d | start no earlier than 2005-01-10 | 2010-12-30 | SCI_TECH; SE | 96h |
| 481 | 1.3.6.18 | closed can test |  | 5.33d | 2008-08-20 | 2008-08-28 | 480 | 473.07d | 0d | start no earlier than 2005-01-10 | 2010-12-30 | SCI_TECH; SE | 96h |
| 482 | 1.3.6.19 | instrument rough installation |  | 2.67d | 2008-08-28 | 2008-09-02 | 481 | 473.07d | 0d | start no earlier than 2005-01-10 | 2010-12-30 | OSG | 24h |
| 483 | 1.3.6.20 | instrument clamp mods |  | 2.67d | 2008-09-02 | 2008-09-05 | 482 | 473.07d | 0d | start no earlier than 2005-01-10 | 2010-12-30 | MT | 24h |
| 484 | 1.3.6.21 | instrument painting |  | 1.78d | 2008-09-05 | 2008-09-09 | 483 | 473.07d | 0d | start no earlier than 2005-01-10 | 2010-12-30 | OSG [200%] | 32h |
| 485 | 1.3.6.22 | instrument final mount |  | 3.56d | 2008-09-09 | 2008-09-15 | 484 | 473.07d | 0d | start no earlier than 2005-01-10 | 2010-12-30 | OSG [200%] | 64h |
| 486 | 1.3.6.23 | instrument cable dressing |  | 3.56d | 2008-09-15 | 2008-09-19 | 485 | 473.07d | 0d | start no earlier than 2005-01-10 | 2010-12-30 | OSG [200%] | 64h |
| 487 | 1.3.6.24 | instrument final paint |  | 2.67d | 2008-09-19 | 2008-09-24 | 486 | 473.07d | 0d | start no earlier than 2005-01-10 | 2010-12-30 | OSG [200%] | 48h |
| 488 | 1.3.6.25 | test accoustic releases |  | 0.44d | 2008-09-24 | 2008-09-24 | 487 | 473.07d | 0d | start no earlier than 2005-01-10 | 2010-12-30 | OSG | 4h |
| 489 | 1.3.6.26 | final system checkout |  | 3.56d | 2008-09-24 | 2008-09-30 | 488 | 473.07d | 0d | start no earlier than 2005-01-10 | 2010-12-30 | SCI_TECH; OSG; SE | 96h |
| 490 | 1.3.6.27 | SSDS data stream checkout |  | 1.78d | 2008-09-30 | 2008-10-02 | 489 | 473.07d | 0d | start no earlier than 2005-01-10 | 2010-12-30 | IAG | 16h |
| 491 | 1.3.6.28 | SSDS server setup and maintenance I&T |  | 1.78d | 2008-10-02 | 2008-10-06 | 490 | 473.07d | 0d | start no earlier than 2005-01-10 | 2010-12-30 | IAG | 16h |
| 492 | 1.3.6.29 | SSDS/SIAM interface testing I&T | milestone | 0d | 2008-10-06 | 2008-10-06 | 491 | 473.07d | 0d | start no earlier than 2005-01-10 | 2010-12-30 | IAG |  |
| 493 | 1.3.6.30 | radio/SIAM integration test |  | 0.63w | 2008-10-06 | 2008-10-13 | 492 | 473.07d | 0d | start no earlier than 2005-01-10 | 2010-12-30 | SE; SUE | 80h |
| 494 | 1.3.6.31 | RF infrastructure end to end test |  | 1.78d | 2008-10-13 | 2008-10-15 | 493 | 473.07d | 0d | start no earlier than 2005-01-10 | 2010-12-30 | SE; SUE | 32h |
| 495 | 1.3.6.32 | software/electrical instrument integration |  | 13.33d | 2008-10-15 | 2008-11-05 | 494 | 473.07d | 0d | start no earlier than 2005-01-10 | 2010-12-30 | SE | 120h |
| 496 | 1.3.6.33 | SIAM radio test |  | 0.89d | 2008-11-05 | 2008-11-06 | 495 | 473.07d | 0d | start no earlier than 2005-01-10 | 2010-12-30 | SE | 8h |
| 497 | 1.3.6.34 | SIAM unit test |  | 1.78d | 2008-11-06 | 2008-11-10 | 496 | 473.07d | 0d | start no earlier than 2005-01-10 | 2010-12-30 | SE | 16h |
| 498 | 1.3.6.35 | SIAM nightly test operation and analysis |  | 0.63w | 2008-11-10 | 2008-11-17 | 497 | 473.07d | 0d | start no earlier than 2005-01-10 | 2010-12-30 | ST | 40h |
| 499 | 1.3.6.36 | SIAM data checks |  | 8d | 2008-11-17 | 2008-11-28 | 498 | 473.07d | 0d | start no earlier than 2005-01-10 | 2010-12-30 | SE | 72h |
| 500 | 1.3.6.37 | SIAM atp tests |  | 2.67d | 2008-11-28 | 2008-12-03 | 499 | 473.07d | 0d | start no earlier than 2005-01-10 | 2010-12-30 | SE | 24h |
| 501 | 1.3.6.38 | pager reset verify operation |  | 0.44d | 2008-12-03 | 2008-12-04 | 500 | 473.07d | 0d | start no earlier than 2005-01-10 | 2010-12-30 | OSG | 4h |
| 502 | 1.3.6.39 | Test in tank |  | 0.89d | 2008-12-04 | 2008-12-05 | 501 | 473.07d |  | start no earlier than 2005-01-10 | 2010-12-30 |  |  |

Notes:
- 443: Bouy
- 444: Bouy
- 445: Bouy
- 446: Bouy
- 447: Bouy
- 448: Bouy
- 449: Bouy
- 450: Bouy
- 451: Bouy
- 452: Bouy
- 453: Bouy
- 454: Bouy
- 455: Bouy
- 456: Bouy
- 457: Bouy
- 458: Bouy
- 459: Bouy
- 460: Bouy
- 461: Bouy
- 462: Bouy
- 463: Bouy
- 464: Bouy
- 465: Bouy
- 466: Bouy
- 467: Bouy
- 468: Bouy
- 469: Bouy
- 470: Bouy
- 471: Bouy
- 472: Bouy
- 473: Bouy
- 474: Bouy
- 475: Bouy
- 476: Bouy
- 477: Bouy
- 478: Bouy
- 479: Bouy
- 480: Bouy
- 481: Bouy
- 482: Bouy
- 483: Bouy
- 484: Bouy
- 485: Bouy
- 486: Bouy
- 487: Bouy
- 488: Bouy
- 489: Bouy
- 490: Bouy
- 491: Bouy
- 492: Bouy
- 493: Bouy
- 494: Bouy
- 495: Bouy
- 496: Bouy
- 497: Bouy
- 498: Bouy
- 499: Bouy
- 500: Bouy
- 501: Bouy
- 502: MS

| ID | WBS | Task | Type | Duration | Start | Finish | Predecessors | Total slack | Free slack | Constraint | Deadline | Resources | Work |
| --- | --- | --- | --- | --- | --- | --- | --- | --- | --- | --- | --- | --- | --- |
| 503 | 1.3.7 | **test and debug** |  | 2.67d | 2008-12-05 | 2008-12-10 | 463 | 473.07d | 0d |  | 2010-12-30 |  | 24h |
| 504 | 1.3.7.1 | SSDS device ID management T/D | milestone | 0d | 2008-12-05 | 2008-12-05 |  | 473.07d | 0d | start no earlier than 2005-01-10 | 2010-12-30 | IAG |  |
| 505 | 1.3.7.2 | SSDS QC plots T/D | milestone | 0d | 2008-12-05 | 2008-12-05 | 504 | 473.07d | 0d | start no earlier than 2005-01-10 | 2010-12-30 | IAG |  |
| 506 | 1.3.7.3 | SSDS API T/D | milestone | 0d | 2008-12-05 | 2008-12-05 | 505 | 473.07d | 0d | start no earlier than 2005-01-10 | 2010-12-30 | IAG |  |
| 507 | 1.3.7.4 | SSDS external access T/D | milestone | 0d | 2008-12-05 | 2008-12-05 | 506 | 473.07d | 0d | start no earlier than 2005-01-10 | 2010-12-30 | IAG |  |
| 508 | 1.3.7.5 | SSDS metadata input T/D | milestone | 0d | 2008-12-05 | 2008-12-05 | 507 | 473.07d | 0d | start no earlier than 2005-01-10 | 2010-12-30 | IAG |  |
| 509 | 1.3.7.6 | SIAM inevitable junk |  | 2.67d | 2008-12-05 | 2008-12-10 | 508 | 473.07d |  | start no earlier than 2005-01-10 | 2010-12-30 | SE | 24h |
| 510 | 1.3.8 | **Deployment** |  | 4.11d | 2008-12-10 | 2008-12-16 | 503 | 473.07d |  |  | 2010-12-30 |  | 52h |
| 511 | 1.3.8.1 | move to dock |  | 0.89d | 2008-12-10 | 2008-12-11 |  | 473.07d | 0d | start no earlier than 2005-01-10 | 2010-12-30 | OSG [400%] | 32h |
| 512 | 1.3.8.2 | load pt sur |  | 0.22d | 2008-12-11 | 2008-12-11 | 511 | 473.07d | 0d | start no earlier than 2005-01-10 | 2010-12-30 | OSG [400%] | 8h |
| 513 | 1.3.8.3 | deploy |  | 0.22d | 2008-12-11 | 2008-12-11 | 512 | 473.07d | 0d | start no earlier than 2005-01-10 | 2010-12-30 | OSG [400%] | 8h |
| 514 | 1.3.8.4 | unload |  | 0.11d | 2008-12-11 | 2008-12-11 | 513 | 473.07d | 0d | start no earlier than 2005-01-10 | 2010-12-30 | OSG [400%] | 4h |
| 515 | 1.3.8.5 | sensor cleaning | milestone | 0d | 2008-12-11 | 2008-12-11 | 514 | 473.07d | 0d | start no earlier than 2005-01-10 | 2010-12-30 | OSG |  |
| 516 | 1.3.8.6 | disassemble buoy | milestone | 0d | 2008-12-11 | 2008-12-11 | 515 | 473.07d | 0d | start no earlier than 2005-01-10 | 2010-12-30 | OSG |  |
| 517 | 1.3.8.7 | instrument data transfer | milestone | 0d | 2008-12-11 | 2008-12-11 | 516 | 473.07d | 0d | start no earlier than 2005-01-10 | 2010-12-30 | OSG |  |
| 518 | 1.3.8.8 | instrument post calibration | milestone | 0d | 2008-12-11 | 2008-12-11 | 517 | 473.07d | 0d | start no earlier than 2005-01-10 | 2010-12-30 | OSG |  |
| 519 | 1.3.8.9 | Integrate with RIN |  | 0.89d | 2008-12-11 | 2008-12-12 | 518 | 473.07d | 0d | start no earlier than 2005-01-10 | 2010-12-30 |  |  |
| 520 | 1.3.8.10 | Test in shallow water with AUV |  | 0.89d | 2008-12-12 | 2008-12-15 | 519 | 473.07d | 0d | start no earlier than 2005-01-10 | 2010-12-30 |  |  |
| 521 | 1.3.8.11 | Install on MARS |  | 0.89d | 2008-12-15 | 2008-12-16 | 520 | 473.07d |  | start no earlier than 2005-01-10 | 2010-12-30 |  |  |
| 523 | 1.3.9 | **Additional unclassified taskings** |  | 88.89d | 2005-01-10 | 2005-05-30 |  | 1296d |  |  | 2010-12-30 |  | 416h |
| 524 | 1.3.9.1 | initial config meeting | milestone | 0d | 2005-01-10 | 2005-01-10 |  | 1384.89d |  | start no earlier than 2005-01-10 | 2010-12-30 |  |  |
| 525 | 1.3.9.2 | scheduling |  | 12.7w | 2005-01-11 | 2005-05-30 |  | 1296d |  | start no earlier than 2005-01-10 | 2010-12-30 | OSG [5%] | 40h |
| 526 | 1.3.9.3 | requirements gathering and review |  | 12.7w | 2005-01-11 | 2005-05-30 |  | 1296d |  | start no earlier than 2005-01-10 | 2010-12-30 | OSG [5%] | 40h |
| 527 | 1.3.9.4 | instrument data stream monitoring |  | 2.67d | 2005-01-11 | 2005-01-13 |  | 1382.22d |  | start no earlier than 2005-01-10 | 2010-12-30 | SCI_TECH; SE; OSG | 72h |
| 528 | 1.3.9.5 | power system data monitoring |  | 17.78d | 2005-01-11 | 2005-02-07 |  | 1367.11d |  | start no earlier than 2005-01-10 | 2010-12-30 | EE [5%]; OSG [5%]; SE [5%] | 24h |
| 529 | 1.3.9.6 | mmc/engr data monitoring |  | 0.89d | 2005-01-11 | 2005-01-11 |  | 1384d |  | start no earlier than 2005-01-10 | 2010-12-30 | SYS_ENG; OSG | 16h |
| 530 | 1.3.9.7 | Status meetings |  | 0.63w | 2005-01-11 | 2005-01-17 |  | 1380.44d |  | start no earlier than 2005-01-10 | 2010-12-30 | SYS_ENG | 40h |
| 531 | 1.3.9.8 | post deployment meeting |  | 0.44d | 2005-01-11 | 2005-01-11 |  | 1384.44d |  | start no earlier than 2005-01-10 | 2010-12-30 | SYS_ENG | 4h |
| 532 | 1.3.9.9 | other meetings |  | 0.63w | 2005-01-11 | 2005-01-17 |  | 1380.44d |  | start no earlier than 2005-01-10 | 2010-12-30 | SYS_ENG | 40h |
| 533 | 1.3.9.10 | overhead |  | 2.67d | 2005-01-11 | 2005-01-13 |  | 1382.22d |  | start no earlier than 2005-01-10 | 2010-12-30 | SYS_ENG | 24h |
| 534 | 1.3.9.11 | supervise machine shop |  | 88.89d | 2005-01-11 | 2005-05-30 |  | 1296d |  | start no earlier than 2005-01-10 | 2010-12-30 | OSG [2%] | 16h |
| 535 | 1.3.9.12 | outside mechanical P.O.s |  | 48.89d | 2005-01-11 | 2005-03-28 |  | 1336d |  | start no earlier than 2005-01-10 | 2010-12-30 | OSG [10%] | 44h |
| 536 | 1.3.9.13 | mechanical material orders |  | 88.89d | 2005-01-11 | 2005-05-30 |  | 1296d |  | start no earlier than 2005-01-10 | 2010-12-30 | OSG [5%] | 40h |
| 537 | 1.3.9.14 | buoy parts inventory |  | 1.78d | 2005-01-11 | 2005-01-12 |  | 1383.11d |  | start no earlier than 2005-01-10 | 2010-12-30 | OSG | 16h |

Notes:
- 503: Bouy
- 504: Bouy
- 505: Bouy
- 506: Bouy
- 507: Bouy
- 508: Bouy
- 509: Bouy
- 510: Bouy
- 511: Bouy
- 512: Bouy
- 513: Bouy
- 514: Bouy
- 515: Bouy
- 516: Bouy
- 517: Bouy
- 518: Bouy
- 519: MS
- 520: MS
- 521: MS
- 523: Bouy
- 524: Bouy
- 525: Bouy
- 526: Bouy
- 527: Bouy
- 528: Bouy
- 529: Bouy
- 530: Bouy
- 531: Bouy
- 532: Bouy
- 533: Bouy
- 534: Bouy
- 535: Bouy
- 536: Bouy
- 537: Bouy

| ID | WBS | Task | Duration | Start | Finish | Total slack | Constraint | Deadline |
| --- | --- | --- | --- | --- | --- | --- | --- | --- |
| 538 | 1.3.10 | **Altex Vehicle** | 26.67d | 2005-01-11 | 2005-02-21 | 1358.22d |  | 2010-12-30 |
| 539 | 1.3.10.1 | Refurb ALTEX vehicle | 26.67d | 2005-01-11 | 2005-02-21 | 1358.22d | start no earlier than 2005-01-10 | 2010-12-30 |

Notes:
- 538: MS
- 539: MS
