# AUV Docking 2005rev1

Schedule from MS Project, 2005-01-03 to 2005-06-22, 9 hours a day, costs in $.
MBARI

## Calendars

- Standard: Mon-Fri 08:00-12:00, 13:00-17:00; Sat-Sun off.

## Resources

| Resource | Rate |
| --- | --- |
| AUV Fabricator #1 | 75 |
| EE | 100 |
| ME | 100 |

## Schedule

| ID | WBS | Task | Duration | Start | Finish | Predecessors | Total slack | Free slack | Constraint | Deadline | Work | Cost |
| --- | --- | --- | --- | --- | --- | --- | --- | --- | --- | --- | --- | --- |
| 1 | 1 | **AUV Docking Project** | 109.25d? | 2005-01-03 | 2005-06-22 |  | 1280.97d |  |  | 2010-12-30 | 769.95h | 57,746.25 |
| 2 | 1.1 | **AUV** | 109.25d? | 2005-01-03 | 2005-06-22 |  | 1280.97d |  |  | 2010-12-30 | 769.95h | 57,746.25 |
| 3 | 1.1.1 | **design** | 11.33d? | 2005-01-03 | 2005-01-19 |  | 1298.64d | 0d |  | 2010-12-30 |  |  |
| 4 | 1.1.1.1 | **Communications** | 6.33d | 2005-01-03 | 2005-01-12 |  | 1303.64d |  |  | 2010-12-30 |  |  |
| 5 | 1.1.1.1.1 | Integrate acoustic modem on AUV | 1d | 2005-01-11 | 2005-01-12 |  | 1303.64d |  | start no earlier than 2005-01-10 | 2010-12-30 |  |  |
| 6 | 1.1.1.1.2 | Integrate network comm device | 1d | 2005-01-03 | 2005-01-04 |  | 1308.97d |  |  | 2010-12-30 |  |  |
| 7 | 1.1.1.2 | **Fairing, Frame, Housing** | 1d | 2005-01-11 | 2005-01-12 |  | 1303.64d |  |  | 2010-12-30 |  |  |
| 8 | 1.1.1.2.1 | Prototype Latch | 1d | 2005-01-11 | 2005-01-12 |  | 1303.64d |  | start no earlier than 2005-01-10 | 2010-12-30 |  |  |
| 9 | 1.1.1.2.2 | Integrate latch onto AUV | 1d | 2005-01-11 | 2005-01-12 |  | 1303.64d |  | start no earlier than 2005-01-10 | 2010-12-30 |  |  |
| 10 | 1.1.1.3 | **Guidance navigation and Control** | 1d | 2005-01-11 | 2005-01-12 |  | 1303.64d |  |  | 2010-12-30 |  |  |
| 11 | 1.1.1.3.1 | **Obstacle Avoidance** | 1d | 2005-01-11 | 2005-01-12 |  | 1303.64d |  |  | 2010-12-30 |  |  |
| 12 | 1.1.1.3.1.1 | Algorithm development | 1d | 2005-01-11 | 2005-01-12 |  | 1303.64d |  | start no earlier than 2005-01-10 | 2010-12-30 |  |  |
| 13 | 1.1.1.3.1.2 | Tests at sea | 1d | 2005-01-11 | 2005-01-12 |  | 1303.64d |  | start no earlier than 2005-01-10 | 2010-12-30 |  |  |
| 14 | 1.1.1.4 | Location Devices | 1d? | 2005-01-03 | 2005-01-04 |  | 1308.97d |  |  | 2010-12-30 |  |  |
| 15 | 1.1.1.5 | Propulsion and control surfaces | 1d? | 2005-01-03 | 2005-01-04 |  | 1308.97d |  |  | 2010-12-30 |  |  |
| 16 | 1.1.1.6 | **Wet Cables and Connectors** | 1d | 2005-01-11 | 2005-01-12 |  | 1303.64d |  |  | 2010-12-30 |  |  |
| 17 | 1.1.1.6.1 | Build prototype/int. COTS | 1d | 2005-01-11 | 2005-01-12 |  | 1303.64d |  | start no earlier than 2005-01-10 | 2010-12-30 |  |  |
| 18 | 1.1.1.7 | **Power** | 1d | 2005-01-11 | 2005-01-12 |  | 1303.64d |  |  | 2010-12-30 |  |  |
| 19 | 1.1.1.7.1 | Build prototype/int. COTS | 1d | 2005-01-11 | 2005-01-12 |  | 1303.64d |  | start no earlier than 2005-01-10 | 2010-12-30 |  |  |
| 20 | 1.1.1.8 | **AUV reliability** | 6d | 2005-01-11 | 2005-01-19 |  | 1298.64d |  |  | 2010-12-30 |  |  |
| 21 | 1.1.1.8.1 | **Battery reliability** | 4d | 2005-01-11 | 2005-01-17 |  | 1300.64d |  |  | 2010-12-30 |  |  |
| 22 | 1.1.1.8.1.1 | Cell balancing | 1d | 2005-01-11 | 2005-01-12 |  | 1300.64d | 0d | start no earlier than 2005-01-10 | 2010-12-30 |  |  |
| 23 | 1.1.1.8.1.2 | Oil conservation | 1d | 2005-01-12 | 2005-01-13 | 22 | 1300.64d | 0d | start no earlier than 2005-01-10 | 2010-12-30 |  |  |
| 24 | 1.1.1.8.1.3 | Auto battery recharge | 1d | 2005-01-13 | 2005-01-14 | 23 | 1300.64d | 0d | start no earlier than 2005-01-10 | 2010-12-30 |  |  |
| 25 | 1.1.1.8.1.4 | Tank test for 96 hours | 1d | 2005-01-14 | 2005-01-17 | 24 | 1300.64d |  | start no earlier than 2005-01-10 | 2010-12-30 |  |  |

Notes:
- 2: MS
- 5: MS
- 8: MS
- 9: MS
- 11: MS
- 12: MS
- 13: MS
- 17: MS
- 19: MS
- 20: MS
- 21: MS
- 22: MS
- 23: MS
- 24: MS
- 25: MS

| ID | WBS | Task | Type | Duration | Start | Finish | Predecessors | Total slack | Free slack | Constraint | Deadline | Resources | Work | Cost |
| --- | --- | --- | --- | --- | --- | --- | --- | --- | --- | --- | --- | --- | --- | --- |
| 26 | 1.1.1.8.2 | **Tailcone reliability** |  | 2d | 2005-01-11 | 2005-01-13 |  | 1302.64d |  |  | 2010-12-30 |  |  |  |
| 27 | 1.1.1.8.2.1 | Prop seal life |  | 1d | 2005-01-11 | 2005-01-12 |  | 1302.64d | 0d | start no earlier than 2005-01-10 | 2010-12-30 |  |  |  |
| 28 | 1.1.1.8.2.2 | Lin act pot life |  | 1d | 2005-01-12 | 2005-01-13 | 27 | 1302.64d |  | start no earlier than 2005-01-10 | 2010-12-30 |  |  |  |
| 29 | 1.1.1.8.3 | **Connector reliability** |  | 2d | 2005-01-11 | 2005-01-13 |  | 1302.64d |  |  | 2010-12-30 |  |  |  |
| 30 | 1.1.1.8.3.1 | Ground fault detection |  | 1d | 2005-01-11 | 2005-01-12 |  | 1302.64d | 0d | start no earlier than 2005-01-10 | 2010-12-30 |  |  |  |
| 31 | 1.1.1.8.3.2 | O-ring life |  | 1d | 2005-01-12 | 2005-01-13 | 30 | 1302.64d |  | start no earlier than 2005-01-10 | 2010-12-30 |  |  |  |
| 32 | 1.1.1.8.4 | **Software reliability** |  | 6d | 2005-01-11 | 2005-01-19 |  | 1298.64d |  |  | 2010-12-30 |  |  |  |
| 33 | 1.1.1.8.4.1 | Auto-reboot after docking |  | 1d | 2005-01-11 | 2005-01-12 |  | 1298.64d | 0d | start no earlier than 2005-01-10 | 2010-12-30 |  |  |  |
| 34 | 1.1.1.8.4.2 | Tank test for 96 hours |  | 5d | 2005-01-12 | 2005-01-19 | 33 | 1298.64d |  | start no earlier than 2005-01-10 | 2010-12-30 |  |  |  |
| 35 | 1.1.2 | Preliminary Design Review | milestone | 1d? | 2005-01-19 | 2005-01-20 | 163, 3 | 1298.64d | 0d |  |  |  |  |  |
| 36 | 1.1.3 | Critical Design Review |  | 1d? | 2005-01-20 | 2005-01-21 | 35 | 1298.64d | 17.67d |  |  |  |  |  |
| 38 | 1.1.4 | **purchasing** |  | 40.25d? | 2005-02-18 | 2005-04-25 | 36, 166 | 1280.97d | 0d |  | 2010-12-30 |  | 90h | 6,750 |
| 39 | 1.1.4.1 | **quote and order Fairings** |  | 10d | 2005-02-18 | 2005-03-08 |  | 1280.97d | 0d |  | 2010-12-30 |  |  |  |
| 40 | 1.1.4.1.1 | Delivery time |  | 10d | 2005-02-18 | 2005-03-08 |  | 1280.97d |  |  |  |  |  |  |
| 41 | 1.1.4.2 | **quote and order Pressure Vessel** |  | 10d? | 2005-03-08 | 2005-03-23 | 39 | 1280.97d | 20.25d |  |  |  |  |  |
| 42 | 1.1.4.2.1 | Benthos Speres |  | 0.25d | 2005-03-08 | 2005-03-08 |  | 1280.97d | 0d |  |  |  |  |  |
| 43 | 1.1.4.2.2 | Other Pressure Vessels (TBD) |  | 1d? | 2005-03-08 | 2005-03-09 | 42 | 1280.97d | 0d |  |  |  |  |  |
| 44 | 1.1.4.2.3 | Delivery time |  | 10d | 2005-03-08 | 2005-03-23 |  | 1301.22d |  |  |  |  |  |  |
| 45 | 1.1.4.3 | **quote and order water tight connectors** |  | 10d | 2005-03-09 | 2005-03-24 | 43 | 1280.97d | 19d |  |  |  |  |  |
| 46 | 1.1.4.3.1 | Vendor 1 |  | 0.5d | 2005-03-09 | 2005-03-10 |  | 1280.97d | 0d |  |  |  |  |  |
| 47 | 1.1.4.3.2 | Vendor 2 |  | 0.5d | 2005-03-10 | 2005-03-10 | 46 | 1280.97d | 0d |  |  |  |  |  |
| 48 | 1.1.4.3.3 | Vendor 3 |  | 0.5d | 2005-03-10 | 2005-03-11 | 47 | 1280.97d | 0d |  |  |  |  |  |
| 49 | 1.1.4.3.4 | Delivery time |  | 10d | 2005-03-09 | 2005-03-24 |  | 1299.97d |  |  |  |  |  |  |
| 50 | 1.1.4.4 | **Quote and Order Syntactic Foam** |  | 10d | 2005-03-11 | 2005-03-28 | 48 | 1280.97d | 35.25d |  | 2010-12-30 | AUV Fabricator #1 | 90h | 6,750 |
| 51 | 1.1.4.4.1 | Drawing Package Preparation |  | 0.25d | 2005-03-11 | 2005-03-11 |  | 1280.97d | 0d | start no earlier than 2005-01-10 | 2010-12-30 |  |  |  |
| 52 | 1.1.4.4.2 | Vendor Quoting/Contracting |  | 0.25d | 2005-03-11 | 2005-03-11 | 51 | 1280.97d | 0d | start no earlier than 2005-01-10 | 2010-12-30 |  |  |  |
| 53 | 1.1.4.4.3 | Delivery time |  | 10d | 2005-03-11 | 2005-03-28 |  | 1298.47d |  |  |  |  |  |  |

Notes:
- 26: MS
- 27: MS
- 28: MS
- 29: MS
- 30: MS
- 31: MS
- 32: MS
- 33: MS
- 34: MS
- 50: HT
- 51: HT
- 52: HT

| ID | WBS | Task | Duration | Start | Finish | Predecessors | Total slack | Free slack | Constraint | Deadline | Resources | Work | Cost |
| --- | --- | --- | --- | --- | --- | --- | --- | --- | --- | --- | --- | --- | --- |
| 54 | 1.1.4.5 | **Quote and order Custom Circuit Board** | 10d | 2005-03-11 | 2005-03-29 | 52 | 1280.97d | 17d |  |  |  |  |  |
| 55 | 1.1.4.5.1 | Drawing Package Preparation | 1d | 2005-03-11 | 2005-03-14 |  | 1280.97d | 0d | start no earlier than 2005-01-10 | 2010-12-30 |  |  |  |
| 56 | 1.1.4.5.2 | Vendor Quoting/Contracting | 1d | 2005-03-14 | 2005-03-16 | 55 | 1280.97d | 0d | start no earlier than 2005-01-10 | 2010-12-30 |  |  |  |
| 57 | 1.1.4.5.3 | Delivery time | 10d | 2005-03-11 | 2005-03-29 |  | 1297.97d |  |  |  |  |  |  |
| 58 | 1.1.4.6 | **Quote and order Electronics** | 10d | 2005-03-16 | 2005-03-31 | 56 | 1280.97d |  |  |  |  |  |  |
| 59 | 1.1.4.6.1 | DVL | 1d | 2005-03-16 | 2005-03-17 |  | 1280.97d | 0d |  |  |  |  |  |
| 60 | 1.1.4.6.2 | USBL | 1d | 2005-03-17 | 2005-03-18 | 59 | 1280.97d | 0d |  |  |  |  |  |
| 61 | 1.1.4.6.3 | RF comms | 1d | 2005-03-18 | 2005-03-21 | 60 | 1280.97d | 0d |  |  |  |  |  |
| 62 | 1.1.4.6.4 | GPS suite | 1d | 2005-03-21 | 2005-03-22 | 61 | 1280.97d | 0d |  |  |  |  |  |
| 63 | 1.1.4.6.5 | AHRS (Crossbow?) | 1d | 2005-03-22 | 2005-03-23 | 62 | 1280.97d | 0d |  |  |  |  |  |
| 64 | 1.1.4.6.6 | Delivery time | 10d | 2005-03-16 | 2005-03-31 |  | 1295.97d |  |  |  |  |  |  |
| 65 | 1.1.4.7 | **Quote and Order Tailcone Assembly** | 10d | 2005-03-23 | 2005-04-07 | 63 | 1280.97d | 0d |  |  |  |  |  |
| 66 | 1.1.4.7.1 | Delivery time | 10d | 2005-03-23 | 2005-04-07 |  | 1280.97d |  |  |  |  |  |  |
| 67 | 1.1.4.8 | **Quote and Order Batteries** | 10d | 2005-04-07 | 2005-04-25 | 65 | 1280.97d |  |  |  |  |  |  |
| 68 | 1.1.4.8.1 | Delivery time | 10d | 2005-04-07 | 2005-04-25 |  | 1280.97d |  |  |  |  |  |  |
| 69 | 1.1.5 | **fabrication of sub assemblies** | 12d | 2005-04-25 | 2005-05-12 | 38 | 1280.97d | 0d |  | 2010-12-30 |  | 610.2h | 45,765 |
| 70 | 1.1.5.1 | **Custom Printed Circuit Board Fabrication** | 4d | 2005-04-25 | 2005-04-29 | 54 | 1288.97d |  |  | 2010-12-30 | AUV Fabricator #1 | 99h | 7,425 |
| 71 | 1.1.5.1.1 | **MEH Power Board Fabrication** | 3d | 2005-04-25 | 2005-04-28 |  | 1289.97d |  |  | 2010-12-30 | AUV Fabricator #1 | 27h | 2,025 |
| 72 | 1.1.5.1.1.1 | Component installation | 2d | 2005-04-25 | 2005-04-27 |  | 1289.97d | 0d | start no earlier than 2005-01-10 | 2010-12-30 |  |  |  |
| 73 | 1.1.5.1.1.2 | Burn-in & test | 1d | 2005-04-27 | 2005-04-28 | 72 | 1289.97d |  | start no earlier than 2005-01-10 | 2010-12-30 |  |  |  |
| 74 | 1.1.5.1.2 | **Junction Box PCB Fabrication** | 4d | 2005-04-25 | 2005-04-29 |  | 1288.97d |  |  | 2010-12-30 | AUV Fabricator #1 | 36h | 2,700 |
| 76 | 1.1.5.1.2.1 | Potting | 1d | 2005-04-27 | 2005-04-28 |  | 1288.97d | 0d |  |  |  |  |  |
| 77 | 1.1.5.1.2.2 | Burn-in & test | 1d | 2005-04-28 | 2005-04-29 | 76 | 1288.97d |  | start no earlier than 2005-01-10 | 2010-12-30 |  |  |  |
| 78 | 1.1.5.2 | **Pressure Vessel Fabrication** | 10.5d | 2005-04-25 | 2005-05-10 | 41 | 1282.47d |  |  | 2010-12-30 | AUV Fabricator #1 | 175.5h | 13,162.5 |
| 79 | 1.1.5.2.1 | **MEH Sphere** | 10.5d | 2005-04-25 | 2005-05-10 |  | 1282.47d |  |  |  |  | 72h | 5,400 |
| 80 | 1.1.5.2.1.1 | Threaded Insert Frame Fabrication | 1d | 2005-04-25 | 2005-04-26 |  | 1282.47d | 0d | start no earlier than 2005-01-10 | 2010-12-30 |  |  |  |
| 81 | 1.1.5.2.1.2 | Urethane Base Molding | 1d | 2005-04-26 | 2005-04-27 | 80 | 1282.47d | 0d | start no earlier than 2005-01-10 | 2010-12-30 |  |  |  |
| 82 | 1.1.5.2.1.3 | Mounting Plate Installation | 1d | 2005-04-27 | 2005-04-28 | 81 | 1282.47d | 0d | start no earlier than 2005-01-10 | 2010-12-30 |  |  |  |
| 83 | 1.1.5.2.1.4 | Strobe and battery | 0.5d | 2005-04-28 | 2005-04-29 | 82 | 1282.47d | 0d |  |  | AUV Fabricator #1 | 4.5h | 337.5 |
| 84 | 1.1.5.2.1.5 | LBL/USBL Electronics | 0.5d | 2005-04-29 | 2005-04-29 | 83 | 1282.47d | 0d |  |  | AUV Fabricator #1 | 4.5h | 337.5 |
| 85 | 1.1.5.2.1.6 | Free Wave Modem and Hub | 0.5d | 2005-04-29 | 2005-05-02 | 84 | 1282.47d | 0d |  |  | AUV Fabricator #1 | 4.5h | 337.5 |
| 86 | 1.1.5.2.1.7 | PC104 Stack | 0.5d | 2005-05-02 | 2005-05-02 | 85 | 1282.47d | 0d |  |  | AUV Fabricator #1 | 4.5h | 337.5 |
| 87 | 1.1.5.2.1.8 | CTD Board Sets | 0.5d | 2005-05-02 | 2005-05-03 | 86 | 1282.47d | 0d |  |  | AUV Fabricator #1 | 4.5h | 337.5 |
| 88 | 1.1.5.2.1.9 | Novatech Installation | 0.5d | 2005-05-03 | 2005-05-03 | 87 | 1282.47d | 0d | start no earlier than 2005-01-10 | 2010-12-30 | AUV Fabricator #1 | 4.5h | 337.5 |
| 89 | 1.1.5.2.1.10 | GPS Installation | 0.5d | 2005-05-03 | 2005-05-04 | 88 | 1282.47d | 0d | start no earlier than 2005-01-10 | 2010-12-30 | AUV Fabricator #1 | 4.5h | 337.5 |
| 90 | 1.1.5.2.1.11 | Heading Reference Installation | 0.5d | 2005-05-04 | 2005-05-05 | 89 | 1282.47d | 0d | start no earlier than 2005-01-10 | 2010-12-30 | AUV Fabricator #1 | 4.5h | 337.5 |
| 91 | 1.1.5.2.1.12 | RF Penetrator Installation/Wiring | 0.5d | 2005-05-05 | 2005-05-05 | 90 | 1282.47d | 0d | start no earlier than 2005-01-10 | 2010-12-30 | AUV Fabricator #1 | 4.5h | 337.5 |
| 92 | 1.1.5.2.1.13 | MINK Penetrator Installation/Wiring | 0.5d | 2005-05-05 | 2005-05-06 | 91 | 1282.47d | 0d | start no earlier than 2005-01-10 | 2010-12-30 | AUV Fabricator #1 | 4.5h | 337.5 |

Notes:
- 55: HT
- 56: HT
- 70: HT
- 71: HT
- 72: HT
- 73: HT
- 74: HT
- 77: HT
- 78: HT
- 80: HT
- 81: HT
- 82: HT
- 88: HT
- 89: HT
- 90: HT
- 91: HT
- 92: HT

| ID | WBS | Task | Duration | Start | Finish | Predecessors | Total slack | Free slack | Constraint | Deadline | Resources | Work | Cost |
| --- | --- | --- | --- | --- | --- | --- | --- | --- | --- | --- | --- | --- | --- |
| 93 | 1.1.5.2.1.14 | **Power Board** | 2d | 2005-05-06 | 2005-05-10 | 92 | 1282.47d |  |  |  | AUV Fabricator #1 | 18h | 1,350 |
| 94 | 1.1.5.2.1.14.1 | Assemble and bench test battery assembly | 2d | 2005-05-06 | 2005-05-10 |  | 1282.47d | 0d |  |  |  |  |  |
| 95 | 1.1.5.2.1.15 | Point-to-Point Wiring Installation | 0.5d | 2005-05-10 | 2005-05-10 | 94 | 1282.47d |  | start no earlier than 2005-01-10 | 2010-12-30 | AUV Fabricator #1 | 4.5h | 337.5 |
| 96 | 1.1.5.2.1.16 | Penetrator/dummy kitting for pressure test | 0.5d | 2005-04-25 | 2005-04-25 |  | 1292.47d |  | start no earlier than 2005-01-10 | 2010-12-30 | AUV Fabricator #1 | 4.5h | 337.5 |
| 97 | 1.1.5.2.2 | **Other Pressure Vessels (TBD)** | 0.5d | 2005-04-25 | 2005-04-25 |  | 1292.47d |  |  | 2010-12-30 | AUV Fabricator #1 | 9h | 675 |
| 98 | 1.1.5.2.2.1 | Penetrator/dummy kitting for pressure test | 0.5d | 2005-04-25 | 2005-04-25 |  | 1292.47d |  | start no earlier than 2005-01-10 | 2010-12-30 | AUV Fabricator #1 | 4.5h | 337.5 |
| 99 | 1.1.5.3 | Tailcone Assembly | 1d | 2005-04-25 | 2005-04-26 | 65 | 1291.97d |  |  |  |  |  |  |
| 100 | 1.1.5.4 | **Wet Cabling Fabrication** | 2d | 2005-04-25 | 2005-04-27 | 45 | 1290.97d | 12d |  | 2010-12-30 | AUV Fabricator #1 | 92.7h | 6,952.5 |
| 101 | 1.1.5.4.1 | C/F Kitting for Seaconn | 0.5d | 2005-04-25 | 2005-04-25 |  | 1292.47d |  | start no earlier than 2005-01-10 | 2010-12-30 | AUV Fabricator #1 | 4.5h | 337.5 |
| 102 | 1.1.5.4.2 | C/F Kitting for Subconn | 0.5d | 2005-04-25 | 2005-04-25 |  | 1292.47d |  | start no earlier than 2005-01-10 | 2010-12-30 | AUV Fabricator #1 | 4.5h | 337.5 |
| 103 | 1.1.5.4.3 | C/F Kitting for Burton | 0.5d | 2005-04-25 | 2005-04-25 |  | 1292.47d |  | start no earlier than 2005-01-10 | 2010-12-30 | AUV Fabricator #1 | 4.5h | 337.5 |
| 104 | 1.1.5.4.4 | C/F Kitting for Impulse | 0.5d | 2005-04-25 | 2005-04-25 |  | 1292.47d |  | start no earlier than 2005-01-10 | 2010-12-30 | AUV Fabricator #1 | 4.5h | 337.5 |
| 105 | 1.1.5.4.5 | MVC Forward Bus Cable | 0.1d | 2005-04-25 | 2005-04-25 |  | 1292.87d |  | start no earlier than 2005-01-10 | 2010-12-30 | AUV Fabricator #1 | 0.9h | 67.5 |
| 106 | 1.1.5.4.6 | MVC Shore Tether Cable | 0.1d | 2005-04-25 | 2005-04-25 |  | 1292.87d |  | start no earlier than 2005-01-10 | 2010-12-30 | AUV Fabricator #1 | 0.9h | 67.5 |
| 107 | 1.1.5.4.7 | MVC/TailCone Cable | 0.1d | 2005-04-25 | 2005-04-25 |  | 1292.87d |  | start no earlier than 2005-01-10 | 2010-12-30 | AUV Fabricator #1 | 0.9h | 67.5 |
| 108 | 1.1.5.4.8 | MVC/DVL Cable | 0.1d | 2005-04-25 | 2005-04-25 |  | 1292.87d |  | start no earlier than 2005-01-10 | 2010-12-30 | AUV Fabricator #1 | 0.9h | 67.5 |
| 109 | 1.1.5.4.9 | MVC/Pressure Sensor Cable | 0.1d | 2005-04-25 | 2005-04-25 |  | 1292.87d |  | start no earlier than 2005-01-10 | 2010-12-30 | AUV Fabricator #1 | 0.9h | 67.5 |
| 110 | 1.1.5.4.10 | Battery JBOX Aft Cable | 0.1d | 2005-04-25 | 2005-04-25 |  | 1292.87d |  | start no earlier than 2005-01-10 | 2010-12-30 | AUV Fabricator #1 | 0.9h | 67.5 |
| 111 | 1.1.5.4.11 | Battery JBOX Forward Cable | 0.1d | 2005-04-25 | 2005-04-25 |  | 1292.87d |  | start no earlier than 2005-01-10 | 2010-12-30 | AUV Fabricator #1 | 0.9h | 67.5 |
| 112 | 1.1.5.4.12 | Science DCON Aft Cable | 0.1d | 2005-04-25 | 2005-04-25 |  | 1292.87d |  | start no earlier than 2005-01-10 | 2010-12-30 | AUV Fabricator #1 | 0.9h | 67.5 |
| 113 | 1.1.5.4.13 | CTD1 Cable | 0.5d | 2005-04-25 | 2005-04-25 |  | 1292.47d |  | start no earlier than 2005-01-10 | 2010-12-30 | AUV Fabricator #1 | 4.5h | 337.5 |
| 114 | 1.1.5.4.14 | CTD2 Cable | 0.5d | 2005-04-25 | 2005-04-25 |  | 1292.47d |  | start no earlier than 2005-01-10 | 2010-12-30 | AUV Fabricator #1 | 4.5h | 337.5 |
| 115 | 1.1.5.4.15 | DO Sensor Cable | 0.5d | 2005-04-25 | 2005-04-25 |  | 1292.47d |  | start no earlier than 2005-01-10 | 2010-12-30 | AUV Fabricator #1 | 4.5h | 337.5 |
| 116 | 1.1.5.4.16 | ISUS Cable | 0.5d | 2005-04-25 | 2005-04-25 |  | 1292.47d |  | start no earlier than 2005-01-10 | 2010-12-30 | AUV Fabricator #1 | 4.5h | 337.5 |
| 117 | 1.1.5.4.17 | Flow Sensor Cable | 0.5d | 2005-04-25 | 2005-04-25 |  | 1292.47d |  | start no earlier than 2005-01-10 | 2010-12-30 | AUV Fabricator #1 | 4.5h | 337.5 |
| 118 | 1.1.5.4.18 | Biolume Cable | 0.5d | 2005-04-25 | 2005-04-25 |  | 1292.47d |  | start no earlier than 2005-01-10 | 2010-12-30 | AUV Fabricator #1 | 4.5h | 337.5 |
| 119 | 1.1.5.4.19 | LISST Cable | 0.5d | 2005-04-25 | 2005-04-25 |  | 1292.47d |  | start no earlier than 2005-01-10 | 2010-12-30 | AUV Fabricator #1 | 4.5h | 337.5 |

Notes:
- 95: HT
- 96: HT
- 97: HT
- 98: HT
- 100: HT
- 101: HT
- 102: HT
- 103: HT
- 104: HT
- 105: HT
- 106: HT
- 107: HT
- 108: HT
- 109: HT
- 110: HT
- 111: HT
- 112: HT
- 113: HT
- 114: HT
- 115: HT
- 116: HT
- 117: HT
- 118: HT
- 119: HT

| ID | WBS | Task | Duration | Start | Finish | Predecessors | Total slack | Free slack | Constraint | Deadline | Resources | Work | Cost |
| --- | --- | --- | --- | --- | --- | --- | --- | --- | --- | --- | --- | --- | --- |
| 120 | 1.1.5.4.20 | **junction Box** | 2d | 2005-04-25 | 2005-04-27 |  | 1290.97d |  |  | 2010-12-30 | AUV Fabricator #1 | 18h | 1,350 |
| 121 | 1.1.5.4.20.1 | Assembly | 2d | 2005-04-25 | 2005-04-27 |  | 1290.97d |  | start no earlier than 2005-01-10 | 2010-12-30 |  |  |  |
| 122 | 1.1.5.4.20.2 | Casting | 1d | 2005-04-25 | 2005-04-26 |  | 1291.97d |  | start no earlier than 2005-01-10 | 2010-12-30 |  |  |  |
| 123 | 1.1.5.4.20.3 | Installation | 0.5d | 2005-04-25 | 2005-04-25 |  | 1292.47d |  | start no earlier than 2005-01-10 | 2010-12-30 |  |  |  |
| 124 | 1.1.5.5 | **Bracket Fabrication** | 12d | 2005-04-25 | 2005-05-12 |  | 1280.97d | 0d |  | 2010-12-30 | AUV Fabricator #1 | 216h | 16,200 |
| 125 | 1.1.5.5.1 | Forward Plate | 1d | 2005-04-25 | 2005-04-26 |  | 1280.97d | 0d | start no earlier than 2005-01-10 | 2010-12-30 | AUV Fabricator #1 | 9h | 675 |
| 126 | 1.1.5.5.2 | Bottom Plate | 2d | 2005-04-26 | 2005-04-28 | 125 | 1280.97d | 0d | start no earlier than 2005-01-10 | 2010-12-30 | AUV Fabricator #1 | 18h | 1,350 |
| 127 | 1.1.5.5.3 | Aft Plate | 1d | 2005-04-28 | 2005-04-29 | 126 | 1280.97d | 0d | start no earlier than 2005-01-10 | 2010-12-30 | AUV Fabricator #1 | 9h | 675 |
| 128 | 1.1.5.5.4 | Mounting Clamps (DVL,parosci,homerpro,xpndr) | 4d | 2005-04-29 | 2005-05-06 | 127 | 1280.97d | 0d | start no earlier than 2005-01-10 | 2010-12-30 | AUV Fabricator #1 | 36h | 2,700 |
| 129 | 1.1.5.5.5 | Antenna/strobe mount | 2d | 2005-05-06 | 2005-05-10 | 128 | 1280.97d | 0d | start no earlier than 2005-01-10 | 2010-12-30 | AUV Fabricator #1 | 18h | 1,350 |
| 130 | 1.1.5.5.6 | Mid Section Plate | 2d | 2005-05-10 | 2005-05-12 | 129 | 1280.97d |  |  | 2010-12-30 | AUV Fabricator #1 | 18h | 1,350 |
| 131 | 1.1.5.6 | **Fairing Fabrication/Holes** | 1d | 2005-04-25 | 2005-04-26 | 39 | 1291.97d | 17d |  | 2010-12-30 | AUV Fabricator #1 | 27h | 2,025 |
| 132 | 1.1.5.6.1 | Port Fairing, set up and drill | 1d | 2005-04-25 | 2005-04-26 |  | 1291.97d |  | start no earlier than 2005-01-10 | 2010-12-30 | AUV Fabricator #1 | 9h | 675 |
| 133 | 1.1.5.6.2 | Stbd Fairing, set up and drill | 1d | 2005-04-25 | 2005-04-26 |  | 1291.97d |  | start no earlier than 2005-01-10 | 2010-12-30 | AUV Fabricator #1 | 9h | 675 |
| 134 | 1.1.6 | **assembly of vessel** | 7d? | 2005-05-12 | 2005-05-24 | 69 | 1280.97d |  |  | 2010-12-30 |  | 15.75h | 1,181.25 |
| 135 | 1.1.6.1 | Assemble internal structure / brackets | 2d | 2005-05-12 | 2005-05-16 | 124 | 1280.97d | 0d |  |  |  |  |  |
| 136 | 1.1.6.2 | Install wet cabling | 1d? | 2005-05-16 | 2005-05-18 | 100, 135 | 1299.97d | 0d |  |  |  |  |  |
| 137 | 1.1.6.3 | Install Tailcone Assembly | 2d | 2005-05-18 | 2005-05-20 | 136 | 1299.97d | 0d |  |  |  |  |  |
| 138 | 1.1.6.4 | **Install MEH sphere** | 0.75d | 2005-05-20 | 2005-05-23 | 137 | 1299.97d | 0d |  | 2010-12-30 | AUV Fabricator #1 | 13.5h | 1,012.5 |
| 139 | 1.1.6.4.1 | Mount/cable Parosci, HomerPro | 0.25d | 2005-05-20 | 2005-05-20 |  | 1299.97d | 0d | start no earlier than 2005-01-10 | 2010-12-30 | AUV Fabricator #1 | 2.25h | 168.75 |
| 140 | 1.1.6.4.2 | Mount USBL Beacon/Transducer | 0.25d | 2005-05-20 | 2005-05-20 | 139 | 1299.97d | 0d | start no earlier than 2005-01-10 | 2010-12-30 | AUV Fabricator #1 | 2.25h | 168.75 |
| 141 | 1.1.6.4.3 | Mount/Cable DVL | 0.25d | 2005-05-20 | 2005-05-23 | 140 | 1299.97d |  | start no earlier than 2005-01-10 | 2010-12-30 | AUV Fabricator #1 | 2.25h | 168.75 |
| 142 | 1.1.6.5 | Syntactic Installation | 0.25d | 2005-05-23 | 2005-05-23 | 50, 138 | 1299.97d | 0d | start no earlier than 2005-01-10 | 2010-12-30 | AUV Fabricator #1 | 2.25h | 168.75 |
| 143 | 1.1.6.6 | Attach hull fairings | 1d? | 2005-05-23 | 2005-05-24 | 131, 142 | 1299.97d |  |  |  |  |  |  |

Notes:
- 120: HT
- 121: HT
- 122: HT
- 123: HT
- 124: HT
- 125: HT
- 126: HT
- 127: HT
- 128: HT
- 129: HT
- 130: HT
- 131: HT
- 132: HT
- 133: HT
- 138: HT
- 139: HT
- 140: HT
- 141: HT
- 142: HT

| ID | WBS | Task | Duration | Start | Finish | Predecessors | Total slack | Free slack | Constraint | Deadline | Resources | Work | Cost |
| --- | --- | --- | --- | --- | --- | --- | --- | --- | --- | --- | --- | --- | --- |
| 144 | 1.1.7 | **Integration and Test** | 21d | 2005-05-16 | 2005-06-17 | 135 | 1280.97d | 0d |  | 2010-12-30 |  | 54h | 4,050 |
| 145 | 1.1.7.1 | **Tail Section Electrical/Mechanical Integration & Test** | 5d | 2005-05-16 | 2005-05-24 |  | 1280.97d | 0d |  | 2010-12-30 | AUV Fabricator #1 | 45h | 3,375 |
| 146 | 1.1.7.1.1 | Propulsion Integration/Installation | 5d | 2005-05-16 | 2005-05-24 |  | 1280.97d |  | start no earlier than 2005-01-10 | 2010-12-30 |  |  |  |
| 147 | 1.1.7.2 | **Functional test of Tail Section sub-systems** | 1d | 2005-05-24 | 2005-05-25 | 145 | 1280.97d | 0d |  | 2010-12-30 | AUV Fabricator #1 | 9h | 675 |
| 148 | 1.1.7.2.1 | Tailcone Calibration | 0.25d | 2005-05-24 | 2005-05-24 |  | 1280.97d | 0d | start no earlier than 2005-01-10 | 2010-12-30 |  |  |  |
| 149 | 1.1.7.2.2 | DVL Comms and Rub Test | 0.25d | 2005-05-24 | 2005-05-25 | 148 | 1280.97d | 0d | start no earlier than 2005-01-10 | 2010-12-30 |  |  |  |
| 150 | 1.1.7.2.3 | Parosci Test | 0.25d | 2005-05-25 | 2005-05-25 | 149 | 1280.97d | 0d | start no earlier than 2005-01-10 | 2010-12-30 |  |  |  |
| 151 | 1.1.7.2.4 | Crossbow comms test | 0.25d | 2005-05-25 | 2005-05-25 | 150 | 1280.97d |  | start no earlier than 2005-01-10 | 2010-12-30 |  |  |  |
| 152 | 1.1.7.3 | Nose Section Electrical/Mechanical Integration & Test | 15d | 2005-05-25 | 2005-06-17 | 147 | 1280.97d |  | start no earlier than 2005-01-10 | 2010-12-30 |  |  |  |
| 153 | 1.1.8 | **Operational Test and debug** | 3d | 2005-06-17 | 2005-06-22 | 144 | 1280.97d | 0d |  | 2010-12-30 |  |  |  |
| 154 | 1.1.8.1 | **Test in Tank** | 1d | 2005-06-17 | 2005-06-20 |  | 1282.97d |  |  |  |  |  |  |
| 155 | 1.1.8.1.1 | Comms | 1d | 2005-06-17 | 2005-06-20 |  | 1282.97d |  |  |  |  |  |  |
| 156 | 1.1.8.1.2 | Battery charge/discharge | 1d | 2005-06-17 | 2005-06-20 |  | 1282.97d |  |  |  |  |  |  |
| 157 | 1.1.8.2 | **Test in Ocean** | 3d | 2005-06-17 | 2005-06-22 |  | 1280.97d |  |  |  |  |  |  |
| 158 | 1.1.8.2.1 | Simple dive/run/surface | 1d | 2005-06-17 | 2005-06-20 |  | 1280.97d | 0d |  |  |  |  |  |
| 159 | 1.1.8.2.2 | Waypoint operations | 1d | 2005-06-20 | 2005-06-21 | 158 | 1280.97d | 0d |  |  |  |  |  |
| 160 | 1.1.8.2.3 | Sleep/wake capability | 1d | 2005-06-21 | 2005-06-22 | 159 | 1280.97d |  |  |  |  |  |  |
| 162 | 1.2 | **Dock** | 36d? | 2005-01-03 | 2005-02-28 |  | 1280.97d |  |  |  |  |  |  |
| 163 | 1.2.1 | **Concept Design** | 1d? | 2005-01-03 | 2005-01-04 |  | 1280.97d | 0d |  |  |  |  |  |
| 164 | 1.2.1.1 | Work through Docking Scenarion | 1d? | 2005-01-03 | 2005-01-04 |  | 1280.97d |  |  |  |  |  |  |
| 165 | 1.2.1.2 | Create Baseline Concept Design | 1d? | 2005-01-03 | 2005-01-04 |  | 1280.97d |  |  |  |  |  |  |
| 166 | 1.2.2 | **High Risk Engineering Development Items** | 30d | 2005-01-04 | 2005-02-18 | 163 | 1280.97d | 0d |  |  |  |  |  |
| 167 | 1.2.2.1 | Design, build and test High Risk items | 30d | 2005-01-04 | 2005-02-18 |  | 1280.97d |  |  |  |  |  |  |
| 169 | 1.2.3 | **Purchasing** | 1d? | 2005-02-18 | 2005-02-21 | 166 | 1354.22d |  |  |  |  |  |  |
| 170 | 1.2.3.1 | Anchor | 1d? | 2005-02-18 | 2005-02-21 |  | 1354.22d | 0d |  |  |  |  |  |

Notes:
- 145: HT
- 146: HT
- 147: HT
- 148: HT
- 149: HT
- 150: HT
- 151: HT
- 152: HT

| ID | WBS | Task | Type | Duration | Start | Finish | Predecessors | Total slack | Free slack | Deadline |
| --- | --- | --- | --- | --- | --- | --- | --- | --- | --- | --- |
| 171 | 1.2.4 | **In house fabrication of sub assemblies** |  | 1d? | 2005-02-22 | 2005-02-23 | 170 | 1354.22d |  |  |
| 172 | 1.2.4.1 | Anchor assembly |  | 1d? | 2005-02-22 | 2005-02-23 |  | 1354.22d | 0d |  |
| 173 | 1.2.5 | **Assembly of Dock** |  | 1d? | 2005-02-23 | 2005-02-24 | 172 | 1354.22d |  |  |
| 174 | 1.2.5.1 | Anchor Connectors |  | 1d? | 2005-02-23 | 2005-02-24 |  | 1354.22d | 0d |  |
| 175 | 1.2.6 | **integration and testing of dock** |  | 1d? | 2005-02-24 | 2005-02-25 | 174 | 1354.22d |  |  |
| 176 | 1.2.6.1 | Anchor Functionality |  | 1d? | 2005-02-24 | 2005-02-25 |  | 1354.22d | 0d |  |
| 177 | 1.2.7 | **Operational Testing and debugging** |  | 1d? | 2005-02-25 | 2005-02-28 | 176 | 1354.22d | 73.25d |  |
| 178 | 1.2.7.1 | Anchor Systems Check |  | 1d? | 2005-02-25 | 2005-02-28 |  | 1354.22d |  |  |
| 184 | 1.3 | Deployment | milestone | 0d | 2005-06-22 | 2005-06-22 | 177, 153 | 1280.97d |  | 2010-12-30 |
