# Labor estimate for docking AUV

Schedule from MS Project, 2005-01-03 to 2005-09-23.
MBARI

## Calendars

- Standard: Mon-Fri 08:00-12:00, 13:00-17:00; Sat-Sun off.

## Resources

| Resource | Rate |
| --- | --- |
| Thomas Hoover | 75 |
| Michael Godin | 100 |
| Jon Erickson | 100 |
| Lance McBride | 100 |
| Hans Thomas | 100 |
| Tom O'Reilly | 100 |
| Jim Bellingham | 150 |
| Rob McEwen | 100 |
| Yanwu Zhang | 100 |

## Schedule

| ID | WBS | Task | Duration | Start | Finish | Predecessors | Baseline start | Baseline finish | Baseline duration | Total slack | Free slack |
| --- | --- | --- | --- | --- | --- | --- | --- | --- | --- | --- | --- |
| 1 | 1 | **Design Vehicle** | 30d | 2005-01-03 | 2005-02-11 |  | 2005-12-23 | 2005-12-23 | 1d? | 0d |  |
| 2 | 1.1 | Analysis | 10d | 2005-01-03 | 2005-01-14 |  |  |  |  | 0d |  |
| 3 | 1.2 | Design | 10d | 2005-01-17 | 2005-01-28 | 2 |  |  |  | 10d | 0d |
| 4 | 1.3 | Design Review | 10d | 2005-01-31 | 2005-02-11 | 3 |  |  |  | 10d |  |
| 5 | 2 | **Build Vehicle** | 30d | 2005-02-14 | 2005-03-25 | 1 | 2005-12-26 | 2005-12-26 | 1d? | 10d | 0d |
| 6 | 2.1 | **Purchasing** | 10d | 2005-02-14 | 2005-02-25 | 1 |  |  |  | 10d |  |
| 7 | 2.1.1 | Fairing, Framing, and Housing | 10d | 2005-02-14 | 2005-02-25 |  | 2005-12-26 | 2005-12-26 | 1d? | 10d | 0d |
| 8 | 2.1.2 | Wet Cables and Connectors | 10d | 2005-02-14 | 2005-02-25 |  | 2005-12-26 | 2005-12-26 | 1d? | 10d | 0d |
| 9 | 2.1.3 | Propulsion and Actuator Controls | 10d | 2005-02-14 | 2005-02-25 |  | 2005-12-26 | 2005-12-26 | 1d? | 10d | 0d |
| 10 | 2.1.4 | Power Systems | 10d | 2005-02-14 | 2005-02-25 |  | 2005-12-26 | 2005-12-26 | 1d? | 10d | 0d |
| 11 | 2.1.5 | Docking Interface | 10d | 2005-02-14 | 2005-02-25 |  |  |  |  | 10d | 0d |
| 12 | 2.1.6 | Guidance, Navigation and Controls | 10d | 2005-02-14 | 2005-02-25 |  | 2005-12-26 | 2005-12-26 | 1d? | 10d | 0d |
| 13 | 2.1.7 | Location Devices | 10d | 2005-02-14 | 2005-02-25 |  | 2005-12-26 | 2005-12-26 | 1d? | 10d | 0d |
| 14 | 2.1.8 | Communication | 10d | 2005-02-14 | 2005-02-25 |  | 2005-12-26 | 2005-12-26 | 1d? | 10d | 0d |
| 15 | 2.2 | **Fabrication** | 10d | 2005-02-28 | 2005-03-11 |  |  |  |  | 10d |  |
| 16 | 2.2.1 | Fairing, Framing, and Housing | 10d | 2005-02-28 | 2005-03-11 | 7 | 2005-12-26 | 2005-12-26 | 1d? | 10d | 0d |
| 17 | 2.2.2 | Wet Cables and Connectors | 10d | 2005-02-28 | 2005-03-11 | 8 | 2005-12-26 | 2005-12-26 | 1d? | 10d | 0d |
| 18 | 2.2.3 | Propulsion and Actuator Controls | 10d | 2005-02-28 | 2005-03-11 | 9 | 2005-12-26 | 2005-12-26 | 1d? | 10d | 0d |
| 19 | 2.2.4 | Power Systems | 10d | 2005-02-28 | 2005-03-11 | 10 | 2005-12-26 | 2005-12-26 | 1d? | 10d | 0d |
| 20 | 2.2.5 | Docking Interface | 10d | 2005-02-28 | 2005-03-11 | 11 |  |  |  | 10d | 0d |
| 21 | 2.2.6 | Guidance, Navigation and Controls | 10d | 2005-02-28 | 2005-03-11 | 12 | 2005-12-26 | 2005-12-26 | 1d? | 10d | 0d |
| 22 | 2.2.7 | Location Devices | 10d | 2005-02-28 | 2005-03-11 | 13 | 2005-12-26 | 2005-12-26 | 1d? | 10d | 0d |
| 23 | 2.2.8 | Communication | 10d | 2005-02-28 | 2005-03-11 | 14 | 2005-12-26 | 2005-12-26 | 1d? | 10d | 0d |
| 24 | 2.3 | **Assembly** | 10d | 2005-03-14 | 2005-03-25 |  |  |  |  | 10d |  |
| 25 | 2.3.1 | Fairing, Framing, and Housing | 10d | 2005-03-14 | 2005-03-25 | 16 | 2005-12-26 | 2005-12-26 | 1d? | 10d |  |
| 26 | 2.3.2 | Wet Cables and Connectors | 10d | 2005-03-14 | 2005-03-25 | 17 | 2005-12-26 | 2005-12-26 | 1d? | 10d |  |
| 27 | 2.3.3 | Propulsion and Actuator Controls | 10d | 2005-03-14 | 2005-03-25 | 18 | 2005-12-26 | 2005-12-26 | 1d? | 10d |  |
| 28 | 2.3.4 | Power Systems | 10d | 2005-03-14 | 2005-03-25 | 19 | 2005-12-26 | 2005-12-26 | 1d? | 10d |  |
| 29 | 2.3.5 | Docking Interface | 10d | 2005-03-14 | 2005-03-25 | 20 |  |  |  | 10d |  |
| 30 | 2.3.6 | Guidance, Navigation and Controls | 10d | 2005-03-14 | 2005-03-25 | 21 | 2005-12-26 | 2005-12-26 | 1d? | 10d |  |
| 31 | 2.3.7 | Location Devices | 10d | 2005-03-14 | 2005-03-25 | 22 | 2005-12-26 | 2005-12-26 | 1d? | 10d |  |
| 32 | 2.3.8 | Communication | 10d | 2005-03-14 | 2005-03-25 | 23 | 2005-12-26 | 2005-12-26 | 1d? | 10d |  |

| ID | WBS | Task | Duration | Start | Finish | Predecessors | Baseline start | Baseline finish | Baseline duration | Total slack |
| --- | --- | --- | --- | --- | --- | --- | --- | --- | --- | --- |
| 33 | 3 | **Design Dock** | 30d | 2005-01-17 | 2005-02-25 | 2 |  |  |  | 0d |
| 34 | 3.1 | Analysis | 10d | 2005-01-17 | 2005-01-28 |  |  |  |  | 0d |
| 35 | 3.2 | Design | 10d | 2005-01-31 | 2005-02-11 | 34 |  |  |  | 0d |
| 36 | 3.3 | Design Review | 10d | 2005-02-14 | 2005-02-25 | 35 |  |  |  | 0d |
| 37 | 4 | **Build Dock** | 30d | 2005-02-28 | 2005-04-08 | 33 |  |  |  | 0d |
| 38 | 4.1 | **Purchasing** | 10d | 2005-02-28 | 2005-03-11 |  |  |  |  | 0d |
| 39 | 4.1.1 | Mechanical Systems | 10d | 2005-02-28 | 2005-03-11 |  | 2005-12-26 | 2005-12-26 | 1d? | 0d |
| 40 | 4.1.2 | Electrical Systems | 10d | 2005-02-28 | 2005-03-11 |  | 2005-12-26 | 2005-12-26 | 1d? | 0d |
| 41 | 4.1.3 | Communication Systmes | 10d | 2005-02-28 | 2005-03-11 |  | 2005-12-26 | 2005-12-26 | 1d? | 0d |
| 42 | 4.2 | **Fabrication** | 10d | 2005-03-14 | 2005-03-25 |  |  |  |  | 0d |
| 43 | 4.2.1 | Mechanical Systems | 10d | 2005-03-14 | 2005-03-25 | 39 | 2005-12-26 | 2005-12-26 | 1d? | 0d |
| 44 | 4.2.2 | Electrical Systems | 10d | 2005-03-14 | 2005-03-25 | 40 | 2005-12-26 | 2005-12-26 | 1d? | 0d |
| 45 | 4.2.3 | Communication Systmes | 10d | 2005-03-14 | 2005-03-25 | 41 | 2005-12-26 | 2005-12-26 | 1d? | 0d |
| 46 | 4.3 | **Assembly** | 10d | 2005-03-28 | 2005-04-08 |  |  |  |  | 0d |
| 47 | 4.3.1 | Mechanical Systems | 10d | 2005-03-28 | 2005-04-08 | 43 | 2005-12-26 | 2005-12-26 | 1d? | 0d |
| 48 | 4.3.2 | Electrical Systems | 10d | 2005-03-28 | 2005-04-08 | 44 | 2005-12-26 | 2005-12-26 | 1d? | 0d |
| 49 | 4.3.3 | Communication Systmes | 10d | 2005-03-28 | 2005-04-08 | 45 | 2005-12-26 | 2005-12-26 | 1d? | 0d |
| 50 | 5 | **Testing** | 70d | 2005-03-28 | 2005-07-01 |  |  |  |  | 0d |
| 51 | 5.1 | **Test Vehicle** | 10d | 2005-03-28 | 2005-04-08 | 5 | 2005-12-27 | 2005-12-29 | 3d? | 10d |
| 52 | 5.1.1 | Operate AUV in test tank | 10d | 2005-03-28 | 2005-04-08 |  | 2005-12-27 | 2005-12-27 | 1d? | 10d |
| 53 | 5.2 | **Test Dock** | 10d | 2005-04-11 | 2005-04-22 | 37 |  |  |  | 0d |
| 54 | 5.2.1 | Deploy dock in test tank | 10d | 2005-04-11 | 2005-04-22 |  |  |  |  | 0d |
| 55 | 5.3 | **Test docking in test tank** | 20d | 2005-04-25 | 2005-05-20 | 53, 51 |  |  |  | 0d |
| 56 | 5.3.1 | Perform dock | 10d | 2005-04-25 | 2005-05-06 | 54 | 2005-12-28 | 2005-12-28 | 1d? | 0d |
| 57 | 5.3.2 | Perform undock | 10d | 2005-05-09 | 2005-05-20 | 56 | 2005-12-29 | 2005-12-29 | 1d? | 0d |

| ID | WBS | Task | Duration | Start | Finish | Predecessors | Baseline start | Baseline finish | Baseline duration | Total slack | Free slack |
| --- | --- | --- | --- | --- | --- | --- | --- | --- | --- | --- | --- |
| 58 | 5.4 | **Test docking at sea** | 30d | 2005-05-23 | 2005-07-01 | 55 |  |  |  | 0d |  |
| 59 | 5.4.1 | Dock with dock deployed from vessel | 10d | 2005-05-23 | 2005-06-03 |  |  |  |  | 0d |  |
| 60 | 5.4.2 | Dock with dock anchored on sea floor | 10d | 2005-06-20 | 2005-07-01 | 64 |  |  |  | 0d |  |
| 61 | 6 | **Deploy dock** | 100d | 2005-01-31 | 2005-06-17 |  |  |  |  | 0d |  |
| 62 | 6.1 | Select site | 10d | 2005-01-31 | 2005-02-11 | 34 |  |  |  | 70d | 0d |
| 63 | 6.2 | Get permits | 10d | 2005-02-14 | 2005-02-25 | 62 |  |  |  | 70d |  |
| 64 | 6.3 | Place dock on sea floor | 10d | 2005-06-06 | 2005-06-17 | 63, 59 |  |  |  | 0d |  |
| 65 | 7 | **Operate Vehicle off Dock** | 60d | 2005-07-04 | 2005-09-23 | 50 | 2005-12-30 | 2005-12-30 | 1d? | 0d |  |
| 66 | 7.1 | Run First Autonomous Mission from Dock | 10d | 2005-07-04 | 2005-07-15 |  | 2005-12-30 | 2005-12-30 | 1d? | 0d |  |
| 67 | 7.2 | Recovery from 1st Mission | 10d | 2005-07-18 | 2005-07-29 | 66 |  |  |  | 0d |  |
| 68 | 7.3 | Run Second Autonomous Mission from Dock | 10d | 2005-08-01 | 2005-08-12 | 67 | 2005-12-30 | 2005-12-30 | 1d? | 0d |  |
| 69 | 7.4 | Recovery from 2nd Mission | 10d | 2005-08-15 | 2005-08-26 | 68 |  |  |  | 0d |  |
| 70 | 7.5 | Run Third Autonomous Mission from Dock | 10d | 2005-08-29 | 2005-09-09 | 69 | 2005-12-30 | 2005-12-30 | 1d? | 0d |  |
| 71 | 7.6 | Recovery from 3rd mission | 10d | 2005-09-12 | 2005-09-23 | 70 |  |  |  | 0d |  |
