# mbari-cimt_major_milestones

Schedule from MS Project, 2004-01-01 to 2004-06-28.
mbari

## Calendars

- Standard: Mon-Fri 08:00-12:00, 13:00-17:00; Sat-Sun off. Exceptions (off unless hours are given): 2004-05-22 08:00-12:00, 13:00-17:00.

## Resources

| Resource |
| --- |
| EXT_VENDOR |
| SCI_TECH |
| SYS_ENG |
| EE |
| ME |
| SE |
| ET |
| MT |
| OSG |
| ST |
| MA |
| SUE |
| IAG |

## Schedule

| ID | WBS | Task | Type | Duration | Start | Finish | Predecessors | Total slack | Free slack | Constraint | Resources | Work |
| --- | --- | --- | --- | --- | --- | --- | --- | --- | --- | --- | --- | --- |
| 1 | 1 | CIMT Deployment | milestone | 0d | 2004-06-03 | 2004-06-03 |  | 17.5d |  | start no earlier than 2004-06-03 |  |  |
| 2 | 2 | **Floatation** |  | 67.5d | 2004-01-01 | 2004-04-05 |  | 38.5d |  |  |  | 652h |
| 3 | 2.1 | **analysis** |  | 0d | 2004-01-01 | 2004-01-01 |  | 38.5d |  |  |  |  |
| 4 | 2.1.1 | none | milestone | 0d | 2004-01-01 | 2004-01-01 |  | 38.5d | 0d |  |  |  |
| 5 | 2.2 | **design** |  | 0d | 2004-01-01 | 2004-01-01 |  | 128.5d |  |  |  |  |
| 6 | 2.2.1 | none | milestone | 0d | 2004-01-01 | 2004-01-01 |  | 128.5d |  |  |  |  |
| 7 | 2.3 | **design review** |  | 0d | 2004-01-01 | 2004-01-01 |  | 38.5d |  |  |  |  |
| 8 | 2.3.1 | none | milestone | 0d | 2004-01-01 | 2004-01-01 | 4 | 38.5d | 0d |  |  |  |
| 9 | 2.4 | **purchasing** |  | 1.5d | 2004-01-01 | 2004-01-02 |  | 38.5d |  |  |  | 12h |
| 10 | 2.4.1 | purchase floatation foam |  | 1d | 2004-01-01 | 2004-01-01 | 8 | 38.5d | 0d |  | OSG | 8h |
| 11 | 2.4.2 | floatation plate orders |  | 0.5d | 2004-01-02 | 2004-01-02 | 10 | 38.5d | 0d |  | MA | 4h |
| 12 | 2.5 | **fab** |  | 61.5d | 2004-01-01 | 2004-03-26 |  | 40d |  |  |  | 588h |
| 13 | 2.5.1 | build and ship foam |  | 12w | 2004-01-02 | 2004-03-26 | 11 | 38.5d | 0d |  | EXT_VENDOR | 480h |
| 14 | 2.5.2 | floatation plate cut |  | 1d | 2004-01-01 | 2004-01-01 |  | 93.5d | 0d |  | MA | 8h |
| 15 | 2.5.3 | floatation plate weld |  | 5d | 2004-01-02 | 2004-01-08 | 14 | 93.5d | 0d |  | MA | 40h |
| 16 | 2.5.4 | floatation plate finishing |  | 0.5d | 2004-01-09 | 2004-01-09 | 15 | 93.5d | 55d |  | MA | 4h |
| 17 | 2.5.5 | floatation tie rod machining |  | 1d | 2004-01-26 | 2004-01-26 |  | 81d | 0d | start no earlier than 2004-01-26 | MA | 8h |
| 18 | 2.5.6 | floatation tie rod weld |  | 1d | 2004-01-27 | 2004-01-27 | 17 | 81d | 42.5d |  | MA | 8h |
| 19 | 2.5.7 | buoy standup support |  | 5d | 2004-01-29 | 2004-02-04 |  | 103.5d |  | start no earlier than 2004-01-29 | MT | 40h |
| 20 | 2.6 | **assembly** |  | 6d | 2004-03-26 | 2004-04-05 |  | 38.5d |  |  |  | 52h |
| 21 | 2.6.1 | attach top and bottom plates, tie rods |  | 3d | 2004-03-26 | 2004-03-31 | 13, 16, 18 | 38.5d | 0d |  | MT | 24h |
| 22 | 2.6.2 | apply anti-fouling paint |  | 3d | 2004-03-31 | 2004-04-05 | 21 | 61d |  |  | EXT_VENDOR | 24h |
| 23 | 2.6.3 | paint logo |  | 0.5d | 2004-03-31 | 2004-03-31 | 21 | 63.5d |  |  | EXT_VENDOR | 4h |
| 24 | 2.7 | **integration and test** |  | 0d | 2004-03-31 | 2004-03-31 |  | 38.5d |  |  |  |  |
| 25 | 2.7.1 | integration ready | milestone | 0d | 2004-03-31 | 2004-03-31 | 21 | 38.5d | 0d |  |  |  |

| ID | WBS | Task | Type | Duration | Start | Finish | Predecessors | Total slack | Free slack | Resources | Work |
| --- | --- | --- | --- | --- | --- | --- | --- | --- | --- | --- | --- |
| 26 | 2.8 | **test and debug** |  | 0d | 2004-01-01 | 2004-01-01 |  | 128.5d |  |  |  |
| 27 | 2.8.1 | none | milestone | 0d | 2004-01-01 | 2004-01-01 |  | 128.5d |  |  |  |
| 28 | 3 | **Tower** |  | 74d | 2004-01-01 | 2004-04-13 |  | 29d |  |  | 592h |
| 29 | 3.1 | **analysis** |  | 0d | 2004-01-01 | 2004-01-01 |  | 128.5d |  |  |  |
| 30 | 3.1.1 | none | milestone | 0d | 2004-01-01 | 2004-01-01 |  | 128.5d |  |  |  |
| 31 | 3.2 | **design** |  | 0d | 2004-01-01 | 2004-01-01 |  | 128.5d |  |  |  |
| 32 | 3.2.1 | none | milestone | 0d | 2004-01-01 | 2004-01-01 |  | 128.5d |  |  |  |
| 33 | 3.3 | **design review** |  | 0d | 2004-01-01 | 2004-01-01 |  | 128.5d |  |  |  |
| 34 | 3.3.1 | none | milestone | 0d | 2004-01-01 | 2004-01-01 |  | 128.5d |  |  |  |
| 35 | 3.4 | **purchasing** |  | 1d | 2004-01-01 | 2004-01-01 |  | 29d |  |  | 8h |
| 36 | 3.4.1 | purchase tower |  | 1d | 2004-01-01 | 2004-01-01 |  | 29d | 0d | OSG | 8h |
| 37 | 3.5 | **fab** |  | 73d | 2004-01-02 | 2004-04-13 |  | 29d |  |  | 584h |
| 38 | 3.5.1 | tower machining |  | 12w | 2004-01-02 | 2004-03-25 | 36 | 29d | 0d | EXT_VENDOR | 480h |
| 39 | 3.5.2 | tower bracket welding |  | 3d | 2004-03-26 | 2004-03-30 | 38 | 29d | 0d | MA | 24h |
| 40 | 3.5.3 | tower heat treat+shipping |  | 2w | 2004-03-31 | 2004-04-13 | 39 | 29d | 0d | EXT_VENDOR | 80h |
| 41 | 3.6 | **assembly** |  | 0d | 2004-01-01 | 2004-01-01 |  | 128.5d |  |  |  |
| 42 | 3.6.1 | none | milestone | 0d | 2004-01-01 | 2004-01-01 |  | 128.5d |  |  |  |
| 43 | 3.7 | **integration and test** |  | 0d | 2004-04-13 | 2004-04-13 |  | 29d |  |  |  |
| 44 | 3.7.1 | integration ready | milestone | 0d | 2004-04-13 | 2004-04-13 | 40 | 29d | 0d |  |  |
| 45 | 3.8 | **test and debug** |  | 0d | 2004-01-01 | 2004-01-01 |  | 128.5d |  |  |  |
| 46 | 3.8.1 | none | milestone | 0d | 2004-01-01 | 2004-01-01 |  | 128.5d |  |  |  |
| 47 | 4 | **Bridle** |  | 62d | 2004-01-01 | 2004-03-26 |  | 42d |  |  | 496h |
| 48 | 4.1 | **analysis** |  | 0d | 2004-01-01 | 2004-01-01 |  | 128.5d |  |  |  |
| 49 | 4.1.1 | none | milestone | 0d | 2004-01-01 | 2004-01-01 |  | 128.5d |  |  |  |

| ID | WBS | Task | Type | Duration | Start | Finish | Predecessors | Total slack | Free slack | Resources | Work |
| --- | --- | --- | --- | --- | --- | --- | --- | --- | --- | --- | --- |
| 50 | 4.2 | **design** |  | 0d | 2004-01-01 | 2004-01-01 |  | 128.5d |  |  |  |
| 51 | 4.2.1 | none | milestone | 0d | 2004-01-01 | 2004-01-01 |  | 128.5d |  |  |  |
| 52 | 4.3 | **design review** |  | 0d | 2004-01-01 | 2004-01-01 |  | 128.5d |  |  |  |
| 53 | 4.3.1 | none | milestone | 0d | 2004-01-01 | 2004-01-01 |  | 128.5d |  |  |  |
| 54 | 4.4 | **purchasing** |  | 1d | 2004-01-01 | 2004-01-01 |  | 42d |  |  | 8h |
| 55 | 4.4.1 | purchase bridle parts and heat treating |  | 1d | 2004-01-01 | 2004-01-01 |  | 42d | 0d | OSG | 8h |
| 56 | 4.5 | **fab** |  | 61d | 2004-01-02 | 2004-03-26 |  | 42d |  |  | 488h |
| 57 | 4.5.1 | bridle machining (stainless, no heat treat) |  | 12w | 2004-01-02 | 2004-03-25 | 55 | 42d | 0d | EXT_VENDOR | 480h |
| 58 | 4.5.2 | bridle mods for ballast mount |  | 1d | 2004-03-26 | 2004-03-26 | 57 | 66.5d |  | MT | 8h |
| 59 | 4.6 | **assembly** |  | 0d | 2004-01-01 | 2004-01-01 |  | 128.5d |  |  |  |
| 60 | 4.6.1 | none | milestone | 0d | 2004-01-01 | 2004-01-01 |  | 128.5d |  |  |  |
| 61 | 4.7 | **integration ant test** |  | 0d | 2004-03-25 | 2004-03-25 |  | 42d |  |  |  |
| 62 | 4.7.1 | integration ready | milestone | 0d | 2004-03-25 | 2004-03-25 | 57 | 42d | 3.5d |  |  |
| 63 | 4.8 | **test and debug** |  | 0d | 2004-01-01 | 2004-01-01 |  | 128.5d |  |  |  |
| 64 | 4.8.1 | none | milestone | 0d | 2004-01-01 | 2004-01-01 |  | 128.5d |  |  |  |
| 65 | 5 | **Elevator** |  | 32d | 2004-01-01 | 2004-02-13 |  | 94.5d |  |  | 432h |
| 66 | 5.1 | **analysis** |  | 0d | 2004-01-01 | 2004-01-01 |  | 128.5d |  |  |  |
| 67 | 5.1.1 | none | milestone | 0d | 2004-01-01 | 2004-01-01 |  | 128.5d |  |  |  |
| 68 | 5.2 | **design** |  | 0d | 2004-01-01 | 2004-01-01 |  | 128.5d |  |  |  |
| 69 | 5.2.1 | none | milestone | 0d | 2004-01-01 | 2004-01-01 |  | 128.5d |  |  |  |
| 70 | 5.3 | **design review** |  | 0d | 2004-01-01 | 2004-01-01 |  | 128.5d |  |  |  |
| 71 | 5.3.1 | none | milestone | 0d | 2004-01-01 | 2004-01-01 |  | 128.5d |  |  |  |
| 72 | 5.4 | **purchasing** |  | 1d | 2004-01-01 | 2004-01-01 |  | 118.5d |  |  | 8h |
| 73 | 5.4.1 | purchase elevator and winch parts |  | 1d | 2004-01-01 | 2004-01-01 |  | 118.5d | 0d | OSG | 8h |

| ID | WBS | Task | Type | Duration | Start | Finish | Predecessors | Total slack | Free slack | Constraint | Resources | Work |
| --- | --- | --- | --- | --- | --- | --- | --- | --- | --- | --- | --- | --- |
| 74 | 5.5 | **fab** |  | 31d | 2004-01-01 | 2004-02-12 |  | 94.5d |  |  |  | 408h |
| 75 | 5.5.1 | elevator cage machining |  | 2w | 2004-01-01 | 2004-01-14 |  | 94.5d | 0d |  | EXT_VENDOR | 80h |
| 76 | 5.5.2 | elevator cage electropolish, passivate |  | 2w | 2004-01-15 | 2004-01-28 | 75 | 94.5d | 0d |  | EXT_VENDOR | 80h |
| 77 | 5.5.3 | elevator cage copper plate |  | 2w | 2004-01-29 | 2004-02-11 | 76 | 94.5d | 0d |  | EXT_VENDOR | 80h |
| 78 | 5.5.4 | elevator rods machining |  | 1w | 2004-01-01 | 2004-01-07 |  | 119.5d | 25d |  | MA | 40h |
| 79 | 5.5.5 | elevator small parts ( bushings, clamp blocks, stops, stop brackets, pins…) |  | 3w | 2004-01-01 | 2004-01-21 |  | 109.5d | 15d |  | MA | 120h |
| 80 | 5.5.6 | elevator winch lead time |  | 1w | 2004-01-02 | 2004-01-08 | 73 | 118.5d | 0d |  |  |  |
| 81 | 5.5.7 | elevator assembly |  | 1d | 2004-02-12 | 2004-02-12 | 77, 78, 79, 80 | 94.5d | 0d |  | OSG | 8h |
| 82 | 5.6 | **assembly** |  | 26d | 2004-01-09 | 2004-02-13 |  | 94.5d |  |  |  | 16h |
| 83 | 5.6.1 | elevator winch |  | 1d | 2004-01-09 | 2004-01-09 | 80 | 118.5d | 24d |  | OSG | 8h |
| 84 | 5.6.2 | elevator rods |  | 1d | 2004-02-13 | 2004-02-13 | 81, 83 | 94.5d | 0d |  | OSG | 8h |
| 85 | 5.7 | **integration and test** |  | 0d | 2004-02-13 | 2004-02-13 |  | 94.5d |  |  |  |  |
| 86 | 5.7.1 | integration ready | milestone | 0d | 2004-02-13 | 2004-02-13 | 84 | 94.5d | 43d |  |  |  |
| 87 | 5.8 | **test and debug** |  | 0d | 2004-01-01 | 2004-01-01 |  | 128.5d |  |  |  |  |
| 88 | 5.8.1 | none | milestone | 0d | 2004-01-01 | 2004-01-01 |  | 128.5d |  |  |  |  |
| 89 | 6 | **Cable** |  | 64d | 2004-01-01 | 2004-03-30 |  | 64.5d |  |  |  | 144h |
| 90 | 6.1 | **analysis** |  | 0d | 2004-02-16 | 2004-02-16 |  | 64d |  |  |  |  |
| 91 | 6.1.1 | none | milestone | 0d | 2004-02-16 | 2004-02-16 |  | 64d | 0d | start no earlier than 2004-02-16 |  |  |
| 92 | 6.2 | **design** |  | 0d | 2004-02-16 | 2004-02-16 |  | 64d |  |  |  |  |
| 93 | 6.2.1 | none | milestone | 0d | 2004-02-16 | 2004-02-16 | 91 | 64d | 0d |  |  |  |
| 94 | 6.3 | **design review** |  | 0d | 2004-02-16 | 2004-02-16 |  | 64d |  |  |  |  |
| 95 | 6.3.1 | none | milestone | 0d | 2004-02-16 | 2004-02-16 | 93 | 64d | 0d |  |  |  |
| 96 | 6.4 | **purchasing** |  | 32d | 2004-02-16 | 2004-03-30 |  | 64d |  |  |  | 112h |
| 97 | 6.4.1 | inventory hardware and cable |  | 2d | 2004-02-16 | 2004-02-17 | 95 | 64d | 0d |  | OSG | 16h |
| 98 | 6.4.2 | purchase cable, chain, standard hardware |  | 2w | 2004-02-18 | 2004-03-02 | 97 | 82d | 0d |  | OSG | 80h |
| 99 | 6.4.3 | purchase steamer chain |  | 2d | 2004-02-18 | 2004-02-19 | 97 | 92.5d |  |  | OSG | 16h |
| 100 | 6.4.4 | accoustic release lead time |  | 6w | 2004-02-18 | 2004-03-30 | 97 | 64d | 0d |  |  |  |

| ID | WBS | Task | Type | Duration | Start | Finish | Predecessors | Total slack | Free slack | Resources | Work |
| --- | --- | --- | --- | --- | --- | --- | --- | --- | --- | --- | --- |
| 101 | 6.5 | **fab** |  | 1d | 2004-01-01 | 2004-01-01 |  | 127.5d |  |  |  |
| 102 | 6.5.1 | none |  | 1d | 2004-01-01 | 2004-01-01 |  | 127.5d |  |  |  |
| 103 | 6.6 | **assembly** |  | 2.5d | 2004-03-03 | 2004-03-05 |  | 82d |  |  | 32h |
| 104 | 6.6.1 | spool cable |  | 2.5d | 2004-03-03 | 2004-03-05 | 98 | 82d |  | OSG | 20h |
| 105 | 6.6.2 | cable install hardware |  | 1.5d | 2004-03-03 | 2004-03-04 | 98 | 83d |  | OSG | 12h |
| 106 | 6.7 | **integration and test** |  | 0d | 2004-01-01 | 2004-01-01 |  | 128.5d |  |  |  |
| 107 | 6.7.1 | none | milestone | 0d | 2004-01-01 | 2004-01-01 |  | 128.5d |  |  |  |
| 108 | 6.8 | **test and debug** |  | 0d | 2004-01-01 | 2004-01-01 |  | 128.5d |  |  |  |
| 109 | 6.8.1 | none | milestone | 0d | 2004-01-01 | 2004-01-01 |  | 128.5d |  |  |  |
| 110 | 7 | **Anchor** |  | 16d | 2004-01-01 | 2004-01-22 |  | 112.5d |  |  | 184h |
| 111 | 7.1 | **analysis** |  | 0d | 2004-01-01 | 2004-01-01 |  | 128.5d |  |  |  |
| 112 | 7.1.1 | none | milestone | 0d | 2004-01-01 | 2004-01-01 |  | 128.5d |  |  |  |
| 113 | 7.2 | **design** |  | 1d | 2004-01-01 | 2004-01-01 |  | 112.5d |  |  | 8h |
| 114 | 7.2.1 | anchor design |  | 1d | 2004-01-01 | 2004-01-01 |  | 112.5d | 0d | OSG | 8h |
| 115 | 7.3 | **design review** |  | 0d | 2004-01-01 | 2004-01-01 |  | 112.5d |  |  |  |
| 116 | 7.3.1 | none | milestone | 0d | 2004-01-01 | 2004-01-01 | 114 | 112.5d | 0d |  |  |
| 117 | 7.4 | **purchasing** |  | 1d | 2004-01-02 | 2004-01-02 |  | 126.5d |  |  | 8h |
| 118 | 7.4.1 | purchase anchor parts |  | 1d | 2004-01-02 | 2004-01-02 | 116 | 126.5d |  | OSG | 8h |
| 119 | 7.5 | **fab** |  | 15d | 2004-01-02 | 2004-01-22 |  | 112.5d |  |  | 156h |
| 120 | 7.5.1 | anchor trawl-resistant dome fab and ship |  | 3w | 2004-01-02 | 2004-01-22 | 116 | 112.5d |  | EXT_VENDOR | 120h |
| 121 | 7.5.2 | anchor welding |  | 4.5d | 2004-01-02 | 2004-01-08 | 116 | 121.5d | 0d | MA | 36h |
| 122 | 7.6 | **assembly** |  | 0d | 2004-01-01 | 2004-01-01 |  | 128.5d |  |  |  |
| 123 | 7.6.1 | none | milestone | 0d | 2004-01-01 | 2004-01-01 |  | 128.5d |  |  |  |
| 124 | 7.7 | **integration** |  | 1.5d | 2004-01-08 | 2004-01-09 |  | 121.5d |  |  | 12h |
| 125 | 7.7.1 | anchor integration with cable |  | 1.5d | 2004-01-08 | 2004-01-09 | 121 | 121.5d |  | OSG | 12h |

| ID | WBS | Task | Type | Duration | Start | Finish | Predecessors | Total slack | Free slack | Resources | Work |
| --- | --- | --- | --- | --- | --- | --- | --- | --- | --- | --- | --- |
| 126 | 7.8 | **test and debug** |  | 0d | 2004-01-01 | 2004-01-01 |  | 128.5d |  |  |  |
| 127 | 7.8.1 | none | milestone | 0d | 2004-01-01 | 2004-01-01 |  | 128.5d |  |  |  |
| 128 | 8 | **Power System** |  | 51d | 2004-01-01 | 2004-03-11 |  | 63d |  |  | 2138.4h |
| 129 | 8.1 | **analysis** |  | 0d | 2004-01-01 | 2004-01-01 |  | 128.5d |  |  |  |
| 130 | 8.1.1 | none | milestone | 0d | 2004-01-01 | 2004-01-01 |  | 128.5d |  |  |  |
| 131 | 8.2 | **design** |  | 0d | 2004-01-01 | 2004-01-01 |  | 128.5d |  |  |  |
| 132 | 8.2.1 | none | milestone | 0d | 2004-01-01 | 2004-01-01 |  | 128.5d |  |  |  |
| 133 | 8.3 | **design review** |  | 0d | 2004-01-01 | 2004-01-01 |  | 128.5d |  |  |  |
| 134 | 8.3.1 | none | milestone | 0d | 2004-01-01 | 2004-01-01 |  | 128.5d |  |  |  |
| 135 | 8.4 | **purchasing** |  | 20d | 2004-01-01 | 2004-01-28 |  | 108.5d |  |  | 32h |
| 136 | 8.4.1 | purchase power can mechanical |  | 1d | 2004-01-01 | 2004-01-01 |  | 127.5d |  | OSG | 8h |
| 137 | 8.4.2 | purchase power can electrical |  | 1d | 2004-01-01 | 2004-01-01 |  | 127.5d |  | OSG | 8h |
| 138 | 8.4.3 | purchasing support |  | 20d | 2004-01-01 | 2004-01-28 |  | 108.5d |  | EE [10%] | 16h |
| 139 | 8.4.4 | power can chassis | milestone | 0d | 2004-01-01 | 2004-01-01 |  | 128.5d |  |  |  |
| 140 | 8.4.5 | power can electronics parts | milestone | 0d | 2004-01-01 | 2004-01-01 |  | 128.5d |  |  |  |
| 141 | 8.4.6 | power can housing | milestone | 0d | 2004-01-01 | 2004-01-01 |  | 128.5d |  |  |  |
| 142 | 8.4.7 | power can lid | milestone | 0d | 2004-01-01 | 2004-01-01 |  | 128.5d |  |  |  |
| 143 | 8.4.8 | power can bulkhead connectors | milestone | 0d | 2004-01-01 | 2004-01-01 |  | 128.5d |  |  |  |
| 144 | 8.4.9 | power cables | milestone | 0d | 2004-01-01 | 2004-01-01 |  | 128.5d |  |  |  |
| 145 | 8.4.10 | solar panels | milestone | 0d | 2004-01-01 | 2004-01-01 |  | 128.5d |  |  |  |
| 146 | 8.4.11 | battery boxes | milestone | 0d | 2004-01-01 | 2004-01-01 |  | 128.5d |  |  |  |
| 147 | 8.4.12 | load sink resistors | milestone | 0d | 2004-01-01 | 2004-01-01 |  | 128.5d |  |  |  |
| 148 | 8.4.13 | batteries | milestone | 0d | 2004-01-01 | 2004-01-01 |  | 128.5d |  |  |  |
| 149 | 8.5 | **fab** |  | 51d | 2004-01-01 | 2004-03-11 |  | 63d |  |  | 2016h |
| 150 | 8.5.1 | **chassis (1+1 spare)** |  | 21d | 2004-01-01 | 2004-01-29 |  | 107.5d |  |  | 488h |
| 151 | 8.5.1.1 | power can chassis endplates |  | 2w | 2004-01-01 | 2004-01-14 |  | 117.5d | 10d | EXT_VENDOR | 80h |
| 152 | 8.5.1.2 | power can chassis rails |  | 4w | 2004-01-01 | 2004-01-28 |  | 107.5d | 0d | EXT_VENDOR | 160h |
| 153 | 8.5.1.3 | power can chassis card guide |  | 3w | 2004-01-01 | 2004-01-21 |  | 112.5d | 5d | MA | 120h |
| 154 | 8.5.1.4 | power can chassis clips |  | 3w | 2004-01-01 | 2004-01-21 |  | 112.5d | 5d | MA | 120h |
| 155 | 8.5.1.5 | power can chassis assy |  | 1d | 2004-01-29 | 2004-01-29 | 151, 152, 153, 154 | 107.5d |  | OSG | 8h |

| ID | WBS | Task | Type | Duration | Start | Finish | Predecessors | Total slack | Free slack | Resources | Work |
| --- | --- | --- | --- | --- | --- | --- | --- | --- | --- | --- | --- |
| 156 | 8.5.2 | **housing (1 + 1 spare)** |  | 20d | 2004-01-01 | 2004-01-28 |  | 108.5d |  |  | 344h |
| 157 | 8.5.2.1 | power can housing machining |  | 4w | 2004-01-01 | 2004-01-28 |  | 108.5d | 0d | EXT_VENDOR | 160h |
| 158 | 8.5.2.2 | power can housing brazing (incl shipping) |  | 2w | 2004-01-01 | 2004-01-14 |  | 118.5d | 10d | EXT_VENDOR | 80h |
| 159 | 8.5.2.3 | power can housing anodization (incl shipping) |  | 2w | 2004-01-01 | 2004-01-14 |  | 118.5d | 10d | EXT_VENDOR | 80h |
| 160 | 8.5.2.4 | power can housing QC (2x) |  | 1d | 2004-01-01 | 2004-01-01 |  | 127.5d | 19d | OSG | 8h |
| 161 | 8.5.2.5 | power can housing pressure test |  | 2d | 2004-01-01 | 2004-01-02 |  | 126.5d | 18d | OSG | 16h |
| 162 | 8.5.2.6 | power can complete | milestone | 0d | 2004-01-28 | 2004-01-28 | 157, 158, 159, 160, 161 | 108.5d |  |  |  |
| 163 | 8.5.3 | **endcap (1 + 1 spare)** |  | 21d | 2004-01-01 | 2004-01-29 |  | 107.5d |  |  | 120h |
| 164 | 8.5.3.1 | power can endcap machining |  | 3d | 2004-01-01 | 2004-01-05 |  | 124.5d | 17d | EXT_VENDOR | 24h |
| 165 | 8.5.3.2 | power can endcap anodization (incl shipping) |  | 2w | 2004-01-01 | 2004-01-14 |  | 117.5d | 10d | EXT_VENDOR | 80h |
| 166 | 8.5.3.3 | power can endcap QC (2x) |  | 1d | 2004-01-01 | 2004-01-01 |  | 126.5d | 19d | OSG | 8h |
| 167 | 8.5.3.4 | power can bulkhead connectors lead time |  | 4w | 2004-01-01 | 2004-01-28 |  | 107.5d | 0d |  |  |
| 168 | 8.5.3.5 | power can endcap assembly |  | 1d | 2004-01-29 | 2004-01-29 | 164, 165, 166, 167 | 107.5d |  | OSG | 8h |
| 169 | 8.5.4 | **battery boxes (8+2 spare)** |  | 22d | 2004-01-01 | 2004-01-30 |  | 98d |  |  | 552h |
| 170 | 8.5.4.1 | battery box machining |  | 3w | 2004-01-01 | 2004-01-21 |  | 98d | 0d | EXT_VENDOR | 120h |
| 171 | 8.5.4.2 | battery box flanges machining |  | 6d | 2004-01-01 | 2004-01-08 |  | 107d | 9d | EXT_VENDOR | 48h |
| 172 | 8.5.4.3 | battery box lid machining |  | 10d | 2004-01-01 | 2004-01-14 |  | 103d | 5d | EXT_VENDOR | 80h |
| 173 | 8.5.4.4 | battery box internal parts machining |  | 2w | 2004-01-01 | 2004-01-14 |  | 103d | 5d | EXT_VENDOR | 80h |
| 174 | 8.5.4.5 | flange,battery box brazing (incl shipping) |  | 2w | 2004-01-01 | 2004-01-14 |  | 103d | 5d | EXT_VENDOR | 80h |
| 175 | 8.5.4.6 | flange, battery box, anodization (incl shipping) |  | 2w | 2004-01-01 | 2004-01-14 |  | 103d | 5d | EXT_VENDOR | 80h |
| 176 | 8.5.4.7 | battery box QC (2x) |  | 1d | 2004-01-01 | 2004-01-01 |  | 112d | 14d | OSG | 8h |
| 177 | 8.5.4.8 | battery box assy |  | 5d | 2004-01-22 | 2004-01-28 | 170, 171, 172, 173, 174, 175, 176 | 98d | 0d | OSG | 40h |
| 178 | 8.5.4.9 | battery box pressure test |  | 2d | 2004-01-29 | 2004-01-30 | 177 | 98d | 53d | OSG | 16h |
| 179 | 8.5.5 | **load resistors (2+1 spare)** |  | 9d | 2004-01-01 | 2004-01-13 |  | 111.5d |  |  | 136h |
| 180 | 8.5.5.1 | load resistor tube machining |  | 8d | 2004-01-01 | 2004-01-12 |  | 111.5d | 0d | EXT_VENDOR | 64h |
| 181 | 8.5.5.2 | load resistor brazing |  | 7d | 2004-01-01 | 2004-01-09 |  | 112.5d | 1d | EXT_VENDOR | 56h |
| 182 | 8.5.5.3 | load resistor QC |  | 1d | 2004-01-01 | 2004-01-01 |  | 118.5d | 7d | OSG | 8h |
| 183 | 8.5.5.4 | load resistor assy |  | 1d | 2004-01-13 | 2004-01-13 | 180, 181, 182 | 111.5d | 56.5d | OSG | 8h |

| ID | WBS | Task | Type | Duration | Start | Finish | Predecessors | Total slack | Free slack | Resources | Work |
| --- | --- | --- | --- | --- | --- | --- | --- | --- | --- | --- | --- |
| 184 | 8.5.6 | **solar panels (4+1 spare)** |  | 51d | 2004-01-01 | 2004-03-11 |  | 63d |  |  | 288h |
| 185 | 8.5.6.1 | solar panel lamination lead time |  | 3w | 2004-01-01 | 2004-01-21 |  | 73d | 10d |  |  |
| 186 | 8.5.6.2 | solar panel lead time |  | 5w | 2004-01-01 | 2004-02-04 |  | 63d | 0d |  |  |
| 187 | 8.5.6.3 | solar panel frame machining |  | 2w | 2004-01-01 | 2004-01-14 |  | 78d | 15d | EXT_VENDOR | 80h |
| 188 | 8.5.6.4 | solar panel assembly |  | 26d | 2004-02-05 | 2004-03-11 | 185, 186, 187 | 63d | 24d | MT | 208h |
| 189 | 8.5.7 | **wind generator** |  | 0d | 2004-01-01 | 2004-01-01 |  | 128.5d |  |  |  |
| 190 | 8.5.7.1 | wind generator lead time | milestone | 0d | 2004-01-01 | 2004-01-01 |  | 128.5d |  |  |  |
| 191 | 8.5.7.2 | wind generator mast machining | milestone | 0d | 2004-01-01 | 2004-01-01 |  | 128.5d |  | MA |  |
| 192 | 8.5.7.3 | wind generator cable lead time | milestone | 0d | 2004-01-01 | 2004-01-01 |  | 128.5d |  |  |  |
| 193 | 8.5.7.4 | wind generator assembly | milestone | 0d | 2004-01-01 | 2004-01-01 |  | 128.5d |  | OSG |  |
| 194 | 8.5.8 | **electronics** |  | 26d | 2004-01-01 | 2004-02-05 |  | 97.5d |  |  | 88h |
| 195 | 8.5.8.1 | power can electronics board fab | milestone | 0d | 2004-01-01 | 2004-01-01 |  | 112.5d | 15d | EXT_VENDOR |  |
| 196 | 8.5.8.2 | power tracker lead time |  | 3w | 2004-01-01 | 2004-01-21 |  | 97.5d | 0d |  |  |
| 197 | 8.5.8.3 | power can electronics assembly and board bringup |  | 1d | 2004-01-22 | 2004-01-22 | 195, 196 | 97.5d | 0d | ET | 8h |
| 198 | 8.5.8.4 | power can wiring harness |  | 2w | 2004-01-23 | 2004-02-05 | 197 | 97.5d | 0d | ET | 80h |
| 199 | 8.5.9 | power cables lead time |  | 6w | 2004-01-01 | 2004-02-11 |  | 98.5d |  |  |  |
| 200 | 8.5.10 | batteries lead time |  | 4d | 2004-01-01 | 2004-01-06 |  | 124.5d |  |  |  |
| 201 | 8.6 | **integration and test** |  | 31d | 2004-01-01 | 2004-02-12 |  | 97.5d |  |  | 90.4h |
| 202 | 8.6.1 | chassis checkout |  | 1w | 2004-02-06 | 2004-02-12 | 198 | 97.5d |  | OSG; EE | 80h |
| 203 | 8.6.2 | solar panel test |  | 0.3d | 2004-01-01 | 2004-01-01 |  | 128.2d |  | OSG | 2.4h |
| 204 | 8.6.3 | battery box test |  | 1d | 2004-01-01 | 2004-01-01 |  | 127.5d |  | OSG | 8h |
| 205 | 8.7 | **test and debug** |  | 0d | 2004-01-01 | 2004-01-01 |  | 128.5d |  |  |  |
| 206 | 8.7.1 | none | milestone | 0d | 2004-01-01 | 2004-01-01 |  | 128.5d |  |  |  |
| 207 | 9 | **MMC** |  | 48d | 2004-01-01 | 2004-03-08 |  | 43.5d |  |  | 1448h |
| 208 | 9.1 | **analysis** |  | 0d | 2004-01-01 | 2004-01-01 |  | 128.5d |  |  |  |
| 209 | 9.1.1 | none | milestone | 0d | 2004-01-01 | 2004-01-01 |  | 128.5d |  |  |  |

Notes:
- 195: 7 types of boards, 3-4 wks min to do board build. Kit and build done outside.

| ID | WBS | Task | Type | Duration | Start | Finish | Predecessors | Total slack | Free slack | Resources | Work |
| --- | --- | --- | --- | --- | --- | --- | --- | --- | --- | --- | --- |
| 210 | 9.2 | **design** |  | 0d | 2004-01-01 | 2004-01-01 |  | 128.5d |  |  |  |
| 211 | 9.2.1 | none | milestone | 0d | 2004-01-01 | 2004-01-01 |  | 128.5d |  |  |  |
| 212 | 9.3 | **design review** |  | 0d | 2004-01-01 | 2004-01-01 |  | 128.5d |  |  |  |
| 213 | 9.3.1 | none | milestone | 0d | 2004-01-01 | 2004-01-01 |  | 128.5d |  |  |  |
| 214 | 9.4 | **purchasing** |  | 1d | 2004-01-01 | 2004-01-01 |  | 127.5d |  |  | 16h |
| 215 | 9.4.1 | purchase MMC mechanical parts |  | 1d | 2004-01-01 | 2004-01-01 |  | 127.5d |  | OSG | 8h |
| 216 | 9.4.2 | purchase MMC electrical parts |  | 1d | 2004-01-01 | 2004-01-01 |  | 127.5d |  | OSG | 8h |
| 217 | 9.4.3 | MMC bulkhead connectors | milestone | 0d | 2004-01-01 | 2004-01-01 |  | 128.5d |  |  |  |
| 218 | 9.4.4 | MMC housing | milestone | 0d | 2004-01-01 | 2004-01-01 |  | 128.5d |  |  |  |
| 219 | 9.4.5 | MMC housing lid | milestone | 0d | 2004-01-01 | 2004-01-01 |  | 128.5d |  |  |  |
| 220 | 9.4.6 | MMC chassis | milestone | 0d | 2004-01-01 | 2004-01-01 |  | 128.5d |  |  |  |
| 221 | 9.4.7 | MMC electronics parts (Sidearm, DPA, backplane,RFComms) | milestone | 0d | 2004-01-01 | 2004-01-01 |  | 128.5d |  |  |  |
| 222 | 9.4.8 | compass | milestone | 0d | 2004-01-01 | 2004-01-01 |  | 128.5d |  |  |  |
| 223 | 9.5 | **fab** |  | 39d | 2004-01-01 | 2004-02-24 |  | 43.5d |  |  | 1360h |
| 224 | 9.5.1 | **chassis (1+1 spare)** |  | 21d | 2004-01-01 | 2004-01-29 |  | 43.5d |  |  | 488h |
| 225 | 9.5.1.1 | MMC chassis endplates |  | 2w | 2004-01-01 | 2004-01-14 |  | 71.5d | 10d | EXT_VENDOR | 80h |
| 226 | 9.5.1.2 | MMC chassis rails |  | 4w | 2004-01-01 | 2004-01-28 |  | 61.5d | 0d | EXT_VENDOR | 160h |
| 227 | 9.5.1.3 | MMC chassis card guide |  | 3w | 2004-01-01 | 2004-01-21 |  | 43.5d | 0d | MA | 120h |
| 228 | 9.5.1.4 | MMC chassis clips |  | 3w | 2004-01-01 | 2004-01-21 |  | 66.5d | 5d | MA | 120h |
| 229 | 9.5.1.5 | MMC chassis assy |  | 1d | 2004-01-29 | 2004-01-29 | 225, 226, 227, 228 | 61.5d | 18d | OSG | 8h |
| 230 | 9.5.2 | **housing (1 + 1 spare)** |  | 20d | 2004-01-01 | 2004-01-28 |  | 58.5d |  |  | 344h |
| 231 | 9.5.2.1 | MMC housing machining |  | 4w | 2004-01-01 | 2004-01-28 |  | 108.5d |  | EXT_VENDOR | 160h |
| 232 | 9.5.2.2 | MMC housing brazing (incl shipping) |  | 2w | 2004-01-01 | 2004-01-14 |  | 118.5d |  | EXT_VENDOR | 80h |
| 233 | 9.5.2.3 | MMC housing anodization (incl shipping) |  | 2w | 2004-01-01 | 2004-01-14 |  | 118.5d |  | EXT_VENDOR | 80h |
| 234 | 9.5.2.4 | MMC housing QC (2x) |  | 1d | 2004-01-22 | 2004-01-22 | 227 | 43.5d | 0d | OSG | 8h |
| 235 | 9.5.2.5 | MMC housing pressure test |  | 2d | 2004-01-23 | 2004-01-26 | 234 | 43.5d | 0d | OSG | 16h |

| ID | WBS | Task | Duration | Start | Finish | Predecessors | Total slack | Free slack | Resources | Work |
| --- | --- | --- | --- | --- | --- | --- | --- | --- | --- | --- |
| 236 | 9.5.3 | **endcap (1 + 1 spare)** | 39d | 2004-01-01 | 2004-02-24 |  | 43.5d |  |  | 120h |
| 237 | 9.5.3.1 | MMC endcap machining | 3d | 2004-01-01 | 2004-01-05 |  | 78.5d | 35d | EXT_VENDOR | 24h |
| 238 | 9.5.3.2 | MMC endcap anodization (incl shipping) | 2w | 2004-01-01 | 2004-01-14 |  | 71.5d | 28d | EXT_VENDOR | 80h |
| 239 | 9.5.3.3 | MMC endcap QC (2x) | 1d | 2004-01-01 | 2004-01-01 |  | 80.5d | 37d | OSG | 8h |
| 240 | 9.5.3.4 | MMC bulkhead connectors lead time | 4w | 2004-01-27 | 2004-02-23 | 235 | 43.5d | 0d |  |  |
| 241 | 9.5.3.5 | MMC endcap assembly | 1d | 2004-02-24 | 2004-02-24 | 237, 238, 239, 240 | 43.5d | 0d | OSG | 8h |
| 242 | 9.5.4 | **DPA** | 4d | 2004-01-01 | 2004-01-06 |  | 78.5d |  |  | 40h |
| 243 | 9.5.4.1 | DPA kit | 1d | 2004-01-01 | 2004-01-01 |  | 79.5d | 1d | EXT_VENDOR | 8h |
| 244 | 9.5.4.2 | DPA board fab | 2d | 2004-01-01 | 2004-01-02 |  | 78.5d | 0d | EXT_VENDOR | 16h |
| 245 | 9.5.4.3 | DPA mount | 1d | 2004-01-05 | 2004-01-05 | 243, 244 | 78.5d | 0d | EXT_VENDOR | 8h |
| 246 | 9.5.4.4 | DPA test | 1d | 2004-01-06 | 2004-01-06 | 245 | 78.5d | 35d | OSG | 8h |
| 247 | 9.5.5 | **Backplane** | 4d | 2004-01-01 | 2004-01-06 |  | 78.5d |  |  | 40h |
| 248 | 9.5.5.1 | Backplane kit | 1d | 2004-01-01 | 2004-01-01 |  | 79.5d | 1d | EXT_VENDOR | 8h |
| 249 | 9.5.5.2 | Backplane board fab | 2d | 2004-01-01 | 2004-01-02 |  | 78.5d | 0d | EXT_VENDOR | 16h |
| 250 | 9.5.5.3 | Backplane mount | 1d | 2004-01-05 | 2004-01-05 | 248, 249 | 78.5d | 0d | EXT_VENDOR | 8h |
| 251 | 9.5.5.4 | Backplane test | 1d | 2004-01-06 | 2004-01-06 | 250 | 78.5d | 35d | OSG | 8h |
| 252 | 9.5.6 | **Sidearm** | 25d | 2004-01-01 | 2004-02-04 |  | 65.5d |  |  | 280h |
| 253 | 9.5.6.1 | Sidearm kit | 2w | 2004-01-01 | 2004-01-14 |  | 65.5d | 0d | EXT_VENDOR | 80h |
| 254 | 9.5.6.2 | Sidearm board fab | 2w | 2004-01-01 | 2004-01-14 |  | 65.5d | 0d | EXT_VENDOR | 80h |
| 255 | 9.5.6.3 | Sidearm mount | 1w | 2004-01-15 | 2004-01-21 | 253, 254 | 65.5d | 0d | EXT_VENDOR | 40h |
| 256 | 9.5.6.4 | Sidearm bringup/config | 2w | 2004-01-22 | 2004-02-04 | 255 | 65.5d | 22d | ET | 80h |
| 257 | 9.5.7 | **RFIO** | 5d | 2004-01-01 | 2004-01-07 |  | 85.5d |  |  | 48h |
| 258 | 9.5.7.1 | RFIO kit | 1d | 2004-01-01 | 2004-01-01 |  | 86.5d | 1d | EXT_VENDOR | 8h |
| 259 | 9.5.7.2 | RFIO board fab | 2d | 2004-01-01 | 2004-01-02 |  | 85.5d | 0d | EXT_VENDOR | 16h |
| 260 | 9.5.7.3 | RFIO mount | 1d | 2004-01-05 | 2004-01-05 | 258, 259 | 85.5d | 0d | EXT_VENDOR | 8h |
| 261 | 9.5.7.4 | RFIO test | 2d | 2004-01-06 | 2004-01-07 | 260 | 85.5d | 42d | OSG | 16h |

| ID | WBS | Task | Type | Duration | Start | Finish | Predecessors | Total slack | Free slack | Resources | Work |
| --- | --- | --- | --- | --- | --- | --- | --- | --- | --- | --- | --- |
| 262 | 9.5.8 | **Fiber Optic Switch** |  | 0d | 2004-01-01 | 2004-01-01 |  | 128.5d |  |  |  |
| 263 | 9.5.8.1 | need significant EE time to support build and test | milestone | 0d | 2004-01-01 | 2004-01-01 |  | 128.5d |  |  |  |
| 264 | 9.6 | MMC wiring harness, assembly (1+ 1 spare) |  | 8d | 2004-02-25 | 2004-03-05 | 229, 241, 246, 251 | 43.5d | 0d | OSG | 64h |
| 265 | 9.7 | **Integration and test** |  | 1d | 2004-03-08 | 2004-03-08 |  | 43.5d |  |  | 8h |
| 266 | 9.7.1 | MMC verify wiring (1 + 1 spare) |  | 1d | 2004-03-08 | 2004-03-08 | 264, 246, 256, 261 | 43.5d | 0d | OSG | 8h |
| 267 | 9.8 | **test and debug** |  | 0d | 2004-01-01 | 2004-01-01 |  | 128.5d |  |  |  |
| 268 | 9.8.1 | none | milestone | 0d | 2004-01-01 | 2004-01-01 |  | 128.5d |  |  |  |
| 269 | 10 | **Pucks** |  | 48.5d | 2004-01-01 | 2004-03-09 |  | 62d |  |  | 440h |
| 270 | 10.1 | **analysis** |  | 0d | 2004-01-01 | 2004-01-01 |  | 128.5d |  |  |  |
| 271 | 10.1.1 | none | milestone | 0d | 2004-01-01 | 2004-01-01 |  | 128.5d |  |  |  |
| 272 | 10.2 | **design** |  | 0d | 2004-01-01 | 2004-01-01 |  | 128.5d |  |  |  |
| 273 | 10.2.1 | none | milestone | 0d | 2004-01-01 | 2004-01-01 |  | 128.5d |  |  |  |
| 274 | 10.3 | **design review** |  | 0d | 2004-01-01 | 2004-01-01 |  | 128.5d |  |  |  |
| 275 | 10.3.1 | none | milestone | 0d | 2004-01-01 | 2004-01-01 |  | 128.5d |  |  |  |
| 276 | 10.4 | **purchasing** |  | 1d | 2004-01-01 | 2004-01-01 |  | 127.5d |  |  | 16h |
| 277 | 10.4.1 | purchase puck mechanical |  | 1d | 2004-01-01 | 2004-01-01 |  | 127.5d |  | OSG | 8h |
| 278 | 10.4.2 | purchase puck electrical |  | 1d | 2004-01-01 | 2004-01-01 |  | 127.5d |  | OSG | 8h |
| 279 | 10.4.3 | potted puck cables and connectors | milestone | 0d | 2004-01-01 | 2004-01-01 |  | 128.5d |  |  |  |
| 280 | 10.4.4 | puck housing tubes | milestone | 0d | 2004-01-01 | 2004-01-01 |  | 128.5d |  |  |  |
| 281 | 10.4.5 | puck housing bulkheads | milestone | 0d | 2004-01-01 | 2004-01-01 |  | 128.5d |  |  |  |
| 282 | 10.4.6 | puck housing board connectors | milestone | 0d | 2004-01-01 | 2004-01-01 |  | 128.5d |  |  |  |
| 283 | 10.4.7 | puck boards | milestone | 0d | 2004-01-01 | 2004-01-01 |  | 128.5d |  |  |  |
| 284 | 10.4.8 | puck electronics | milestone | 0d | 2004-01-01 | 2004-01-01 |  | 128.5d |  |  |  |
| 285 | 10.4.9 | test cable parts | milestone | 0d | 2004-01-01 | 2004-01-01 |  | 128.5d |  |  |  |

| ID | WBS | Task | Type | Duration | Start | Finish | Predecessors | Total slack | Free slack | Resources | Work |
| --- | --- | --- | --- | --- | --- | --- | --- | --- | --- | --- | --- |
| 286 | 10.5 | **fab** |  | 30d | 2004-01-01 | 2004-02-11 |  | 62d |  |  | 340h |
| 287 | 10.5.1 | puck board build |  | 2w | 2004-01-01 | 2004-01-14 |  | 75d | 0d | EXT_VENDOR | 80h |
| 288 | 10.5.2 | puck board test |  | 0.5d | 2004-01-01 | 2004-01-01 |  | 128d |  | ET | 4h |
| 289 | 10.5.3 | puck housing machining |  | 2w | 2004-01-01 | 2004-01-14 |  | 75d | 0d | EXT_VENDOR | 80h |
| 290 | 10.5.4 | puck bulkhead machining |  | 2w | 2004-01-01 | 2004-01-14 |  | 82d | 38.5d | EXT_VENDOR | 80h |
| 291 | 10.5.5 | puck test cable build |  | 1d | 2004-01-01 | 2004-01-01 |  | 90.5d | 47d | OSG | 8h |
| 292 | 10.5.6 | puck firmware changes |  | 1d | 2004-01-01 | 2004-01-01 |  | 90.5d | 47d | SE | 8h |
| 293 | 10.5.7 | puck mount machining |  | 2w | 2004-01-15 | 2004-01-28 | 289 | 108.5d |  | MA | 80h |
| 294 | 10.5.8 | puck cable and connector lead time |  | 6w | 2004-01-01 | 2004-02-11 |  | 62d | 18.5d |  |  |
| 295 | 10.6 | **assembly** |  | 7d | 2004-01-15 | 2004-01-23 |  | 75d |  |  | 56h |
| 296 | 10.6.1 | puck electronic assembly |  | 2d | 2004-01-15 | 2004-01-16 | 289, 287 | 75d | 0d | OSG | 16h |
| 297 | 10.6.2 | puck potting |  | 1w | 2004-01-19 | 2004-01-23 | 296 | 75d | 31.5d | OSG | 40h |
| 298 | 10.7 | **integration and test** |  | 48.5d | 2004-01-01 | 2004-03-09 |  | 80d |  |  | 28h |
| 299 | 10.7.1 | pressure test pucks |  | 3d | 2004-01-01 | 2004-01-05 |  | 125.5d |  | OSG | 24h |
| 300 | 10.7.2 | verify puck operation |  | 0.5d | 2004-03-09 | 2004-03-09 | 266, 287, 291, 292, 296 | 43.5d | 0d | SE | 4h |
| 301 | 10.7.3 | integration ready | milestone | 0d | 2004-03-09 | 2004-03-09 | 300, 289, 290, 294, 297, 296 | 43.5d |  |  |  |
| 302 | 10.8 | **test and debug** |  | 0d | 2004-01-01 | 2004-01-01 |  | 128.5d |  |  |  |
| 303 | 10.8.1 | none | milestone | 0d | 2004-01-01 | 2004-01-01 |  | 128.5d |  |  |  |
| 304 | 11 | **Pager Reset** |  | 31.5d | 2004-01-01 | 2004-02-13 |  | 97d |  |  | 262h |
| 305 | 11.1 | **analysis** |  | 0d | 2004-01-01 | 2004-01-01 |  | 128.5d |  |  |  |
| 306 | 11.1.1 | none | milestone | 0d | 2004-01-01 | 2004-01-01 |  | 128.5d |  |  |  |
| 307 | 11.2 | **design** |  | 0d | 2004-01-01 | 2004-01-01 |  | 128.5d |  |  |  |
| 308 | 11.2.1 | none | milestone | 0d | 2004-01-01 | 2004-01-01 |  | 128.5d |  |  |  |
| 309 | 11.3 | **design review** |  | 0d | 2004-01-01 | 2004-01-01 |  | 128.5d |  |  |  |
| 310 | 11.3.1 | none | milestone | 0d | 2004-01-01 | 2004-01-01 |  | 128.5d |  |  |  |

| ID | WBS | Task | Type | Duration | Start | Finish | Predecessors | Total slack | Free slack | Constraint | Resources | Work |
| --- | --- | --- | --- | --- | --- | --- | --- | --- | --- | --- | --- | --- |
| 311 | 11.4 | **purchasing** |  | 18d | 2004-01-01 | 2004-01-26 |  | 110.5d |  |  |  | 18h |
| 312 | 11.4.1 | purchase pager reset mechanical |  | 1d | 2004-01-26 | 2004-01-26 |  | 97d | 0d | start no earlier than 2004-01-26 | OSG | 8h |
| 313 | 11.4.2 | purchase pager reset electronics |  | 1d | 2004-01-01 | 2004-01-01 |  | 127.5d |  |  | OSG | 8h |
| 314 | 11.4.3 | pager service setup |  | 0.25d | 2004-01-01 | 2004-01-01 |  | 128.25d |  |  | OSG | 2h |
| 315 | 11.4.4 | pager reset board | milestone | 0d | 2004-01-01 | 2004-01-01 |  | 128.5d |  |  |  |  |
| 316 | 11.4.5 | pager reset housing | milestone | 0d | 2004-01-01 | 2004-01-01 |  | 128.5d |  |  |  |  |
| 317 | 11.4.6 | pager reset connectors | milestone | 0d | 2004-01-01 | 2004-01-01 |  | 128.5d |  |  |  |  |
| 318 | 11.4.7 | pager reset cable | milestone | 0d | 2004-01-01 | 2004-01-01 |  | 128.5d |  |  |  |  |
| 319 | 11.4.8 | pager reset mounts | milestone | 0d | 2004-01-01 | 2004-01-01 |  | 128.5d |  |  |  |  |
| 320 | 11.5 | **fab** |  | 30d | 2004-01-01 | 2004-02-11 |  | 98.5d |  |  |  | 232h |
| 321 | 11.5.1 | **housing** |  | 11d | 2004-01-27 | 2004-02-10 |  | 97d | 0d |  |  | 168h |
| 322 | 11.5.1.1 | pager reset housing machining |  | 2w | 2004-01-27 | 2004-02-09 | 312 | 97d | 0d |  | EXT_VENDOR | 80h |
| 323 | 11.5.1.2 | pager reset internal mounts |  | 2w | 2004-01-27 | 2004-02-09 | 312 | 97d | 0d |  | EXT_VENDOR | 80h |
| 324 | 11.5.1.3 | pager reset pressure test |  | 1d | 2004-02-10 | 2004-02-10 | 322, 323 | 97d |  |  | OSG | 8h |
| 325 | 11.5.2 | pager reset board build |  | 2d | 2004-01-19 | 2004-01-20 |  | 112d | 15d | start no earlier than 2004-01-19 | ET | 16h |
| 326 | 11.5.3 | pager reset electronics assy |  | 1d | 2004-02-11 | 2004-02-11 | 325, 321 | 97d | 0d |  | OSG | 8h |
| 327 | 11.5.4 | pager reset mounts |  | 1w | 2004-01-01 | 2004-01-07 |  | 123.5d |  |  | EXT_VENDOR | 40h |
| 328 | 11.6 | **assembly** |  | 1d | 2004-02-12 | 2004-02-12 |  | 97d |  |  |  | 8h |
| 329 | 11.6.1 | pager reset assembly |  | 1d | 2004-02-12 | 2004-02-12 | 326 | 97d | 0d |  | OSG | 8h |
| 330 | 11.7 | **integration and test** |  | 0.5d | 2004-02-13 | 2004-02-13 |  | 97d |  |  |  | 4h |
| 331 | 11.7.1 | pager reset verify operation |  | 0.5d | 2004-02-13 | 2004-02-13 | 329 | 97d |  |  | OSG | 4h |
| 332 | 11.8 | **test and debug** |  | 0d | 2004-01-01 | 2004-01-01 |  | 128.5d |  |  |  |  |
| 333 | 11.8.1 | none | milestone | 0d | 2004-01-01 | 2004-01-01 |  | 128.5d |  |  |  |  |
| 334 | 12 | **SIAM** |  | 9d | 2004-01-01 | 2004-01-13 |  | 119.5d |  |  |  | 216h |
| 335 | 12.1 | **analysis** |  | 0d | 2004-01-01 | 2004-01-01 |  | 128.5d |  |  |  |  |
| 336 | 12.1.1 | none | milestone | 0d | 2004-01-01 | 2004-01-01 |  | 128.5d |  |  |  |  |

| ID | WBS | Task | Type | Duration | Start | Finish | Predecessors | Total slack | Free slack | Resources | Work |
| --- | --- | --- | --- | --- | --- | --- | --- | --- | --- | --- | --- |
| 337 | 12.2 | **design** |  | 0d | 2004-01-01 | 2004-01-01 |  | 125.5d |  |  |  |
| 338 | 12.2.1 | none | milestone | 0d | 2004-01-01 | 2004-01-01 |  | 125.5d | 0d |  |  |
| 339 | 12.3 | **design review** |  | 0d | 2004-01-01 | 2004-01-01 |  | 128.5d |  |  |  |
| 340 | 12.3.1 | none | milestone | 0d | 2004-01-01 | 2004-01-01 |  | 128.5d |  |  |  |
| 341 | 12.4 | **purchasing** |  | 0d | 2004-01-01 | 2004-01-01 |  | 128.5d |  |  |  |
| 342 | 12.4.1 | none | milestone | 0d | 2004-01-01 | 2004-01-01 |  | 128.5d |  |  |  |
| 343 | 12.5 | **fab** |  | 0d | 2004-01-01 | 2004-01-01 |  | 125.5d |  |  |  |
| 344 | 12.5.1 | none | milestone | 0d | 2004-01-01 | 2004-01-01 | 338 | 125.5d | 0d |  |  |
| 345 | 12.6 | **assembly** |  | 1.5d | 2004-01-01 | 2004-01-02 |  | 127d |  |  | 32h |
| 346 | 12.6.1 | MMC setup |  | 1.5d | 2004-01-01 | 2004-01-02 |  | 127d |  | SE | 12h |
| 347 | 12.6.2 | PC setup |  | 1d | 2004-01-01 | 2004-01-01 |  | 127.5d |  | SE | 8h |
| 348 | 12.6.3 | SIAM software setup |  | 1.5d | 2004-01-01 | 2004-01-02 |  | 127d |  | SE | 12h |
| 349 | 12.7 | **integration and test** |  | 9d | 2004-01-01 | 2004-01-13 |  | 119.5d |  |  | 160h |
| 350 | 12.7.1 | SIAM radio test |  | 1d | 2004-01-01 | 2004-01-01 |  | 127.5d |  | SE | 8h |
| 351 | 12.7.2 | SIAM unit test |  | 2d | 2004-01-01 | 2004-01-02 |  | 126.5d |  | SE | 16h |
| 352 | 12.7.3 | SIAM nightly test operation and analysis |  | 1w | 2004-01-01 | 2004-01-07 |  | 123.5d |  | ST | 40h |
| 353 | 12.7.4 | SIAM data checks |  | 9d | 2004-01-01 | 2004-01-13 |  | 119.5d |  | SE | 72h |
| 354 | 12.7.5 | SIAM atp tests |  | 3d | 2004-01-01 | 2004-01-05 |  | 125.5d |  | SE | 24h |
| 355 | 12.8 | **test and debug** |  | 3d | 2004-01-01 | 2004-01-05 |  | 125.5d |  |  | 24h |
| 356 | 12.8.1 | SIAM inevitable junk |  | 3d | 2004-01-01 | 2004-01-05 | 344 | 125.5d |  | SE | 24h |
| 357 | 13 | **SSDS** |  | 92d | 2004-01-01 | 2004-05-10 |  | 36.5d |  |  | 168h |
| 358 | 13.1 | **analysis** |  | 0d | 2004-01-01 | 2004-01-01 |  | 128.5d |  |  |  |
| 359 | 13.1.1 | none | milestone | 0d | 2004-01-01 | 2004-01-01 |  | 128.5d |  |  |  |
| 360 | 13.2 | **design** |  | 0d | 2004-01-01 | 2004-01-01 |  | 128.5d |  |  |  |
| 361 | 13.2.1 | none | milestone | 0d | 2004-01-01 | 2004-01-01 |  | 128.5d |  |  |  |

| ID | WBS | Task | Type | Duration | Start | Finish | Predecessors | Total slack | Free slack | Constraint | Resources | Work |
| --- | --- | --- | --- | --- | --- | --- | --- | --- | --- | --- | --- | --- |
| 362 | 13.3 | **design review** |  | 0d | 2004-01-01 | 2004-01-01 |  | 128.5d |  |  |  |  |
| 363 | 13.3.1 | none | milestone | 0d | 2004-01-01 | 2004-01-01 |  | 128.5d |  |  |  |  |
| 364 | 13.4 | **purchasing** |  | 0d | 2004-01-01 | 2004-01-01 |  | 128.5d |  |  |  |  |
| 365 | 13.4.1 | none | milestone | 0d | 2004-01-01 | 2004-01-01 |  | 128.5d |  |  |  |  |
| 366 | 13.5 | **fab** |  | 60d | 2004-01-01 | 2004-03-24 |  | 68.5d |  |  |  | 136h |
| 367 | 13.5.1 | SSDS workarounds for TBD automation |  | 60d | 2004-01-01 | 2004-03-24 |  | 68.5d |  |  | IAG [10%] | 48h |
| 368 | 13.5.2 | SSDS device ID management | milestone | 0d | 2004-02-02 | 2004-02-02 |  | 95.5d | 0d | start no earlier than 2004-02-02 | IAG |  |
| 369 | 13.5.3 | SSDS QC plots impl | milestone | 0d | 2004-01-01 | 2004-01-01 |  | 128.5d |  |  | IAG |  |
| 370 | 13.5.4 | SSDS API impl | milestone | 0d | 2004-01-01 | 2004-01-01 |  | 128.5d |  |  | IAG |  |
| 371 | 13.5.5 | SSDS external access impl | milestone | 0d | 2004-01-01 | 2004-01-01 |  | 128.5d |  |  | IAG |  |
| 372 | 13.5.6 | SSDS metadata input impl |  | 11d | 2004-02-02 | 2004-02-16 | 505, 368 | 95.5d |  |  | IAG | 88h |
| 373 | 13.6 | **assembly** |  | 0d | 2004-01-01 | 2004-01-01 |  | 128.5d |  |  |  |  |
| 374 | 13.6.1 | none | milestone | 0d | 2004-01-01 | 2004-01-01 |  | 128.5d |  |  |  |  |
| 375 | 13.7 | **integration and test** |  | 92d | 2004-01-01 | 2004-05-10 |  | 36.5d |  |  |  | 32h |
| 376 | 13.7.1 | SSDS data stream checkout |  | 2d | 2004-01-01 | 2004-01-02 |  | 126.5d |  |  | IAG | 16h |
| 377 | 13.7.2 | SSDS server setup and maintenance I&T |  | 2d | 2004-02-02 | 2004-02-03 |  | 104.5d |  | start no earlier than 2004-02-01 | IAG | 16h |
| 378 | 13.7.3 | SSDS/SIAM interface testing I&T | milestone | 0d | 2004-05-10 | 2004-05-10 | 484SS | 36.5d |  |  | IAG |  |
| 379 | 13.8 | **test and debug** |  | 0d | 2004-01-01 | 2004-01-01 |  | 128.5d |  |  |  |  |
| 380 | 13.8.1 | SSDS device ID management T/D | milestone | 0d | 2004-01-01 | 2004-01-01 |  | 128.5d |  |  | IAG |  |
| 381 | 13.8.2 | SSDS QC plots T/D | milestone | 0d | 2004-01-01 | 2004-01-01 |  | 128.5d |  |  | IAG |  |
| 382 | 13.8.3 | SSDS API T/D | milestone | 0d | 2004-01-01 | 2004-01-01 |  | 128.5d |  |  | IAG |  |
| 383 | 13.8.4 | SSDS external access T/D | milestone | 0d | 2004-01-01 | 2004-01-01 |  | 128.5d |  |  | IAG |  |
| 384 | 13.8.5 | SSDS metadata input T/D | milestone | 0d | 2004-01-01 | 2004-01-01 |  | 128.5d |  |  | IAG |  |
| 385 | 14 | **Instrumentation** |  | 105d | 2004-01-01 | 2004-05-25 |  | 0d |  |  |  | 452h |
| 386 | 14.1 | **analysis** |  | 0d | 2004-01-01 | 2004-01-01 |  | 128.5d |  |  |  |  |
| 387 | 14.1.1 | none | milestone | 0d | 2004-01-01 | 2004-01-01 |  | 128.5d |  |  |  |  |

| ID | WBS | Task | Type | Duration | Start | Finish | Predecessors | Total slack | Free slack | Constraint | Resources | Work |
| --- | --- | --- | --- | --- | --- | --- | --- | --- | --- | --- | --- | --- |
| 388 | 14.2 | **design** |  | 91d | 2004-01-12 | 2004-05-17 |  | 30.5d |  |  |  | 136h |
| 389 | 14.2.1 | design instrument cable and connectors |  | 6d | 2004-01-12 | 2004-01-19 | 505 | 110.5d | 0d |  | OSG | 48h |
| 390 | 14.2.2 | design monster cable |  | 3d | 2004-01-20 | 2004-01-22 | 389 | 110.5d | 0d |  | OSG | 24h |
| 391 | 14.2.3 | design instrument mounts |  | 8d | 2004-05-06 | 2004-05-17 | 438 | 30.5d |  |  | ME | 64h |
| 392 | 14.3 | **design review** |  | 2d | 2004-01-23 | 2004-01-26 |  | 110.5d |  |  |  | 16h |
| 393 | 14.3.1 | review instrument cable and connectors |  | 2d | 2004-01-23 | 2004-01-26 | 390 | 110.5d |  |  | OSG | 16h |
| 394 | 14.4 | **purchasing** |  | 50d | 2004-01-01 | 2004-03-10 |  | 0d |  |  |  | 36h |
| 395 | 14.4.1 | inventory instrument cables and connectors |  | 1d | 2004-01-01 | 2004-01-01 |  | 127.5d |  |  | OSG | 8h |
| 396 | 14.4.2 | purchase instruments |  | 50d | 2004-01-01 | 2004-03-10 |  | 0d |  |  | OSG [2%] | 8h |
| 397 | 14.4.3 | purchase instrument cables and connectors |  | 50d | 2004-01-01 | 2004-03-10 |  | 5d | 0d |  | OSG [5%] | 20h |
| 398 | 14.4.4 | Metsys | milestone | 0d | 2004-01-01 | 2004-01-01 |  | 128.5d |  |  |  |  |
| 399 | 14.4.5 | ADCP | milestone | 0d | 2004-01-01 | 2004-01-01 |  | 128.5d |  |  |  |  |
| 400 | 14.4.6 | Serial CTD | milestone | 0d | 2004-01-01 | 2004-01-01 |  | 128.5d |  |  |  |  |
| 401 | 14.4.7 | Inductive CTD 10m,20m,40m,60m | milestone | 0d | 2004-01-01 | 2004-01-01 |  | 128.5d |  |  |  |  |
| 402 | 14.4.8 | Inductive Modem | milestone | 0d | 2004-01-01 | 2004-01-01 |  | 128.5d |  |  |  |  |
| 403 | 14.4.9 | Inductive Coupler | milestone | 0d | 2004-01-01 | 2004-01-01 |  | 128.5d |  |  |  |  |
| 404 | 14.4.10 | Nitrate | milestone | 0d | 2004-01-01 | 2004-01-01 |  | 128.5d |  |  |  |  |
| 405 | 14.4.11 | CO2 | milestone | 0d | 2004-01-01 | 2004-01-01 |  | 128.5d |  |  |  |  |
| 406 | 14.4.12 | Radiometers | milestone | 0d | 2004-01-01 | 2004-01-01 |  | 128.5d |  |  |  |  |
| 407 | 14.4.13 | Fluorometer | milestone | 0d | 2004-01-01 | 2004-01-01 |  | 128.5d |  |  |  |  |
| 408 | 14.4.14 | Backscatter | milestone | 0d | 2004-01-01 | 2004-01-01 |  | 128.5d |  |  |  |  |
| 409 | 14.4.15 | Locator | milestone | 0d | 2004-01-01 | 2004-01-01 |  | 128.5d |  |  |  |  |
| 410 | 14.4.16 | GPS | milestone | 0d | 2004-01-01 | 2004-01-01 |  | 128.5d |  |  |  |  |
| 411 | 14.5 | **fab** |  | 92d | 2004-01-01 | 2004-05-07 |  | 36.5d |  |  |  | 144h |
| 412 | 14.5.1 | instrument order lead time |  | 6w | 2004-03-11 | 2004-04-21 | 396 | 0d |  |  |  |  |
| 413 | 14.5.2 | instrument calibration time |  | 2w | 2004-04-22 | 2004-05-05 | 412 | 0d |  | start no earlier than 2004-01-30 |  |  |
| 414 | 14.5.3 | instrument cable and connector lead time |  | 6w | 2004-03-11 | 2004-04-21 | 397 | 5d | 0d |  |  |  |
| 415 | 14.5.4 | build instrument cables |  | 5d | 2004-04-22 | 2004-04-28 | 414 | 5d |  |  | ET | 40h |
| 416 | 14.5.5 | monster cable lead time |  | 6w | 2004-01-01 | 2004-02-11 |  | 57d | 0d |  |  |  |
| 417 | 14.5.6 | build monster cable |  | 1w | 2004-02-12 | 2004-02-18 | 416 | 57d |  |  | OSG | 40h |
| 418 | 14.5.7 | test instrument cables |  | 2d | 2004-05-06 | 2004-05-07 | 415, 413 | 0d |  |  | OSG | 16h |

| ID | WBS | Task | Type | Duration | Start | Finish | Predecessors | Total slack | Free slack | Resources | Work |
| --- | --- | --- | --- | --- | --- | --- | --- | --- | --- | --- | --- |
| 419 | 14.5.8 | **mounts** |  | 5d | 2004-01-01 | 2004-01-07 |  | 123.5d |  |  | 48h |
| 420 | 14.5.8.1 | inventory instrument mounts |  | 1d | 2004-01-01 | 2004-01-01 |  | 127.5d |  | OSG | 8h |
| 421 | 14.5.8.2 | radiometer mounts | milestone | 0d | 2004-01-01 | 2004-01-01 |  | 128.5d |  |  |  |
| 422 | 14.5.8.3 | SOON mounts | milestone | 0d | 2004-01-01 | 2004-01-01 |  | 128.5d |  |  |  |
| 423 | 14.5.8.4 | nitrate mounts | milestone | 0d | 2004-01-01 | 2004-01-01 |  | 128.5d |  |  |  |
| 424 | 14.5.8.5 | other instrument mounts fab |  | 1w | 2004-01-01 | 2004-01-07 |  | 123.5d |  | MA | 40h |
| 425 | 14.5.9 | SOON battery housings | milestone | 0d | 2004-01-01 | 2004-01-01 |  | 128.5d |  |  |  |
| 426 | 14.5.10 | **software** |  | 0d | 2004-01-01 | 2004-01-01 |  | 128.5d |  |  |  |
| 427 | 14.5.10.1 | Metsys service | milestone | 0d | 2004-01-01 | 2004-01-01 |  | 128.5d |  |  |  |
| 428 | 14.5.10.2 | ADCP service | milestone | 0d | 2004-01-01 | 2004-01-01 |  | 128.5d |  |  |  |
| 429 | 14.5.10.3 | Serial CTD service | milestone | 0d | 2004-01-01 | 2004-01-01 |  | 128.5d |  |  |  |
| 430 | 14.5.10.4 | Inductive CTD service | milestone | 0d | 2004-01-01 | 2004-01-01 |  | 128.5d |  |  |  |
| 431 | 14.5.10.5 | Nitrate service | milestone | 0d | 2004-01-01 | 2004-01-01 |  | 128.5d |  |  |  |
| 432 | 14.5.10.6 | CO2 service | milestone | 0d | 2004-01-01 | 2004-01-01 |  | 128.5d |  |  |  |
| 433 | 14.5.10.7 | Radiometer service | milestone | 0d | 2004-01-01 | 2004-01-01 |  | 128.5d |  |  |  |
| 434 | 14.5.10.8 | Fluorometer service | milestone | 0d | 2004-01-01 | 2004-01-01 |  | 128.5d |  |  |  |
| 435 | 14.5.10.9 | Backscatter service | milestone | 0d | 2004-01-01 | 2004-01-01 |  | 128.5d |  |  |  |
| 436 | 14.5.10.10 | metadata specification | milestone | 0d | 2004-01-01 | 2004-01-01 |  | 128.5d |  | SE |  |
| 437 | 14.6 | **integration and test** |  | 15d | 2004-05-05 | 2004-05-25 |  | 23.5d |  |  | 120h |
| 438 | 14.6.1 | instruments and test cables available | milestone | 0d | 2004-05-05 | 2004-05-05 | 414, 413 | 23.5d | 0d |  |  |
| 439 | 14.6.2 | software/electrical instrument integration |  | 15d | 2004-05-06 | 2004-05-25 | 438 | 23.5d |  | SE | 120h |
| 440 | 14.7 | **test and debug** |  | 0d | 2004-01-01 | 2004-01-01 |  | 128.5d |  |  |  |
| 441 | 14.7.1 | none | milestone | 0d | 2004-01-01 | 2004-01-01 |  | 128.5d |  |  |  |
| 442 | 15 | **RF Infrastructure** |  | 113d | 2004-01-01 | 2004-06-04 |  | 15.5d |  |  | 532h |
| 443 | 15.1 | **analysis** |  | 5d | 2004-01-01 | 2004-01-07 |  | 123.5d |  |  |  |
| 444 | 15.1.1 | radio infrastructure specification (radios and antennas) |  | 1w | 2004-01-01 | 2004-01-07 |  | 123.5d |  |  |  |

| ID | WBS | Task | Type | Duration | Start | Finish | Predecessors | Total slack | Free slack | Resources | Work |
| --- | --- | --- | --- | --- | --- | --- | --- | --- | --- | --- | --- |
| 445 | 15.2 | **design** |  | 2d | 2004-01-01 | 2004-01-02 |  | 126.5d |  |  |  |
| 446 | 15.2.1 | design radio housing |  | 2d | 2004-01-01 | 2004-01-02 |  | 126.5d |  |  |  |
| 447 | 15.2.2 | design radio cabling and connectors |  | 2d | 2004-01-01 | 2004-01-02 |  | 126.5d |  |  |  |
| 448 | 15.3 | **design review** |  | 0d | 2004-01-01 | 2004-01-01 |  | 128.5d |  |  |  |
| 449 | 15.3.1 | none | milestone | 0d | 2004-01-01 | 2004-01-01 |  | 128.5d |  |  |  |
| 450 | 15.4 | **purchasing** |  | 1d | 2004-01-01 | 2004-01-01 |  | 127.5d |  |  | 16h |
| 451 | 15.4.1 | purchase RF electrical |  | 1d | 2004-01-01 | 2004-01-01 |  | 127.5d |  | SUE | 8h |
| 452 | 15.4.2 | purchase RF mechanical |  | 1d | 2004-01-01 | 2004-01-01 |  | 127.5d |  | SUE | 8h |
| 453 | 15.4.3 | radio housing | milestone | 0d | 2004-01-01 | 2004-01-01 |  | 128.5d |  |  |  |
| 454 | 15.4.4 | radio mounts | milestone | 0d | 2004-01-01 | 2004-01-01 |  | 128.5d |  |  |  |
| 455 | 15.4.5 | cables and connectors | milestone | 0d | 2004-01-01 | 2004-01-01 |  | 128.5d |  |  |  |
| 456 | 15.4.6 | radios | milestone | 0d | 2004-01-01 | 2004-01-01 |  | 128.5d |  |  |  |
| 457 | 15.4.7 | antennas | milestone | 0d | 2004-01-01 | 2004-01-01 |  | 128.5d |  |  |  |
| 458 | 15.5 | **fab** |  | 30.5d | 2004-01-01 | 2004-02-12 |  | 94d |  |  | 372h |
| 459 | 15.5.1 | radio lead time |  | 3d | 2004-01-01 | 2004-01-05 |  | 121.5d | 27.5d |  |  |
| 460 | 15.5.2 | antenna lead time |  | 3d | 2004-01-01 | 2004-01-05 |  | 121.5d | 27.5d |  |  |
| 461 | 15.5.3 | radio housings and mounts machining |  | 2w | 2004-01-01 | 2004-01-14 |  | 117.5d | 0d | EXT_VENDOR | 80h |
| 462 | 15.5.4 | radio cables and connectors fab |  | 6w | 2004-01-01 | 2004-02-11 |  | 94d | 0d | EXT_VENDOR | 240h |
| 463 | 15.5.5 | test RF cables |  | 0.5d | 2004-02-12 | 2004-02-12 | 462 | 94d | 0d | SUE | 4h |
| 464 | 15.5.6 | radio can mounts machining |  | 1w | 2004-01-01 | 2004-01-07 |  | 123.5d |  | EXT_VENDOR | 40h |
| 465 | 15.5.7 | radio housing vacuum test |  | 1d | 2004-01-15 | 2004-01-15 | 461 | 117.5d |  | SUE | 8h |
| 466 | 15.6 | **assembly** |  | 32.5d | 2004-01-01 | 2004-02-16 |  | 96d |  |  | 24h |
| 467 | 15.6.1 | shore side RF installation |  | 2d | 2004-02-12 | 2004-02-16 | 459, 460, 463 | 94d | 64.5d | SUE | 16h |
| 468 | 15.6.2 | ship RF installation |  | 1d | 2004-01-01 | 2004-01-01 |  | 127.5d |  | OSG | 8h |

| ID | WBS | Task | Type | Duration | Start | Finish | Predecessors | Total slack | Free slack | Constraint | Resources | Work |
| --- | --- | --- | --- | --- | --- | --- | --- | --- | --- | --- | --- | --- |
| 469 | 15.7 | **integration and test** |  | 21d | 2004-05-10 | 2004-06-04 |  | 15.5d |  |  |  | 120h |
| 470 | 15.7.1 | radio/SIAM integration test |  | 1w | 2004-05-10 | 2004-05-14 | 484SS | 29.5d | 0d |  | SE; SUE | 80h |
| 471 | 15.7.2 | RF link quality monitoring |  | 10d | 2004-05-24 | 2004-06-04 |  | 15.5d |  | start no earlier than 2004-05-24 | SUE [10%] | 8h |
| 472 | 15.7.3 | RF infrastructure end to end test |  | 2d | 2004-05-17 | 2004-05-18 | 470, 467 | 29.5d |  |  | SE; SUE | 32h |
| 473 | 15.8 | **test and debug** |  | 0d | 2004-01-01 | 2004-01-01 |  | 128.5d |  |  |  |  |
| 474 | 15.8.1 | none | milestone | 0d | 2004-01-01 | 2004-01-01 |  | 128.5d |  |  |  |  |
| 475 | 16 | **Integration and Test** |  | 63d | 2004-03-31 | 2004-06-24 |  | 1.5d |  |  |  | 648h |
| 476 | 16.1 | attach bridle to float |  | 1d | 2004-03-31 | 2004-04-01 | 25, 62, 13 | 38.5d | 0d |  | MT | 8h |
| 477 | 16.2 | attach tower to float |  | 1d | 2004-04-14 | 2004-04-14 | 25, 44, 13 | 29d | 0d |  | MT | 8h |
| 478 | 16.3 | install elevator |  | 2d | 2004-04-15 | 2004-04-16 | 476, 86, 477 | 51.5d |  |  | OSG | 16h |
| 479 | 16.4 | solar panel install |  | 2d | 2004-04-15 | 2004-04-16 | 188, 477 | 39d | 0d |  | MT | 16h |
| 480 | 16.5 | solar panel door fitting |  | 1w | 2004-04-19 | 2004-04-23 | 477, 479 | 39d | 0d |  | MA | 40h |
| 481 | 16.6 | battery box install |  | 1d | 2004-04-15 | 2004-04-15 | 178, 177, 477 | 45d | 6d |  | OSG | 8h |
| 482 | 16.7 | load dump install |  | 0.5d | 2004-04-01 | 2004-04-01 | 183, 476 | 55d | 16d |  | OSG | 4h |
| 483 | 16.8 | power system wiring |  | 2d | 2004-04-26 | 2004-04-27 | 480, 481, 482 | 39d |  |  |  |  |
| 484 | 16.9 | open can test |  | 6d | 2004-05-10 | 2004-05-17 | 301, 266, 412, 413, 417, 418 | 0d |  |  | SCI_TECH; SE | 96h |
| 485 | 16.10 | closed can test |  | 6d | 2004-05-18 | 2004-05-24 | 484 | 0d |  |  | SCI_TECH; SE | 96h |
| 486 | 16.11 | instrument rough installation |  | 3d | 2004-05-25 | 2004-05-27 | 485, 476, 477 | 0d |  |  | OSG | 24h |
| 487 | 16.12 | instrument clamp mods |  | 3d | 2004-05-28 | 2004-06-01 | 486 | 0d |  |  | MT | 24h |
| 488 | 16.13 | instrument painting |  | 2d | 2004-06-02 | 2004-06-03 | 487 | 0d |  |  | OSG [200%] | 32h |
| 489 | 16.14 | instrument final mount |  | 4d | 2004-06-04 | 2004-06-09 | 488 | 0d |  |  | OSG [200%] | 64h |
| 490 | 16.15 | instrument cable dressing |  | 4d | 2004-06-10 | 2004-06-15 | 489 | 0d |  |  | OSG [200%] | 64h |
| 491 | 16.16 | instrument final paint |  | 3d | 2004-06-16 | 2004-06-18 | 490 | 0d |  |  | OSG [200%] | 48h |
| 492 | 16.17 | test accoustic releases |  | 0.5d | 2004-03-31 | 2004-03-31 | 97, 100 | 64d |  | start no earlier than 2004-03-08 | OSG | 4h |
| 493 | 16.18 | final system checkout |  | 4d | 2004-06-21 | 2004-06-24 | 491, 483 | 0d |  |  | SCI_TECH; OSG; SE | 96h |

| ID | WBS | Task | Type | Duration | Start | Finish | Predecessors | Total slack | Free slack | Constraint | Resources | Work |
| --- | --- | --- | --- | --- | --- | --- | --- | --- | --- | --- | --- | --- |
| 494 | 17 | **Deployment** |  | 16.5d | 2004-06-04 | 2004-06-28 |  | 0d |  |  |  | 52h |
| 495 | 17.1 | move to dock |  | 1d | 2004-06-25 | 2004-06-25 | 493 | 0d |  |  | OSG [400%] | 32h |
| 496 | 17.2 | load pt sur |  | 0.25d | 2004-06-28 | 2004-06-28 | 495 | 0d |  |  | OSG [400%] | 8h |
| 497 | 17.3 | deploy |  | 0.25d | 2004-06-28 | 2004-06-28 | 496 | 0d |  |  | OSG [400%] | 8h |
| 498 | 17.4 | unload |  | 0.12d | 2004-06-04 | 2004-06-04 |  | 16.38d |  | start no earlier than 2004-06-04 | OSG [400%] | 4h |
| 499 | 17.5 | sensor cleaning | milestone | 0d | 2004-06-07 | 2004-06-07 |  | 15.5d |  | start no earlier than 2004-06-07 | OSG |  |
| 500 | 17.6 | disassemble buoy | milestone | 0d | 2004-06-07 | 2004-06-07 |  | 15.5d |  | start no earlier than 2004-06-07 | OSG |  |
| 501 | 17.7 | instrument data transfer | milestone | 0d | 2004-06-07 | 2004-06-07 |  | 15.5d |  | start no earlier than 2004-06-07 | OSG |  |
| 502 | 17.8 | instrument post calibration | milestone | 0d | 2004-06-07 | 2004-06-07 |  | 15.5d |  | start no earlier than 2004-06-07 | OSG |  |
| 503 | 18 | **Systems Engineering** |  | 118d | 2004-01-01 | 2004-06-11 |  | 10.5d |  |  |  | 576h |
| 504 | 18.1 | initial config meeting | milestone | 0d | 2004-01-01 | 2004-01-01 |  | 128.5d |  | start no earlier than 2004-01-01 |  |  |
| 505 | 18.2 | configuration freeze | milestone | 0d | 2004-01-12 | 2004-01-12 |  | 110.5d | 0d | start no earlier than 2004-01-12 |  |  |
| 506 | 18.3 | scheduling |  | 20w | 2004-01-01 | 2004-05-19 |  | 28.5d |  |  | OSG [5%] | 40h |
| 507 | 18.4 | requirements gathering and review |  | 20w | 2004-01-01 | 2004-05-19 |  | 28.5d |  |  | OSG [5%] | 40h |
| 508 | 18.5 | **design** |  | 5d | 2004-01-01 | 2004-01-07 |  | 123.5d |  |  |  | 120h |
| 509 | 18.5.1 | single line diagram and instrument list |  | 1w | 2004-01-01 | 2004-01-07 |  | 123.5d |  |  | SYS_ENG | 40h |
| 510 | 18.5.2 | power budget |  | 1w | 2004-01-01 | 2004-01-07 |  | 123.5d |  |  | SYS_ENG | 40h |
| 511 | 18.5.3 | data and telemetry budget |  | 1w | 2004-01-01 | 2004-01-07 |  | 123.5d |  |  | SYS_ENG | 40h |
| 512 | 18.6 | **design review** |  | 4d | 2004-01-01 | 2004-01-06 |  | 124.5d |  |  |  | 40h |
| 513 | 18.6.1 | review of connectors and penetrations |  | 1d | 2004-01-01 | 2004-01-01 |  | 127.5d |  |  | SYS_ENG | 8h |
| 514 | 18.6.2 | readiness reviews |  | 4d | 2004-01-01 | 2004-01-06 |  | 124.5d |  |  | SYS_ENG | 32h |
| 515 | 18.7 | instrument data stream monitoring |  | 3d | 2004-01-01 | 2004-01-05 |  | 125.5d |  |  | SCI_TECH; SE; OSG | 72h |
| 516 | 18.8 | power system data monitoring |  | 20d | 2004-05-18 | 2004-06-11 | 484 | 10.5d |  | start no earlier than 2004-04-01 | EE [5%]; OSG [5%]; SE [5%] | 24h |
| 517 | 18.9 | mmc/engr data monitoring |  | 1d | 2004-01-01 | 2004-01-01 |  | 127.5d |  |  | SYS_ENG; OSG | 16h |
| 518 | 18.10 | Status meetings |  | 1w | 2004-01-01 | 2004-01-07 |  | 123.5d |  |  | SYS_ENG | 40h |
| 519 | 18.11 | post deployment meeting |  | 0.5d | 2004-01-01 | 2004-01-01 |  | 128d |  |  | SYS_ENG | 4h |
| 520 | 18.12 | other meetings |  | 1w | 2004-01-01 | 2004-01-07 |  | 123.5d |  |  | SYS_ENG | 40h |
| 521 | 18.13 | overhead |  | 3d | 2004-01-01 | 2004-01-05 |  | 125.5d |  |  | SYS_ENG | 24h |
| 522 | 18.14 | supervise machine shop |  | 100d | 2004-01-01 | 2004-05-19 |  | 28.5d |  |  | OSG [2%] | 16h |
| 523 | 18.15 | outside mechanical P.O.s |  | 55d | 2004-01-01 | 2004-03-17 |  | 73.5d |  |  | OSG [10%] | 44h |
| 524 | 18.16 | mechanical material orders |  | 100d | 2004-01-01 | 2004-05-19 |  | 28.5d |  |  | OSG [5%] | 40h |
| 525 | 18.17 | buoy parts inventory |  | 2d | 2004-01-01 | 2004-01-02 |  | 126.5d |  |  | OSG | 16h |

| ID | WBS | Task | Duration | Start | Finish | Total slack | Constraint | Resources | Work |
| --- | --- | --- | --- | --- | --- | --- | --- | --- | --- |
| 526 | 19 | **Documentation** | 50d | 2004-01-15 | 2004-03-24 | 68.5d |  |  | 80h |
| 527 | 19.1 | mechanical drawings | 10w | 2004-01-15 | 2004-03-24 | 68.5d | start no earlier than 2004-01-15 | ME [20%] | 80h |
| 528 | 20 | Publications | 1d | 2004-01-01 | 2004-01-01 | 127.5d |  |  |  |
| 529 | 21 | **Administration** | 2d | 2004-02-02 | 2004-02-03 | 104.5d |  |  | 16h |
| 530 | 21.1 | permitting (sanctuary, CG) | 2d | 2004-02-02 | 2004-02-03 | 104.5d | start no earlier than 2004-02-01 | OSG | 16h |
